# 3GPP_Release-2000

Schedule from MS Project, 2000-01-01 to 2009-12-25, A marks actual dates.

## Calendars

- Standard: Mon-Fri 08:00-12:00, 13:00-17:00; Sat-Sun off.

## Resources

| Resource |
| --- |
| NP |
| N1 |
| N2 |
| N3 |
| N4 |
| N5 |
| TP |
| T1 |
| T2 |
| T3 |
| RP |
| R1 |
| R2 |
| R3 |
| R4 |
| SP |
| S1 |
| S2 |
| S3 |
| S4 |
| S5 |
| PCG |
| GP |
| No |
| CN4 |
| ? |
| WG G2 |
| G2 |
| G1 |
| G4 |
| G3 |
| All |
| Generic |
| MLST |
| G5 |
| S3, G2 |
| WG T2 |
| GP,G1 |
| G4,G5 |
| OMA |
| GP-G2 |
| Yes |
| GP, |
| N4, |
| GP, N1 |
| CT5 |
| C5 |
| C1 |
| C4 |
| C3 |
| C6 |
| G1, |
| 4 |
| ct |
| c,s,r |
| CT,RAN,SA |
| G2, |
| G1, G3 |
| CT6 |
| CT1 |
| CT1, CT3, CT4 |
| C1, C3, C4 |
| CP |
| R5 |
| C |
| Rel-8 |
| GP, G2 |
| R1,R4 |
| S5,C1 |
| CT,RAN,SA,GERAN |
| S3,C1,C4 |
| 5 |
| S1,C1,C3,C4,S5 |
| S1,C1,C3,C5 |
| S1,C1,C3,C4 |
| S1,S5 |
| S2,S3 |
| RAN,SA |
| RP,S5 |
| S2,CT |
| S1,CT |
| S1,CT,GERAN |
| S1,C5 |
| S3,CT |
| S4,CT |
| C1,SA |
| S1,S2 |
| S1,S4 |
| S2,S2,S3,CT |
| S2,S3,CT |
| S1,CT,GX |
| S1,S4,CT |
| S2,S2,S3,S5,CT |
| S1,S2,CT |
| S1,S2,S3,CT |
| S1,S2,S3,S5CT |
| S1,S2,S3,S5,CT |
| S2,S5,CT |
| S4,S3 |
| S1,C1 |
| CP,C1 |
| C1,C3 |
| C1,C3,C4 |
| S1,S5,CT |
| C4,C3 |
| CP,RAN,SA,GERAN |
| S1,S2,S3,S5,CP |
| S2,S3,CP |
| S2,CP |
| S1,CP,GX |
| S1,CP |
| S1,S4,CP |
| S1,S2,CP |
| S1,S2,S3,CP |
| S2,S5,CP |
| S3,CP |
| S1,S5,CP |
| RAN,SA,GERAN |
| S1,S2,S3,S5,C1,C3,C4,C6 |
| S2,S3,C1,C3,C4 |
| S2,C4 |
| S2,C1,C3,C4 |
| S2,C1,C4 |
| S2,S3,C1,C4 |
| S1,C1,C4,G2 |
| C1,C4 |
| S1,C1,C3 |
| S1,S4,C1,C3,C4 |
| S1,S2,S3,C1,C3,C4 |
| S2,S5,C3 |
| S1,S2,C1,C4 |
| S2,C1 |
| S2,C1,C3 |
| S3,C1,C3,C4 |
| S1,S5,C1,C3,C4 |
| S2,C3,C4 |
| C3,C1 |
| R2,R4 |
| R2,R5 |
| RP,R5 |
| RP,S5,R5 |
| R1,R5 |
| S1,C1,R5 |
| S1,C1,S4,R5 |
| GERAN |
| G3new |
| G1, G3new |
| C4,C1,C3 |
| R1.R4 |
| R1, R4 |
| R2,R3 |
| C3,C4 |
| S4,C3 |
| S4,C3,C1,C4 |
| S1,S2,C1 |
| S1,S2<C1,C3,C4 |
| S1,S2,C1,C3,C4 |
| S5,C1,C3,C4 |
| GP,C4 |
| C4,C1 |
| S2,S1 |
| RP,SP,GP |
| RP,SP,CP,GP |
| CP,GP,RP,SP |
| GP,C4,S4 |

## Schedule

| ID | WBS | Task | Type | Duration | Start | Finish | Complete | Remaining | Baseline start | Baseline finish | Baseline duration | Total slack | Constraint | Resources | Work | Actual work | Text9 | Text6 | Text1 | Text4 | Text5 | Text8 |
| --- | --- | --- | --- | --- | --- | --- | --- | --- | --- | --- | --- | --- | --- | --- | --- | --- | --- | --- | --- | --- | --- | --- |
| 1 | 1 | VERSION 2008 June 17th |  | 1d | 2000-01-03 | 2000-01-03 |  |  | 2000-01-03 | 2000-01-03 | 1d | 2604d | start no earlier than 2000-01-01 |  |  |  | 2044 |  |  |  |  |  |
| 2 | 2 | "CTRL + a" to display all the 3GPP fields |  | 1d | 2000-01-03 | 2000-01-03 |  |  | 2000-01-03 | 2000-01-03 | 1d | 2604d | start no earlier than 2000-01-01 |  |  |  | 1462 |  |  |  |  |  |
| 3 | 3 | Content of Rel-8 (Stage 1, SA2/3 Stage 2 frozen, few exceptions) |  | 1d | 2000-01-03 | 2000-01-03 |  |  | 2000-01-03 | 2000-01-03 | 1d | 2604d | start no earlier than 2000-01-01 |  |  |  | 2058 |  |  |  |  |  |
| 4 | 4 | Gantt: dark blue=done; light blue=to be done; grey: previous values; black=summary |  | 1d? | 2000-01-03 | 2000-01-03 |  |  | 2000-01-03 | 2000-01-03 | 1d? | 2604d | start no earlier than 2000-01-01 |  |  |  |  |  |  |  |  |  |
| 6 | 5 | Release 9 Features | milestone | 0d? | 2000-01-01 | 2000-01-01 |  |  | 2000-01-01 | 2000-01-01 | 0d? | 2605d |  | CP,GP,RP,SP |  |  |  | Rel-9 |  |  |  |  |
| 7 | 6 | Services Alignment and Migration |  | 537d? | 2006-12-06 A | 2008-12-25 | 80% | 107.4d? | 2006-12-06 | 2008-12-25 | 537d? | 261d | finish no earlier than 2008-12-25 | S1 | 4296h | 3436.8h |  | Rel-9 | ServAl | China Mobile | fenglingjuan@chinamobile.com | Alain |
| 8 | 7 | **Registration in Densely-populated area (RED)** |  | 391d? | 2007-03-12 A | 2008-09-08 | 51% | 192.42d? | 2007-03-12 | 2008-09-08 | 391d? | 339d |  | S1,S2 | 5160h | 1064h |  | Rel-9 | RED | NTT DoCoMo | takakurat@s1.nttdocomo.co.jp | Alain |
| 9 | 7.1 | Stage 1 for RED |  | 4d? | 2007-03-12 A | 2007-03-15 A | 100% |  | 2007-03-12 | 2007-03-15 | 4d? |  | start no earlier than 2007-03-12 | S1 | 32h | 32h |  | Rel-9 | RED-St1 | NTT DoCoMo | takakurat@s1.nttdocomo.co.jp | Alain |
| 10 | 7.2 | Stage 2 for RED |  | 250d? | 2007-09-25 A | 2008-09-08 | 50% | 125d? | 2007-09-25 | 2008-09-08 | 250d? | 339d | finish no earlier than 2008-09-08 | S2 | 2000h | 1000h |  | Rel-9 | RED-St2 | NTT DoCoMo | tanakai@nttdocomo.co.jp | Maurice |
| 11 | 8 | End-User Identity |  | 344d? | 2007-09-03 A | 2008-12-25 | 5% | 326.8d? | 2007-09-03 | 2008-12-25 | 344d? | 261d | finish no earlier than 2008-12-25 | S1 | 2752h | 137.6h |  | Rel-9 | EUI | NSN | Joerg.Swetina@Siemens.com | Alain |
| 12 | 9 | Customized Ringing Signal |  | 276d? | 2007-12-06 A | 2008-12-25 | 60% | 110.4d? | 2007-12-06 | 2008-12-25 | 276d? | 261d | finish no earlier than 2008-12-25 | S1 | 2208h | 1324.8h |  | Rel-9 | CRS | Telecom Italia |  | Alain |
| 13 | 10 | **Public Warning System** |  | 276d? | 2007-12-06 | 2008-12-25 |  |  | 2007-12-06 | 2008-12-25 | 276d? | 261d |  | S1 | 4416h |  |  | Rel-9 | PWS | Telecom Italia |  | Alain |
| 14 | 10.1 | Stage 1 for PWS |  | 276d? | 2007-12-06 | 2008-12-25 |  |  | 2007-12-06 | 2008-12-25 | 276d? | 261d | finish no earlier than 2008-12-25 | S1 | 2208h |  |  | Rel-9 | PWS-S1 | Telecom Italia |  | Alain |
| 15 | 11 | Network Selection for non-3GPP Access |  | 280d? | 2007-12-06 A | 2008-12-31 | 38% | 173.6d? | 2007-12-06 | 2008-12-31 | 280d? | 257d | finish no earlier than 2008-12-31 | S1 | 2240h | 851.2h |  | Rel-9 | N3GTONSP | Telecom Italia |  | Alain |
| 16 | 12 | **Enhancements to Multimedia Priority Service** |  | 584d? | 2006-03-13 | 2008-06-05 |  |  | 2006-03-13 | 2008-06-05 | 584d? | 406d |  | S1 | 4672h |  |  | Rel-9 | ePRIOR | Telcordia | jgarraha@telcordia.com | Alain |
| 17 | 12.1 | Service Requirements for PRIOR_Ph2 |  | 584d? | 2006-03-13 | 2008-06-05 |  |  | 2006-03-13 | 2008-06-05 | 584d? | 406d | start no earlier than 2006-03-12 | S1 | 4672h |  |  | Rel-9 | ePRIOR | Telcordia | jgarraha@telcordia.com | Alain |
| 18 | 13 | **Support of Personal Area Networks and Enhancements to Personal Network Management** |  | 0d? | 2008-06-05 A | 2008-06-05 A | 100% |  | 2008-06-05 | 2008-06-05 | 0d? |  |  | S1 |  |  |  | Rel-9 | PAN_EPNM | Vodafone | armin.toepfer@vodafone.com | Alain |
| 19 | 13.1 | Stage 1 for PAN_EPNM | milestone | 0d? | 2008-06-05 A | 2008-06-05 A | 100% |  | 2008-06-05 | 2008-06-05 | 0d? |  | finish no earlier than 2008-06-05 | S1 |  |  |  | Rel-9 | PAN_EPNM | Vodafone | armin.toepfer@vodafone.com | Alain |
| 20 | 14 | **Multi-Media Telephony Service enhancements** |  | 201d? | 2008-06-05 | 2009-03-12 |  |  | 2008-06-05 | 2009-03-12 | 201d? | 206d |  | S1 | 3216h |  |  | Rel-9 | eMMTel | France Telecom | Philippe Lottin | Alain |
| 21 | 14.1 | Stage 1 for eMMTel |  | 201d? | 2008-06-05 | 2009-03-12 |  |  | 2008-06-05 | 2009-03-12 | 201d? | 206d | start no earlier than 2008-06-05 | S1 | 1608h |  |  | Rel-9 | eMMTel | France Telecom | Philippe Lottin | Alain |
| 22 | 15 | **User Data Convergence** |  | 201d? | 2008-06-05 | 2009-03-12 |  |  | 2008-06-05 | 2009-03-12 | 201d? | 206d |  | S1 | 3216h |  |  | Rel-9 | UDC | China Mobile | Lan Sizhong (lansizhong@chinamobile.com | Alain |
| 23 | 15.1 | Stage 1 for UDC |  | 201d? | 2008-06-05 | 2009-03-12 |  |  | 2008-06-05 | 2009-03-12 | 201d? | 206d | start no earlier than 2008-06-05 | S1 | 1608h |  |  | Rel-9 | UDC | China Mobile | Lan Sizhong (lansizhong@chinamobile.com | Alain |
| 24 | 16 | **Enhanced Home NodeB / eNodeB** |  | 136d? | 2008-06-05 | 2008-12-11 |  |  | 2008-06-05 | 2008-12-11 | 136d? | 271d |  | S1 | 2176h |  |  | Rel-9 | EHNB | T-Mobile | Michael Kurz | Alain |
| 25 | 16.1 | Stage 1 for EHNB |  | 136d? | 2008-06-05 | 2008-12-11 |  |  | 2008-06-05 | 2008-12-11 | 136d? | 271d | finish no earlier than 2008-12-11 | S1 | 1088h |  |  | Rel-9 | EHNB | T-Mobile | Michael Kurz | Alain |
| 26 | 17 | Support for IMS Emergency Calls over GPRS and EPS |  | 171d? | 2008-01-14 A | 2008-09-08 | 25% | 128.25d? | 2008-01-14 | 2008-09-08 | 171d? | 339d | finish no earlier than 2008-09-08 | S2 | 1368h | 342h |  | Rel-9 | IMS_EMER_GPRS_EPS | Alcatel-Lucent | Deborah Barclay | Maurice |

Notes:
- 7: Triggered by Study UID_370086 (FSServAl). SA#39 moved to Rel-9. / Text3: 22.182
- 8: SA#35 Stage 1 completed. SA#40 SA2 moved to Rel-9. / Text3: TS
- 9: SA#35 completed / Text3: 22.101
- 10: SP#37 WID approved. SA#40 moved to Rel-9. / Text3: 23.880
- 11: SA#38 moved to Rel-9 / Text3: 22.101
- 12: SA#38 WID approved. SA#39 moved to Rel-9 / Text3: TS
- 13: Larger scope than Rel-8 Feature UID_370051 (ETWS). Triggered by Study UID_320025 (PWS-SI). SA#39 moved to Rel-9 / Text3: TS
- 14: SA#39 moved to Rel-9 / Text3: TS
- 15: Triggered by Study UID_340033 (N3GtoNSP). SA#38 WID approved. SA#39 exception granted to Jun 2008. S1#40: 06/08=>12/08. SA#40 moved to Rel-9 / Text3: TS
- 16: 06/08 Record created. SA#39 WID approved. SA#40 Stage 1 completed. / Text3: 22.153
- 17: 06/08 Record created. SA#39 WID approved. SA#40 completed / Text3: 22.153
- 18: SA#40 WID approved & Stage 1 completed / Text3: 22.259
- 19: SA#40 WID approved & Stage 1 completed / Text3: 22.259
- 20: SA#40 WID approved. / Text3: 22.173
- 21: SA#40 WID approved. / Text3: 22.173
- 22: Triggered by SA5 Study Common Profile Storage (CPS) UID_390038 (OAM8-Studies) TR 32.808. SA#40 WID approved. / Text3: 22.9xy, 22.101
- 23: Triggered by SA5 Study Common Profile Storage (CPS) UID_390038 (OAM8-Studies) TR 32.808. SA#40 WID approved. / Text3: 22.9xy, 22.101
- 24: SA#40 WID approved. / Text3: 22.xxx, 22.011
- 25: SA#40 WID approved. / Text3: 22.xxx, 22.011
- 26: SA#38 WID approved. Moved to Rel-9. SA#40 updated WID SP-070820=>SP-080352 / Text3: 23.8xx, 22.101, 23.060, 23.167, 23.228, 23.271, 23.203, 23.401, 23.402, 23.221

| ID | WBS | Task | Type | Duration | Start | Finish | Complete | Remaining | Baseline start | Baseline finish | Baseline duration | Total slack | Constraint | Resources | Work | Actual work | Text1 | Text3 | Text4 | Text5 | Text6 | Text8 | Text12 |
| --- | --- | --- | --- | --- | --- | --- | --- | --- | --- | --- | --- | --- | --- | --- | --- | --- | --- | --- | --- | --- | --- | --- | --- |
| 27 | 18 | **LCS Control Plane Solution for EPS** |  | 266d? | 2008-06-05 | 2009-06-11 |  |  | 2008-06-05 | 2009-06-11 | 266d? | 141d |  | S2 | 4256h |  | LCS_CPS_EPS | 23.8xx, 23.271, 23.401, 23.402 | Polaris Wireless | Robert Gross | Rel-9 | Maurice |  |
| 28 | 18.1 | Stage 2 for LCS_CPS_EPS |  | 266d? | 2008-06-05 | 2009-06-11 |  |  | 2008-06-05 | 2009-06-11 | 266d? | 141d | finish no earlier than 2009-06-11 | S2 | 2128h |  | LCS_CPS_EPS | 23.8xx, 23.271, 23.401, 23.402 | Polaris Wireless | Robert Gross | Rel-9 | Maurice |  |
| 29 | 19 | **MBMS support in EPS** |  | 266d? | 2008-06-05 | 2009-06-11 |  |  | 2008-06-05 | 2009-06-11 | 266d? | 141d |  | S2 | 4256h |  | MBMS_EPS |  | China Mobile | Liu Hong (liuhongyfw@chinamobile.com) | Rel-9 | Maurice |  |
| 30 | 19.1 | Stage 2 for MBMS_EPS |  | 266d? | 2008-06-05 | 2009-06-11 |  |  | 2008-06-05 | 2009-06-11 | 266d? | 141d | finish no earlier than 2009-06-11 | S2 | 2128h |  | MBMS_EPS | 23.246 | China Mobile | Liu Hong (liuhongyfw@chinamobile.com) | Rel-9 | Maurice |  |
| 31 | 20 | **Deleted - SAES Enhancements (non RAN aspects)** |  | 381d? | 2007-06-25 A | 2008-12-08 A | 100% |  | 2007-06-25 | 2008-12-08 | 381d? |  |  | S2 | 11664h | 11664h | SAES_Ph2 |  | NSN |  | Rel-9 | Maurice | SP-39 |
| 32 | 20.1 | Deleted - Functions and procedures for SAE to support LTE MBMS |  | 381d? | 2007-06-25 A | 2008-12-08 A | 100% |  | 2007-06-25 | 2008-12-08 | 381d? |  | finish no earlier than 2008-12-08 | S2 | 3048h | 3048h | SAES_Ph2 |  |  |  | Rel-9 | Maurice | SP-39 |
| 33 | 20.2 | Deleted - CS over EPS |  | 194d? | 2008-03-12 A | 2008-12-08 A | 100% |  | 2008-03-12 | 2008-12-08 | 194d? |  | finish no earlier than 2008-12-08 | S2 | 1552h | 1552h | SAES_Ph2 |  |  |  | Rel-9 | Maurice | SP-39 |
| 34 | 20.3 | **Deleted - SAE for generic support for non-3GPP accesses** |  | 251d? | 2007-06-25 A | 2008-06-09 A | 100% |  | 2007-06-25 | 2008-06-09 | 251d? |  |  | S2 | 4016h | 4016h | SAES_Ph2 |  |  |  | Rel-9 | Maurice | SP-39 |
| 35 | 20.3.1 | Deleted - Single Radio Aspects of SAE for Optimized Handover with WiMAX |  | 251d? | 2007-06-25 A | 2008-06-09 A | 100% |  | 2007-06-25 | 2008-06-09 | 251d? |  | finish no earlier than 2008-06-09 | S2 | 2008h | 2008h | SAES_Ph2 |  |  |  | Rel-9 | Maurice | SP-39 |
| 36 | 21 | Deleted - Support of WiMAX - LTE Mobility |  | 406d? | 2008-06-06 A | 2009-12-25 A | 100% |  | 2008-06-06 | 2009-12-25 | 406d? |  | start no earlier than 2008-06-06 | R2 | 3248h | 3248h | WiMAX_LTE_Mobility | 36.306, 36.331, 36.413, 36.300, 36.214, 36.133, 36.304 | Samsung |  | Rel-9 | Joern | SP-39 |
| 37 | 22 | Deleted - Support of WiMAX - UMTS Mobility |  | 406d? | 2008-06-06 A | 2009-12-25 A | 100% |  | 2008-06-06 | 2009-12-25 | 406d? |  | start no earlier than 2008-06-06 | R2 | 3248h | 3248h | WiMAX_UMTS_Mobility | 25.306, 25.331, 25.413 | Intel |  | Rel-9 | Joern | SP-39 |
| 38 | 23 | Release 8 Features | milestone | 0d? | 2000-01-03 | 2000-01-03 |  |  | 2000-01-03 | 2000-01-03 | 0d? | 2604d | start no earlier than 2000-01-03 | CP,GP,RP,SP |  |  |  |  |  |  | Rel-8 |  |  |
| 39 | 24 | **3GPP System Architecture Evolution Specification - Evolved Packet System (non RAN aspects)** |  | 762d? | 2006-04-12 A | 2009-03-12 | 46% | 411.28d? | 2006-04-12 | 2009-03-12 | 762d? | 206d |  | S1,S2,S3,S5,C1,C3,C4,C6 | 220660h | 91377.2h | SAES | 23.228, 23.279, 23.402 | T-Mobile | michael.kurz@t-mobile.at | Rel-8 | Maurice |  |
| 40 | 24.1 | Requirements for evolution of the 3GPP system architecture |  | 395d? | 2006-06-08 A | 2007-12-12 A | 100% |  | 2006-06-08 | 2007-12-12 | 395d? |  | finish no earlier than 2007-11-30 | S1 | 3160h | 3160h | AIPN-SAE | 22.278, 22.011, 22.246 | T-Mobile | michael.kurz@t-mobile.at | Rel-8 | Alain |  |
| 41 | 24.2 | **High level and common (for all accesses) functions** |  | 514d? | 2007-01-02 A | 2008-12-19 | 31% | 355.77d? | 2007-01-02 | 2008-12-19 | 514d? | 265d |  | S2,S3,C1,C3,C4 | 37896h | 10592h | EPS-ComF |  | NSN |  | Rel-8 | Maurice |  |
| 42 | 24.2.1 | Stage 2 for High level functions |  | 370d? | 2007-01-02 A | 2008-06-02 A | 100% |  | 2007-01-02 | 2008-06-02 | 370d? |  | finish no earlier than 2008-06-02 | S2 | 2960h | 2960h | SAES-SA-HLF | 23.402 | Motorola | Irfan Ali | Rel-8 | Maurice |  |
| 43 | 24.2.2 | Stage 2 Security Architecture |  | 197d? | 2008-03-12 A | 2008-12-11 | 80% | 39.4d? | 2008-03-12 | 2008-12-11 | 197d? | 271d | finish no earlier than 2008-12-11 | S3 | 1576h | 1260.8h | SAES | 33.401, 33.210, 33.310 | NSN | marc.blommaert.ext@nsn.com | Rel-8 | Dionisio |  |
| 44 | 24.2.3 | Stage 3 (CT1) for SAE impact on services, network functions and capabilities |  | 485d? | 2007-02-05 A | 2008-12-15 | 30% | 339.5d? | 2007-02-05 | 2008-12-15 | 485d? | 270d | finish no earlier than 2008-12-15 | C1 | 3880h | 1164h | SAES | 24.229, 24.305, 27.007 | NSN | robert.zaus@nsn.com | Rel-8 | Andrijana |  |
| 45 | 24.2.4 | Stage 3 SAE impact on existing capabilities |  | 490d? | 2007-02-05 | 2008-12-19 |  |  | 2007-02-05 | 2008-12-19 | 490d? | 265d | finish no earlier than 2008-12-19 | C3 | 3920h |  | SAES |  | Huawei |  | Rel-8 | Gwiho |  |
| 46 | 24.2.5 | Stage 3 (CT4) of SAE impact on existing capabilities |  | 480d? | 2007-02-05 A | 2008-12-05 | 10% | 432d? | 2007-02-05 | 2008-12-05 | 480d? | 275d | finish no earlier than 2008-12-05 | C4 | 3840h | 384h | SAES | 29.274, 29.275 | Huawei | shahab.lavasani@huawei.com | Rel-8 | Kimmo |  |
| 47 | 24.2.6 | Stage 2/3 for Network selection procedures |  | 485d? | 2007-02-05 A | 2008-12-15 | 60% | 194d? | 2007-02-05 | 2008-12-15 | 485d? | 270d | finish no earlier than 2008-12-15 | C1 | 3880h | 2328h | SAES | 23.122, 24.302 | NSN | robert.zaus@nsn.com | Rel-8 | Andrijana |  |
| 48 | 24.2.7 | Stage 3 PCC within SAE |  | 490d? | 2007-02-05 A | 2008-12-19 | 10% | 441d? | 2007-02-05 | 2008-12-19 | 490d? | 265d | finish no earlier than 2008-12-19 | C3 | 3920h | 392h | SAES-St3-PCC |  | Ericsson | j.javier.pastor@ericsson.com | Rel-8 | Gwiho |  |
| 49 | 24.2.8 | Stage 3 EPC interworking with external PDNs (SGi) |  | 490d? | 2007-02-05 A | 2008-12-19 | 5% | 465.5d? | 2007-02-05 | 2008-12-19 | 490d? | 265d | finish no earlier than 2008-12-19 | C3 | 3920h | 196h | SAES-St3-intwk |  | Huawei | weiwh@huawei.com | Rel-8 | Gwiho |  |
| 50 | 24.2.9 | Stage 3 for SAE / LTE identities |  | 480d? | 2007-02-05 A | 2008-12-05 | 10% | 432d? | 2007-02-05 | 2008-12-05 | 480d? | 275d | finish no earlier than 2008-12-05 | C4 | 3840h | 384h | SAES | 23.003 | Huawei | shahab.lavasani@huawei.com | Rel-8 | Kimmo |  |
| 51 | 24.2.10 | Unified guidelines for Diameter usage within 3GPP |  | 256d? | 2007-09-21 A | 2008-09-12 | 65% | 89.6d? | 2007-09-21 | 2008-09-12 | 256d? | 335d | finish no earlier than 2008-09-12 | C3 | 2048h | 1331.2h | SAES-DIAM | 29.909 | Huawei | Javier Gonzalez Gallego | Rel-8 | Gwiho |  |

Notes:
- 27: SA#40 WID approved. Triggered by Study UID_380068 (FS_LCS_EPS)
- 28: SA#40 WID approved. Triggered by Study UID_380068 (FS_LCS_EPS)
- 29: SA#40 WID approved.
- 30: SA#40 WID approved.
- 31: SA#39 created to host Rel-9 Wis. BUT no agreed WID
- 32: SA#39 SAE functionality moved to Rel-9. WID returned to SA2 for re-consideration & remove MBMS for EPS from Rel 8
- 33: SA#39 SAE functionality moved to Rel-9. BUT no agreed WID
- 34: SA#39 SAE functionality moved to Rel-9. BUT no agreed WID
- 35: SA#39 SAE functionality moved to Rel-9. BUT no agreed WID
- 36: RAN#39: No agreed WID
- 37: RAN#39: No agreed WID
- 40: SA#38 completed
- 42: SA#40 completed
- 43: SA#39: WID update of SP-070933. WP record created
- 46: CT#40 WID updated CP-080026=>CP-080279
- 50: CT#40 WID updated CP-080026=>CP-080279
- 51: CP#37 WID approved

| ID | WBS | Task | Type | Duration | Start | Finish | Complete | Remaining | Baseline start | Baseline finish | Baseline duration | Total slack | Constraint | Resources | Work | Actual work | Text1 | Text3 | Text4 | Text5 | Text6 | Text8 | Text12 |
| --- | --- | --- | --- | --- | --- | --- | --- | --- | --- | --- | --- | --- | --- | --- | --- | --- | --- | --- | --- | --- | --- | --- | --- |
| 52 | 24.3 | **SAE for LTE access** |  | 514d? | 2007-01-02 A | 2008-12-19 | 57% | 222.47d? | 2007-01-02 | 2008-12-19 | 514d? | 265d |  | S2,C1,C3,C4 | 49064h | 22266.4h | SAES-LTE | 23.402 | Motorola | Irfan.Ali@motorola.com | Rel-8 | Maurice |  |
| 53 | 24.3.1 | CT4 Stage 3 for protocol between EPCs |  | 480d? | 2007-02-05 A | 2008-12-05 | 60% | 192d? | 2007-02-05 | 2008-12-05 | 480d? | 275d | finish no earlier than 2008-12-05 | C4 | 3840h | 2304h | SAES | 29.274, 29.275 | Huawei | shahab.lavasani@huawei.com | Rel-8 | Kimmo |  |
| 54 | 7.2.2.1 | **SAES-SA-FP_LTE with GTP variant** |  | 504d? | 2007-01-02 A | 2008-12-05 | 77% | 113.44d? | 2007-01-02 | 2008-12-05 | 504d? | 275d |  | S2,C4 | 10856h | 5864h | SAES-SA-FP_LTE-GTP |  | NSN |  | Rel-8 | Maurice |  |
| 55 | 24.3.2.1 | Stage 2 for SAES-SA-FP_LTE with GTP variant |  | 373d? | 2007-01-02 A | 2008-06-05 A | 100% |  | 2007-01-02 | 2008-06-05 | 373d? |  | finish no earlier than 2008-06-02 | S2 | 2984h | 2984h | SAES-SA-FP_LTE-GTP-St2 |  | NSN |  | Rel-8 | Maurice |  |
| 56 | 24.3.2.2 | CT4 Stage 3 for GTP v2 protocol |  | 480d? | 2007-02-05 A | 2008-12-05 | 60% | 192d? | 2007-02-05 | 2008-12-05 | 480d? | 275d | finish no earlier than 2008-12-05 | C4 | 3840h | 2304h | SAES | 29.274 | Huawei | shahab.lavasani@huawei.com | Rel-8 | Kimmo |  |
| 57 | 7.2.2.2 | **SAES-SA-FP_LTE with PMIP variant** |  | 504d? | 2007-01-02 A | 2008-12-05 | 77% | 113.44d? | 2007-01-02 | 2008-12-05 | 504d? | 275d |  | S2,C4 | 10856h | 5864h | SAES-SA-FP_LTE-IETF |  | NSN |  | Rel-8 | Maurice |  |
| 58 | 24.3.3.1 | Stage 2 for SAES-SA-FP_LTE with PMIP variant |  | 373d? | 2007-01-02 A | 2008-06-05 A | 100% |  | 2007-01-02 | 2008-06-05 | 373d? |  | finish no earlier than 2008-06-02 | S2 | 2984h | 2984h | SAES-SA-FP_LTE-IETF-St2 |  | NSN |  | Rel-8 | Maurice |  |
| 59 | 24.3.3.2 | CT4 Stage 3 for PMIP protocol within EPC |  | 480d? | 2007-02-05 A | 2008-12-05 | 60% | 192d? | 2007-02-05 | 2008-12-05 | 480d? | 275d | finish no earlier than 2008-12-05 | C4 | 3840h | 2304h | SAES | 29.274, 29.275 | Huawei | shahab.lavasani@huawei.com | Rel-8 | Kimmo |  |
| 60 | 24.3.4 | Stage 3 for UE NAS mobility procedures in idle and active mode |  | 485d? | 2007-02-05 A | 2008-12-15 | 50% | 242.5d? | 2007-02-05 | 2008-12-15 | 485d? | 270d | finish no earlier than 2008-12-15 | C1 | 3880h | 1940h | SAES | 24.007, 24.301 | NSN | robert.zaus@nsn.com | Rel-8 | Andrijana |  |
| 61 | 24.3.5 | Stage 3 for Session management, bearer control and QoS aspects |  | 485d? | 2007-02-05 A | 2008-12-15 | 50% | 242.5d? | 2007-02-05 | 2008-12-15 | 485d? | 270d | finish no earlier than 2008-12-15 | C1 | 3880h | 1940h | SAES | 24.007, 24.301 | NSN | robert.zaus@nsn.com | Rel-8 | Andrijana |  |
| 62 | 24.3.6 | Stage 3 for security aspects of LTE Access |  | 485d? | 2007-02-05 A | 2008-12-15 | 38% | 300.7d? | 2007-02-05 | 2008-12-15 | 485d? | 270d | finish no earlier than 2008-12-15 | C1 | 3880h | 1474.4h | SAES | 24.008, 24.301 | NSN | robert.zaus@nsn.com | Rel-8 | Andrijana |  |
| 63 | 24.3.7 | Stage 3 for QoS mechanisms |  | 490d? | 2007-02-05 | 2008-12-19 |  |  | 2007-02-05 | 2008-12-19 | 490d? | 265d | finish no earlier than 2008-12-19 | C3 | 3920h |  | SAES |  | Ericsson | j.javier.pastor@ericsson.com | Rel-8 | Gwiho |  |
| 64 | 24.3.8 | Stage 3 for EPC - HSS interface |  | 480d? | 2007-02-05 A | 2008-12-05 | 70% | 144d? | 2007-02-05 | 2008-12-05 | 480d? | 275d | finish no earlier than 2008-12-05 | C4 | 3840h | 2688h | SAES | 29.272, 29.275 | Huawei | shahab.lavasani@huawei.com | Rel-8 | Kimmo |  |
| 65 | 24.4 | **SAE for Interoperation between LTE and legacy cellular PS accesses** |  | 485d? | 2007-02-05 A | 2008-12-15 | 35% | 313.58d? | 2007-02-05 | 2008-12-15 | 485d? | 270d |  | S2,C1,C4 | 33816h | 10775h | SAES-SA-FP_3GPP | 23.402 | Motorola | Irfan.Ali@motorola.com | Rel-8 | Maurice |  |
| 66 | 24.4.1 | Stage 2 for Interoperation between LTE and 2G/3G |  | 419d? | 2007-02-05 A | 2008-09-11 | 90% | 41.9d? | 2007-02-05 | 2008-09-11 | 419d? | 336d | finish no earlier than 2008-09-11 | S2 | 3352h | 3016.8h | EPSto2_3G |  | NSN |  | Rel-8 | Maurice |  |
| 67 | 24.4.2 | Stage 3 for Inter-system mobility between E-UTRAN and 2G/3G |  | 485d? | 2007-02-05 A | 2008-12-12 | 5% | 460.75d? | 2007-02-05 | 2008-12-12 | 485d? | 270d | start no earlier than 2007-02-05 | C1 | 3880h | 194h | SAES | 24.008, 24.301 | NSN | robert.zaus@nsn.com | Rel-8 | Andrijana |  |
| 68 | 24.4.3 | Stage 2 GPRS for EPC (23.060, etc.) |  | 179d? | 2008-01-14 A | 2008-09-18 | 40% | 107.4d? | 2008-01-14 | 2008-09-18 | 179d? | 331d | finish no earlier than 2008-09-18 | S2 | 1432h | 572.8h | SAES |  | NSN |  | Rel-8 | Maurice |  |
| 69 | 24.4.4 | Stage 3 for EPC - GPRS |  | 480d? | 2007-02-05 A | 2008-12-05 | 20% | 384d? | 2007-02-05 | 2008-12-05 | 480d? | 275d | finish no earlier than 2008-12-05 | C4 | 3840h | 768h | SAES | 29.274, 29.275 | Huawei | shahab.lavasani@huawei.com | Rel-8 | Kimmo |  |
| 70 | 24.4.5 | Stage 3 for EPC to UTRAN |  | 480d? | 2007-02-05 A | 2008-12-05 | 10% | 432d? | 2007-02-05 | 2008-12-05 | 480d? | 275d | finish no earlier than 2008-12-05 | C4 | 3840h | 384h | SAES | 29.274, 29.275 | Huawei | shahab.lavasani@huawei.com | Rel-8 | Kimmo |  |
| 71 | 24.4.6 | Stage 3 for EPC to 3GPP2 |  | 480d? | 2007-02-05 A | 2008-12-05 | 70% | 144d? | 2007-02-05 | 2008-12-05 | 480d? | 275d | finish no earlier than 2008-12-05 | C4 | 3840h | 2688h | SAES | 29.277, 29.276 | Huawei | shahab.lavasani@huawei.com | Rel-8 | Kimmo |  |
| 72 | 24.4.7 | Stage 2 for Interoperation between LTE and CDMA2000 |  | 254d? | 2007-06-18 A | 2008-06-05 | 98% | 5.08d? | 2007-06-18 | 2008-06-05 | 254d? | 406d | finish no earlier than 2008-04-25 | S2 | 2032h | 1991.36h | EPStoC2k |  | NSN |  | Rel-8 | Maurice |  |
| 73 | 24.4.8 | Stage 3 for Inter-system mobility between E-UTRAN and CDMA2000 |  | 485d? | 2007-02-05 A | 2008-12-15 | 15% | 412.25d? | 2007-02-05 | 2008-12-15 | 485d? | 270d | finish no earlier than 2008-12-15 | C1 | 3880h | 582h | SAES | 24.301, 24.302 | NSN | robert.zaus@nsn.com | Rel-8 | Andrijana |  |
| 74 | 24.4.9 | Stage 3 for MME - SGSN "signalling free" protocol |  | 480d? | 2007-02-05 A | 2008-12-05 | 10% | 432d? | 2007-02-05 | 2008-12-05 | 480d? | 275d | finish no earlier than 2008-12-05 | C4 | 3840h | 384h | SAES | 29.274 | Huawei | shahab.lavasani@huawei.com | Rel-8 | Kimmo |  |
| 75 | 24.5 | **SAE for support for non-3GPP accesses** |  | 509d? | 2007-01-02 A | 2008-12-15 | 46% | 275.07d? | 2007-01-02 | 2008-12-15 | 509d? | 270d |  | S2,S3,C1,C4 | 51552h | 22206.8h | SAES-SA-FP_n3GPP | 23.402 | Motorola | Irfan.Ali@motorola.com | Rel-8 | Maurice |  |
| 76 | 7.2.4.1 | Stage 2 for Host-based Mobility aspects |  | 373d? | 2007-01-02 A | 2008-06-05 A | 100% |  | 2007-01-02 | 2008-06-05 | 373d? |  | finish no earlier than 2008-04-11 | S2 | 2984h | 2984h | SAES-SA-FP_n3GPP-HBMob |  | NSN |  | Rel-8 | Maurice |  |
| 77 | 7.2.4.2 | Stage 2 for Network-based Mobility aspects |  | 448d? | 2007-01-02 A | 2008-09-18 | 90% | 44.8d? | 2007-01-02 | 2008-09-18 | 448d? | 331d | finish no earlier than 2008-09-18 | S2 | 3584h | 3225.6h | SAES-SA-FP_n3GPP-NBMob |  | NSN |  | Rel-8 | Maurice |  |
| 78 | 24.5.3 | Stage 3 for Mobility management based on DSMIP v6 |  | 485d? | 2007-02-05 A | 2008-12-15 | 65% | 169.75d? | 2007-02-05 | 2008-12-15 | 485d? | 270d | finish no earlier than 2008-12-15 | C1 | 3880h | 2522h | SAES | 24.303 | NSN | robert.zaus@nsn.com | Rel-8 | Andrijana |  |
| 79 | 24.5.4 | Stage 3 for Mobility management based on MIP v4 |  | 485d? | 2007-02-05 A | 2008-12-12 | 35% | 315.25d? | 2007-02-05 | 2008-12-12 | 485d? | 270d | start no earlier than 2007-02-05 | C1 | 3880h | 1358h | SAES | 24.304 | NSN | robert.zaus@nsn.com | Rel-8 | Andrijana |  |
| 80 | 24.5.5 | Stage 3 for Inter-system mobility between E-UTRAN and non 3GPP accesses |  | 485d? | 2007-02-05 A | 2008-12-12 | 5% | 460.75d? | 2007-02-05 | 2008-12-12 | 485d? | 270d | start no earlier than 2007-02-05 | C1 | 3880h | 194h | SAES | 24.301 | NSN | robert.zaus@nsn.com | Rel-8 | Andrijana |  |
| 81 | 24.5.6 | Stage 2 for Optimized Dual-Radio Handover with WiMAX |  | 249d? | 2007-06-25 A | 2008-06-05 A | 100% |  | 2007-06-25 | 2008-06-05 | 249d? |  | finish no earlier than 2008-06-09 | S2 | 1992h | 1992h | SAES-SA-FP_n3GPP-OptWIMAX |  | NSN |  | Rel-8 | Maurice |  |
| 82 | 24.5.7 | Stage 2 Security aspects for non-3GPP Access |  | 197d? | 2008-03-12 A | 2008-12-11 | 80% | 39.4d? | 2008-03-12 | 2008-12-11 | 197d? | 271d | finish no earlier than 2008-12-11 | S3 | 1576h | 1260.8h | SAES | 33.402, 33.210, 33.310 | NSN | marc.blommaert.ext@nsn.com | Rel-8 | Dionisio |  |
| 83 | 24.5.8 | Stage 3 security aspects for DSMIP v6 Access |  | 485d? | 2007-02-05 A | 2008-12-15 | 60% | 194d? | 2007-02-05 | 2008-12-15 | 485d? | 270d | finish no earlier than 2008-12-15 | C1 | 3880h | 2328h | SAES | 24.303 | NSN | robert.zaus@nsn.com | Rel-8 | Andrijana |  |
| 84 | 24.5.9 | Stage 3 security aspects for MIPv4 Access |  | 485d? | 2007-02-05 | 2008-12-15 |  |  | 2007-02-05 | 2008-12-15 | 485d? | 270d | finish no earlier than 2008-12-15 | C1 | 3880h |  | SAES | 24.304 | NSN | robert.zaus@nsn.com | Rel-8 | Andrijana |  |
| 85 | 24.5.10 | Stage 3 for Access to the EPC via non-3GPP access networks |  | 485d? | 2007-02-05 A | 2008-12-15 | 35% | 315.25d? | 2007-02-05 | 2008-12-15 | 485d? | 270d | finish no earlier than 2008-12-15 | C1 | 3880h | 1358h | SAES | 24.302 | NSN | robert.zaus@nsn.com | Rel-8 | Andrijana |  |
| 86 | 24.5.11 | Stage 3 for interfaces within EPC |  | 318d? | 2007-09-19 A | 2008-12-05 | 60% | 127.2d? | 2007-09-19 | 2008-12-05 | 318d? | 275d | finish no earlier than 2008-12-05 | C4 | 2544h | 1526.4h | SAES | 29.274 | Huawei | shahab.lavasani@huawei.com | Rel-8 | Kimmo |  |
| 87 | 24.5.12 | Stage 3 for Interfaces EPC - non-3GPP IP access |  | 480d? | 2007-02-05 A | 2008-12-05 | 30% | 336d? | 2007-02-05 | 2008-12-05 | 480d? | 275d | finish no earlier than 2008-12-05 | C4 | 3840h | 1152h | SAES | 29.273, 29.275 | Huawei | shahab.lavasani@huawei.com | Rel-8 | Kimmo |  |
| 88 | 24.5.13 | Stage 3 for AAA/HSS related |  | 480d? | 2007-02-05 A | 2008-12-05 | 30% | 336d? | 2007-02-05 | 2008-12-05 | 480d? | 275d | finish no earlier than 2008-12-05 | C4 | 3840h | 1152h | SAES | 29.273 | Huawei | shahab.lavasani@huawei.com | Rel-8 | Kimmo |  |
| 89 | 24.5.14 | Stage 3 for EPC - AAA interface |  | 480d? | 2007-02-05 A | 2008-12-05 | 20% | 384d? | 2007-02-05 | 2008-12-05 | 480d? | 275d | finish no earlier than 2008-12-05 | C4 | 3840h | 768h | SAES | 29.273 | Huawei | shahab.lavasani@huawei.com | Rel-8 | Kimmo |  |
| 90 | 24.5.15 | Deleted (already covered) SAES-SA-FP_n3GPP Optimized Handover with CDMA | milestone | 0d? | 2007-06-25 A | 2007-06-25 A | 100% |  | 2007-06-25 | 2007-06-25 | 0d? |  | finish no earlier than 2007-06-25 | S2 |  |  | SAES-SA-FP_n3GPP-OptCDMA |  | NSN |  | Rel-8 | Maurice | SP-37 |
| 91 | 24.6 | Single Radio Voice Call Continuity for 3GPP (SRVCC) |  | 373d? | 2007-01-02 A | 2008-09-15 A | 100% |  | 2007-01-02 | 2008-09-15 | 373d? |  | finish no earlier than 2008-09-15 | S2 | 2984h | 2984h | SAES-SRVCC | 23.216 | NSN | Curt Wong | Rel-8 | Maurice |  |
| 92 | 24.7 | Voice Call Continuity for CDMA2000 1X |  | 249d? | 2007-06-25 A | 2008-06-05 A | 100% |  | 2007-06-25 | 2008-06-05 | 249d? |  | finish no earlier than 2008-06-13 | S2 | 1992h | 1992h | SAES-VCC_1X |  | NSN |  | Rel-8 | Maurice |  |
| 93 | 24.8 | SAE impacts on IMS |  | 373d? | 2007-01-02 A | 2008-06-05 A | 100% |  | 2007-01-02 | 2008-06-05 | 373d? |  | finish no earlier than 2008-06-13 | S2 | 2984h | 2984h | SAES-SA_IMS |  | NSN |  | Rel-8 | Maurice |  |

Notes:
- 53: CT#40 WID updated CP-080026=>CP-080279
- 55: SA#40 completed
- 56: CT#40 WID updated CP-080026=>CP-080279
- 58: Multiple PDN related alignments, 23.060-derived changes. SA#40 completed
- 59: CT#40 WID updated CP-080026=>CP-080279
- 64: CT#40 WID updated CP-080026=>CP-080279
- 66: SA#40 exception to Sep 2008 (default bearer issue)
- 68: SA#40 exception to Sep 2008 (QoS mapping related changes, Interoperation between Gn/Gp and S4 SGSN)
- 69: CT#40 WID updated CP-080026=>CP-080279
- 70: CT#40 WID updated CP-080026=>CP-080279
- 71: CT#40 WID updated CP-080026=>CP-080279
- 72: SA#40 exception to Sep 2008 (Handover of multiple PDNs, Handling of multiple BBERFs)
- 74: CT#40 WID updated CP-080026=>CP-080279
- 75: SA#39: retained in Rel 8 (in addition to the essential functionality defined in SP-070699)
- 76: SA#40 completed
- 77: SA#40 exception to Sep 2008 (Multiple PDN connections to the same APN using PMIP)
- 81: SA#40 completed
- 82: SA#39: WID update of SP-070933. WP record created
- 83: post-CT#39: split into DSMIP v6 and MIPv4 Access
- 84: post-CT#39: split into DSMIP v6 and MIPv4 Access. 390072->390172
- 86: CT#40 WID updated CP-080026=>CP-080279
- 87: CT#40 WID updated CP-080026=>CP-080279
- 88: CT#40 WID updated CP-080026=>CP-080279
- 89: CT#40 WID updated CP-080026=>CP-080279
- 90: SA#37 stopped
- 91: SA#38 WID approved. SA#40 exception to Sep 2008 for Single Radio VCC: incorporating of results of the RAN HSPA VoIP to CS alignment work
- 92: SA#40 completed
- 93: SA#40 completed

| ID | WBS | Task | Type | Duration | Start | Finish | Complete | Remaining | Baseline start | Baseline finish | Baseline duration | Total slack | Constraint | Resources | Work | Actual work | Text1 | Text4 | Text5 | Text6 | Text8 | Text12 |
| --- | --- | --- | --- | --- | --- | --- | --- | --- | --- | --- | --- | --- | --- | --- | --- | --- | --- | --- | --- | --- | --- | --- |
| 94 | 24.9 | **CS Fallback in EPS** |  | 193d? | 2008-03-12 A | 2008-12-05 | 19% | 157.17d? | 2008-03-12 | 2008-12-05 | 193d? | 275d |  | S2,C1,C4 | 3760h | 496h | SAES-CSFB | T-Mobile, Vodafone | sabine.demel@t-mobile.at, chris.pudney@vodafone.com | Rel-8 | Maurice |  |
| 95 | 24.9.1 | Stage 2 for CS Fallback in EPS |  | 62d? | 2008-03-12 A | 2008-06-05 A | 100% |  | 2008-03-12 | 2008-06-05 | 62d? |  | finish no earlier than 2008-12-05 | S2 | 496h | 496h | SAES-CSFB | T-Mobile, Vodafone | sabine.demel@t-mobile.at, chris.pudney@vodafone.com | Rel-8 | Maurice |  |
| 96 | 24.9.2 | Stage 3 for CS Fallback in EPS |  | 136d? | 2008-05-30 | 2008-12-05 |  |  | 2008-05-30 | 2008-12-05 | 136d? | 275d | finish no earlier than 2008-12-05 | C1 | 1088h |  | SAES-CSFB | NEC | yannick.lair@nectech.fr | Rel-8 | Andrijana |  |
| 97 | 24.9.3 | Stage 3 for CS Fallback in EPS |  | 136d? | 2008-05-30 | 2008-12-05 |  |  | 2008-05-30 | 2008-12-05 | 136d? | 275d | finish no earlier than 2008-12-05 | C4 | 1088h |  | SAES-CSFB | NEC | yannick.lair@nectech.fr | Rel-8 | Kimmo |  |
| 98 | 24.10 | System enhancements for the use of IMS services in local breakout |  | 62d? | 2008-03-12 A | 2008-06-05 A | 100% |  | 2008-03-12 | 2008-06-05 | 62d? |  | finish no earlier than 2008-06-05 | S2 | 496h | 496h | SAES-IMS_LBO | Telecom Italia | mario.madella@telecomitalia.it | Rel-8 | Maurice |  |
| 99 | 24.11 | **EPC Data Definitions** |  | 309d? | 2008-01-07 A | 2009-03-12 | 20% | 247.2d? | 2008-01-07 | 2009-03-12 | 309d? | 206d |  | S5 | 6624h | 1324.8h | EPC-OAM | Huawei |  | Rel-8 | Dionisio |  |
| 100 | 24.11.1 | EPC Network Resource Model (NRM) Integration Reference Point (IRP) |  | 309d? | 2008-01-07 A | 2009-03-12 | 20% | 247.2d? | 2008-01-07 | 2009-03-12 | 309d? | 206d | finish no earlier than 2009-03-12 | S5 | 2472h | 494.4h | EPC-OAM | Huawei |  | Rel-8 | Dionisio |  |
| 101 | 24.11.2 | Performance measurements for EPC |  | 210d? | 2008-02-22 A | 2008-12-11 | 20% | 168d? | 2008-02-22 | 2008-12-11 | 210d? | 271d | start no earlier than 2008-02-22 | S5 | 1680h | 336h | EPC-OAM | China Mobile |  | Rel-8 | Dionisio |  |
| 102 | 24.12 | EPC Charging |  | 309d? | 2008-01-07 A | 2009-03-12 | 40% | 185.4d? | 2008-01-07 | 2009-03-12 | 309d? | 206d | finish no earlier than 2009-03-12 | S5 | 2472h | 988.8h | EPC-CH | NSN |  | Rel-8 | Dionisio |  |
| 103 | 24.13 | Issues for CT1 TR 24.801 |  | 425d? | 2007-01-04 A | 2008-09-19 | 60% | 170d? | 2007-01-04 | 2008-09-19 | 425d? | 330d | finish no earlier than 2008-09-19 | C1 | 3400h | 2040h | SAES | NSN | robert.zaus@nsn.com | Rel-8 | Andrijana |  |
| 104 | 24.14 | Issues for CT3 TR 29.804 |  | 425d? | 2007-02-05 A | 2008-09-19 | 60% | 170d? | 2007-02-05 | 2008-09-19 | 425d? | 330d | finish no earlier than 2008-09-19 | C3 | 3400h | 2040h | SAES | Ericsson | j.javier.pastor@ericsson.com | Rel-8 | Gwiho |  |
| 105 | 24.15 | Issues for CT4 TR 29.803 |  | 425d? | 2007-01-04 A | 2008-09-19 | 30% | 297.5d? | 2007-01-04 | 2008-09-19 | 425d? | 330d | finish no earlier than 2008-09-19 | C4 | 3400h | 1020h | SAES | Huawei |  | Rel-8 | Kimmo |  |
| 106 | 24.16 | Domain Name System Procedures for Evolved Packet System (DEPS) |  | 119.75d? | 2008-05-30 | 2008-12-15 |  |  | 2008-05-30 | 2008-12-15 | 119.75d? | 270d | finish no earlier than 2008-12-15 | C4 | 958h |  | SAES-DEPS | TeliaSonera | jouni.korhonen@teliasonera.com | Rel-8 | Kimmo |  |
| 107 | 24.17 | CT6 aspects of SAE |  | 425d? | 2007-02-05 | 2008-09-19 |  |  | 2007-02-05 | 2008-09-19 | 425d? | 330d | start no earlier than 2007-02-05 | C6 | 3400h |  | SAES | Nokia | Peter.vestergaard@nokia.com | Rel-8 | Xavier |  |
| 108 | 24.18 | Deleted (covered by 380068): Functions and procedures for SAE to support LCS | milestone | 0d? | 2008-03-03 A | 2008-03-03 A | 100% |  | 2008-03-03 | 2008-03-03 | 0d? |  | finish no earlier than 2008-03-03 | S2 |  |  | SAES-SA-FP_LCS | NSN |  | Rel-8 | Maurice | SP-37 |
| 109 | 24.19 | Deleted (covered by 380064): SAE aspects of Emergency Calls | milestone | 0d? | 2008-03-03 A | 2008-03-03 A | 100% |  | 2008-03-03 | 2008-03-03 | 0d? |  | start no earlier than 2008-03-03 | S2 |  |  | SAES-SA-EmCall | NSN |  | Rel-8 | Maurice | SP-37 |
| 110 | 24.20 | Deleted - CT1 aspects of SAES |  | 16.7d? | 2007-09-04 A | 2007-09-27 A | 100% |  | 2007-09-04 | 2007-09-27 | 16.7d? |  | start no earlier than 2007-09-04 | CP,C1 | 133.62h | 133.62h | SAES-St3 |  |  | Rel-8 | Andrijana | SP-37 |
| 111 | 24.21 | Deleted - CT1 aspects of SAES | milestone | 0d? | 2007-09-04 A | 2007-09-04 A | 100% |  | 2007-09-04 | 2007-09-04 | 0d? |  | start no earlier than 2007-09-04 | C1 |  |  | SAES-St3 |  |  | Rel-8 | Andrijana | SP-37 |
| 112 | 24.22 | Deleted - Interoperability | milestone | 0d? | 2008-03-14 A | 2008-03-14 A | 100% |  | 2008-03-14 | 2008-03-14 | 0d? |  | start no earlier than 2008-03-14 | C1 |  |  | SAES-St3-interop |  |  | Rel-8 | Andrijana | SP-37 |
| 113 | 24.23 | Deleted - CT3 aspects of SAES | milestone | 0d? | 2007-09-04 A | 2007-09-04 A | 100% |  | 2007-09-04 | 2007-09-04 | 0d? |  | start no earlier than 2007-09-04 | C3 |  |  | SAES-St3 |  |  | Rel-8 | Gwiho | SP-37 |
| 114 | 24.24 | Deleted - CT4 aspects of SAES | milestone | 0d? | 2007-09-04 A | 2007-09-04 A | 100% |  | 2007-09-04 | 2007-09-04 | 0d? |  | start no earlier than 2007-09-04 | C4 |  |  | SAES-St3 |  |  | Rel-8 | Kimmo | SP-37 |
| 115 | 24.25 | Deleted - UE to EPC NAS signalling (incl. MBMS and QoS aspects) | milestone | 0d? | 2008-03-14 A | 2008-03-14 A | 100% |  | 2008-03-14 | 2008-03-14 | 0d? |  | start no earlier than 2008-03-14 | C1 |  |  | SAES-St3-sig |  |  | Rel-8 | Andrijana | SP-37 |
| 116 | 24.26 | Deleted -User and Control plane protocols | milestone | 0d? | 2007-09-21 A | 2007-09-21 A | 100% |  | 2007-09-21 | 2007-09-21 | 0d? |  | start no earlier than 2007-09-21 | C4 |  |  | SAES-St3-prot |  |  | Rel-8 | Kimmo | SP-37 |
| 117 | 24.27 | Deleted - GPRS enhancements for LTE access | milestone | 0d? | 2007-09-04 A | 2007-09-04 A | 100% |  | 2007-09-04 | 2007-09-04 | 0d? |  | start no earlier than 2007-09-04 | S2 |  |  | SAES-GPRS_LTE | Vodafone | chris.pudney@vodafone.com | Rel-8 | Maurice | SP-34 |
| 118 | 24.28 | Deleted - Architecture enhancements for non-3GPP accesses | milestone | 0d? | 2007-09-04 A | 2007-09-04 A | 100% |  | 2007-09-04 | 2007-09-04 | 0d? |  | start no earlier than 2007-09-04 | S2 |  |  | SAES-non_3GPP | Motorola | Irfan.Ali@motorola.com | Rel-8 | Maurice | SP-34 |
| 119 | 24.29 | Deleted: Stage 2 of architecture for the 3GPP System Architecture Evolution | milestone | 0d? | 2007-10-02 A | 2007-10-02 A | 100% |  | 2007-10-02 | 2007-10-02 | 0d? |  | start no earlier than 2007-10-02 | S2 |  |  | SAES-St2 | Vodafone | chris.pudney@vodafone.com | Rel-8 | Maurice | SP-34 |
| 120 | 24.30 | Deleted - SA aspects of System Architecture Evolution |  | 384d? | 2006-04-12 A | 2007-10-02 A | 100% |  | 2006-04-12 | 2007-10-02 | 384d? |  | finish no earlier than 2007-10-02 | S2 | 3072h | 3072h | SAES-SA |  |  | Rel-8 | Maurice | SP-34 |

Notes:
- 94: SA#40 Stge 2 completed. CT#40 WID approved / Text3: 23.272, 23.401
- 95: SA#40 completed / Text3: 23.272, 23.401
- 96: CT#40 WID approved / Text3: 24.301, 24.801, 24.008
- 97: CT#40 WID approved / Text3: 23.008
- 98: SA#40 completed / Text3: 23.228, 23.221, 23.203
- 100: 12/07 SA#38 WID approved / Text3: 32.751/2/3/5
- 101: SA#39 WID approved / Text3: 32.426
- 102: SA#38 WID approved / Text3: 32.240/296/251/252/298/299
- 103: CT#39 WID approved / Text3: 24.801
- 104: CT#39 WID approved / Text3: 29.804
- 105: CT#39 WID approved / Text3: 29.803
- 106: CT#40 WID approved / Text3: 23.003, 29.303
- 107: CT#39 WID approved / Text3: 31.102, 31.111
- 108: SA#37 stopped
- 109: SA#37 stopped
- 110: SA#37 stopped
- 111: SA#37 stopped
- 112: SA#37 stopped
- 113: SA#37 stopped
- 114: SA#37 stopped / Text3: 29.803
- 115: SA#37 stopped
- 116: SA#37 stopped
- 117: SA#34 stopped / Text3: 23.401
- 118: SA#34 stopped / Text3: 23.402
- 119: SA#34 stopped / Text3: 23.002, 23.060, 23.107, 23.203, 23.228, 23.234, 23.246, 23.271, 23.279
- 120: SA#34 stopped

| ID | WBS | Task | Type | Duration | Start | Finish | Complete | Remaining | Baseline start | Baseline finish | Baseline duration | Total slack | Constraint | Resources | Work | Actual work | Text1 | Text4 | Text6 | Text8 | Text3 | Text5 | Text12 |
| --- | --- | --- | --- | --- | --- | --- | --- | --- | --- | --- | --- | --- | --- | --- | --- | --- | --- | --- | --- | --- | --- | --- | --- |
| 121 | 25 | **System enhancements for interconnection interfaces between two IMSs** |  | 548d? | 2006-08-16 A | 2008-09-19 | 82% | 98.5d? | 2006-08-16 | 2008-09-19 | 548d? | 330d |  | S2,S5,C3 | 9696h | 5013.2h | IMS_NNI | Orange | Rel-8 | Maurice |  |  |  |
| 122 | 25.1 | Stage 2 for IMS_NNI |  | 120d? | 2007-06-22 A | 2007-12-06 A | 100% |  | 2007-06-22 | 2007-12-06 | 120d? |  | finish no earlier than 2007-12-21 | S2 | 960h | 960h | IMS_NNI | Orange | Rel-8 | Maurice |  |  |  |
| 123 | 25.2 | IMS inter-operator service interconnection interface |  | 341d? | 2007-06-01 A | 2008-09-19 | 65% | 119.35d? | 2007-06-01 | 2008-09-19 | 341d? | 330d | finish no earlier than 2008-09-19 | C3 | 2728h | 1773.2h | FBI2-IOPSI | Telecom Italia | Rel-8 | Gwiho | 29.865 | mauro.ficaccio@telecomitalia.it |  |
| 124 | 25.3 | Charging harmonization for NGN between 3GPP and ATIS-TMOC |  | 51d? | 2006-09-28 A | 2006-12-07 A | 100% |  | 2006-09-28 | 2006-12-07 | 51d? |  | finish no earlier than 2006-12-07 | S5 | 408h | 408h | FBI2-TISP2-CH | Amdocs | Rel-8 | Dionisio | 32.297 |  |  |
| 125 | 25.4 | Deleted - Protocol impact of FBI for TISPAN R2 |  | 152d? | 2006-08-16 A | 2007-03-15 A | 100% |  | 2006-08-16 | 2007-03-15 | 152d? |  | finish no earlier than 2007-03-15 | C1 | 1216h | 1216h | FBI2-TISP2-c1 | Ericsson | Rel-8 | Andrijana |  |  | SP-38 |
| 126 | 25.5 | Deleted (never approved) - Stage 2 of FBI for TISPAN R2 - Rel 8 | milestone | 0d? | 2007-11-30 A | 2007-11-30 A | 100% |  | 2007-11-30 | 2007-11-30 | 0d? |  | finish no earlier than 2007-11-30 | S2 |  |  | FBI2-TISP2-s2 | NSN | Rel-8 | Maurice |  |  | SP-36 |
| 127 | 26 | **IMS Centralized Service Control (ICSRA)** |  | 330d? | 2007-09-03 A | 2008-12-05 | 40% | 197.31d? | 2007-09-03 | 2008-12-05 | 330d? | 275d |  | S1,S2,C1,C3,C4 | 6904h | 2158.4h | ICSRA | AT&T | Rel-8 | Alain |  | Randy Wohlert |  |
| 128 | 26.1 | Stage 1 for ICSRA |  | 138d? | 2007-09-03 A | 2008-03-12 A | 100% |  | 2007-09-03 | 2008-03-12 | 138d? |  | finish no earlier than 2007-12-14 | S1 | 1104h | 1104h | ICSRA | AT&T | Rel-8 | Alain | 22.101 | Randy Wohlert |  |
| 129 | 26.2 | Stage 2 for ICSRA |  | 125d? | 2007-12-14 A | 2008-06-05 A | 100% |  | 2007-12-14 | 2008-06-05 | 125d? |  | start no earlier than 2007-12-14 | S2 | 1000h | 1000h | ICSRA-St2 | ALU | Rel-8 | Maurice | 23.292, 23.206, 22.101 |  |  |
| 130 | 26.3 | Stage 3 for ICSRA – Protocol, Addressing, Subscriber Data |  | 136d? | 2008-05-30 | 2008-12-05 |  |  | 2008-05-30 | 2008-12-05 | 136d? | 275d | start no earlier than 2008-05-30 | C1 | 1088h |  | ICSRA | Ericsson | Rel-8 | Andrijana | 24.292, 24.229 | Sean Schneyer |  |
| 131 | 26.4 | Stage 3 for ICSRA – Protocol, Addressing, Subscriber Data |  | 136d? | 2008-05-30 A | 2008-12-05 | 5% | 129.2d? | 2008-05-30 | 2008-12-05 | 136d? | 275d | start no earlier than 2008-05-30 | C3 | 1088h | 54.4h | ICSRA | Ericsson | Rel-8 | Gwiho | 24.293 | Sean Schneyer |  |
| 132 | 26.5 | Stage 3 for ICSRA – Protocol, Addressing, Subscriber Data |  | 136d? | 2008-05-30 | 2008-12-05 |  |  | 2008-05-30 | 2008-12-05 | 136d? | 275d | start no earlier than 2008-05-30 | C4 | 1088h |  | ICSRA | Ericsson | Rel-8 | Kimmo | 29.292, 23.003, 29.232, 23.018, 29.002 | Sean Schneyer |  |
| 133 | 27 | AS/MRFC stage 2 and 3 work |  | 218d? | 2007-11-14 A | 2008-09-12 | 5% | 207.1d? | 2007-11-14 | 2008-09-12 | 218d? | 335d | finish no earlier than 2008-09-12 | C1 | 1744h | 87.2h | MRFC_TS | HP | Rel-8 | Andrijana | 23.218, 24.229, 24.147, 24.247 | mark.syrett@hp.com |  |
| 134 | 28 | **IMS Multimedia Telephony and Supplementary Services** |  | 421d? | 2007-05-02 A | 2008-12-10 | 39% | 258.61d? | 2007-05-02 | 2008-12-10 | 421d? | 272d |  | S1,S5,C1,C3,C4 | 36526.4h | 11457.5h | IMSTSS | Ericsson | Rel-8 | Andrijana |  |  |  |
| 135 | 28.1 | **General aspects of IMS Sup Services** |  | 270d? | 2007-09-03 A | 2008-09-12 | 87% | 36.15d? | 2007-09-03 | 2008-09-12 | 270d? | 335d |  | S1,C1,C3,C4 | 7752h | 5443.2h | IMSSS-Gal | Telecom Italia | Rel-8 | Alain |  |  |  |
| 136 | 28.1.1 | Service and Capability for Core IMS - inclusion of TISPAN requirements |  | 75d? | 2007-09-03 A | 2007-12-14 A | 100% |  | 2007-09-03 | 2007-12-14 | 75d? |  | finish no earlier than 2007-12-14 | S1 | 600h | 600h | TISCAPR8, CIMS8-TIS | Ericsson | Rel-8 | Alain | 22.228, 22.115, 22.101 | Susana Sabater |  |
| 137 | 28.1.2 | Documentation of TISPAN R1 and R2 in CT1 |  | 208d? | 2007-11-28 A | 2008-09-12 | 95% | 10.4d? | 2007-11-28 | 2008-09-12 | 208d? | 335d | finish no earlier than 2008-09-12 | C1 | 1664h | 1580.8h | REDOC_TIS-C1 | NSN | Rel-8 | Andrijana |  | peter.leis@nsn.com |  |
| 138 | 28.1.3 | Documentation of TISPAN R1 and R2 in CT3 |  | 208d? | 2007-11-28 A | 2008-09-12 | 70% | 62.4d? | 2007-11-28 | 2008-09-12 | 208d? | 335d | finish no earlier than 2008-09-12 | C3 | 1664h | 1164.8h | REDOC_TIS-C3 | NSN | Rel-8 | Gwiho |  | peter.leis@nsn.com |  |
| 139 | 28.1.4 | Documentation of TISPAN R1 and R2 in CT4 |  | 208d? | 2007-11-28 A | 2008-09-12 | 90% | 20.8d? | 2007-11-28 | 2008-09-12 | 208d? | 335d | finish no earlier than 2008-09-12 | C4 | 1664h | 1497.6h | REDOC_TIS-C4 | NSN | Rel-8 | Kimmo |  |  |  |
| 140 | 28.2 | **IMS Multimedia Telephony Service** |  | 328d? | 2007-09-10 A | 2008-12-10 | 37% | 207.02d? | 2007-09-10 | 2008-12-10 | 328d? | 272d |  | S1,S5 | 4568h | 1428.8h | IMS-MMTel | Telecom Italia | Rel-8 | Alain |  |  |  |
| 141 | 28.2.1 | Merging TISPAN MMTel [requirements] for Common IMS |  | 65d? | 2007-09-10 A | 2007-12-07 A | 100% |  | 2007-09-10 | 2007-12-07 | 65d? |  | finish no earlier than 2007-12-07 | S1 | 520h | 520h | TMMTEL | NSN | Rel-8 | Alain | 22.173 |  |  |
| 142 | 28.2.2 | MMTel and Supplementary Services Charging |  | 243d? | 2008-01-07 A | 2008-12-10 | 20% | 194.4d? | 2008-01-07 | 2008-12-10 | 243d? | 272d | finish no earlier than 2008-12-10 | S5 | 1944h | 388.8h | MMTel-CH | ALU | Rel-8 | Dionisio | 32.275, 32.298/299 |  |  |
| 143 | 28.3 | **Call Completion on Busy Subscriber (CCBS)/Call Completion on Non-Reachable (CCNR) on IMS** |  | 418d? | 2007-05-02 A | 2008-12-05 | 7% | 389.07d? | 2007-05-02 | 2008-12-05 | 418d? | 275d |  | C1,C3 | 9552h | 661.01h | CCBS_CCNR | Deutsche Telekom | Rel-8 | Andrijana | 29.163, 24.229, 24.173 | martin.huelsemann@telekom.de |  |
| 144 | 28.3.1 | Stage 3 CCBS_CCNR |  | 358d? | 2007-05-02 A | 2008-09-12 | 15% | 304.3d? | 2007-05-02 | 2008-09-12 | 358d? | 335d | finish no earlier than 2008-09-12 | C1 | 2864h | 429.6h | CCBS_CCNR | Deutsche Telekom | Rel-8 | Andrijana | 24.642, 24.229, 24.173 | martin.huelsemann@telekom.de |  |
| 145 | 28.3.2 | Stage 3 CCBS_CCNR |  | 418d? | 2007-05-02 | 2008-12-05 |  |  | 2007-05-02 | 2008-12-05 | 418d? | 275d | finish no earlier than 2008-12-05 | C3 | 3344h |  | CCBS_CCNR | Deutsche Telekom | Rel-8 | Gwiho | 29.163 | martin.huelsemann@telekom.de |  |

Notes:
- 121: Name changed from "System enhancements for TISPAN Rel2" at SA36
- 122: SA#38 completed
- 123: CP-36: WI approved. C3-36: draft 29.865 advanced.
- 124: SA#33 WID approved
- 125: SA#38 stopped
- 126: SA#36 stopped
- 127: SA#40 SA1/2 completed. CT#40 WID approved.
- 128: SA#38 WID approved. SA#39 completed
- 129: SA#38 WID approved. SA#40 completed
- 130: CT#40 WID approved.
- 131: CT#40 WID approved.
- 132: CT#40 WID approved.
- 133: Triggered by Study UID_7048 (MRFC)
- 136: SA#39 completed
- 141: SA#38 completed
- 142: SA#38 WID approved

| ID | WBS | Task | Duration | Start | Finish | Complete | Remaining | Baseline start | Baseline finish | Baseline duration | Total slack | Constraint | Resources | Work | Actual work | Text1 | Text4 | Text5 | Text6 | Text8 |
| --- | --- | --- | --- | --- | --- | --- | --- | --- | --- | --- | --- | --- | --- | --- | --- | --- | --- | --- | --- | --- |
| 146 | 28.4 | **Flexible Alerting** | 164d? | 2008-01-30 A | 2008-09-15 | 42% | 94.56d? | 2008-01-30 | 2008-09-15 | 164d? | 334d |  | S1,C1 | 3294.4h | 867.2h | FA | Nortel | milanpa@nortel.com | Rel-8 | Alain |
| 147 | 28.4.1 | Stage 1 FA | 92d? | 2008-01-30 A | 2008-06-05 A | 100% |  | 2008-01-30 | 2008-06-05 | 92d? |  |  | S1 | 670.4h | 670.4h | FA | Telecom Italia |  | Rel-8 | Alain |
| 148 | 28.4.2 | Stage 3 FA | 164d? | 2008-01-30 A | 2008-09-15 | 10% | 147.6d? | 2008-01-30 | 2008-09-15 | 164d? | 334d | start no earlier than 2008-01-30 | C1 | 1312h | 131.2h | FA | Nortel | milanpa@nortel.com | Rel-8 | Andrijana |
| 149 | 28.5 | **Communication Wait on IMS** | 211d? | 2007-11-30 A | 2008-09-19 | 5% | 200.58d? | 2007-11-30 | 2008-09-19 | 211d? | 330d |  | C1,C3 | 5024h | 248.19h | CW_IMS | Deutsche Telekom | martin.huelsemann@telekom.de | Rel-8 | Andrijana |
| 150 | 28.5.1 | Stage 3 CW-IMS | 206d? | 2007-11-30 A | 2008-09-12 | 10% | 185.4d? | 2007-11-30 | 2008-09-12 | 206d? | 335d | finish no earlier than 2008-09-12 | C1 | 1648h | 164.8h | CW_IMS | Deutsche Telekom | martin.huelsemann@telekom.de | Rel-8 | Andrijana |
| 151 | 28.5.2 | Stage 3 CW-IMS | 211d? | 2007-11-30 | 2008-09-19 |  |  | 2007-11-30 | 2008-09-19 | 211d? | 330d | finish no earlier than 2008-09-19 | C3 | 1688h |  | CW_IMS | Deutsche Telekom | martin.huelsemann@telekom.de | Rel-8 | Gwiho |
| 152 | 28.6 | Advice of Charge (AoC) support in IMS Charging | 243d? | 2008-01-07 A | 2008-12-10 | 25% | 182.25d? | 2008-01-07 | 2008-12-10 | 243d? | 272d | finish no earlier than 2008-12-10 | S5 | 1944h | 486h | IMSTSS | NSN |  | Rel-8 | Dionisio |
| 153 | 28.7 | Add Interconnection Border Control Function (IBCF) to IMS Charging | 128d? | 2007-09-17 A | 2008-03-12 A | 100% |  | 2007-09-17 | 2008-03-12 | 128d? |  | finish no earlier than 2008-03-12 | S5 | 1024h | 1024h | IMSTSS | ALU |  | Rel-8 | Dionisio |
| 154 | 29 | Harmonization of Gq'/Rx for Common IMS | 171d? | 2008-01-14 A | 2008-09-08 | 20% | 136.8d? | 2008-01-14 | 2008-09-08 | 171d? | 339d | finish no earlier than 2008-09-08 | S2 | 1368h | 273.6h | IMS_Comm_GqRx_Harm | Alcatel-Lucent | geoffrey.cristallo@alcatel-lucent.be | Rel-8 | Maurice |
| 155 | 30 | **Interworking between User-to-User Signalling (UUS) and SIP** | 266d? | 2007-11-30 A | 2008-12-05 | 65% | 93.1d? | 2007-11-30 | 2008-12-05 | 266d? | 275d |  | C1,C3 | 6384h | 4149.6h | UUSIW | Huawei | kadyyang@huawei.com | Rel-8 | Kimmo |
| 156 | 30.1 | Stage 3 MGCF UUSIW | 266d? | 2007-11-30 A | 2008-12-05 | 70% | 79.8d? | 2007-11-30 | 2008-12-05 | 266d? | 275d | finish no earlier than 2008-12-05 | C1 | 2128h | 1489.6h | UUSIW | Huawei | kadyyang@huawei.com | Rel-8 | Andrijana |
| 157 | 30.2 | Stage 3 MGCF UUSIW | 266d? | 2007-11-30 A | 2008-12-05 | 60% | 106.4d? | 2007-11-30 | 2008-12-05 | 266d? | 275d | finish no earlier than 2008-12-05 | C3 | 2128h | 1276.8h | UUSIW | Huawei | kadyyang@huawei.com | Rel-8 | Gwiho |
| 158 | 31 | **Support of Overlap signalling** | 266d? | 2007-11-30 A | 2008-12-05 | 2% | 260.68d? | 2007-11-30 | 2008-12-05 | 266d? | 275d |  | C1,C3 | 6384h | 127.69h | Overlap | Deutsche Telekom | r.jesske@telekom.de | Rel-8 | Gwiho |
| 159 | 31.1 | Stage 3 Overlap (CT1) | 266d? | 2007-11-30 A | 2008-12-05 | 2% | 260.68d? | 2007-11-30 | 2008-12-05 | 266d? | 275d | finish no earlier than 2008-12-05 | C1 | 2128h | 42.57h | Overlap | Deutsche Telekom | r.jesske@telekom.de | Rel-8 | Andrijana |
| 160 | 31.2 | Stage 3 Overlap (CT3) | 266d? | 2007-11-30 A | 2008-12-05 | 2% | 260.68d? | 2007-11-30 | 2008-12-05 | 266d? | 275d | finish no earlier than 2008-12-05 | C3 | 2128h | 42.57h | Overlap | Deutsche Telekom | r.jesske@telekom.de | Rel-8 | Gwiho |
| 161 | 32 | **Maintenance of TISPAN documentation** | 244d? | 2007-07-02 A | 2008-06-05 A | 100% |  | 2007-07-02 | 2008-06-05 | 244d? |  |  | S2,C1,C3,C4 | 5984h | 5984h | MAINTISP | Ericsson |  | Rel-8 | Andrijana |
| 162 | 32.1 | Maintenance of TISPAN R1 | 86d? | 2007-11-09 A | 2008-03-07 A | 100% |  | 2007-11-09 | 2008-03-07 | 86d? |  | start no earlier than 2007-11-09 | C1,C3,C4 | 688h | 688h | MAINT_R1 | ALU | drage@alcatel-lucent.com | Rel-7 | Kimmo |
| 163 | 32.2 | Maintenance of TISPAN R2 | 86d? | 2007-11-09 A | 2008-03-07 A | 100% |  | 2007-11-09 | 2008-03-07 | 86d? |  | start no earlier than 2007-11-09 | C1,C3,C4 | 688h | 688h | MAINT_R2 | ALU | drage@alcatel-lucent.com | Rel-8 | Kimmo |
| 164 | 32.3 | Documentation of TISPAN NGN R1 and R2 in 3GPP SA2 | 104d? | 2008-01-14 A | 2008-06-05 A | 100% |  | 2008-01-14 | 2008-06-05 | 104d? |  | finish no earlier than 2008-06-20 | S2 | 832h | 832h | IMS_Comm_Doc | NSN | jozsef.varga@nsn.com | Rel-8 | Maurice |
| 165 | 32.4 | Maintenance of TISPAN release 1 common IMS | 114d? | 2007-07-02 A | 2007-12-06 A | 100% |  | 2007-07-02 | 2007-12-06 | 114d? |  | finish no earlier than 2007-12-06 | S2,S1 | 912h | 912h | IMS_Comm_Mtce7 | BT, Ericsson | Dick Knight, Raymond Forbes | Rel-7 | Maurice |
| 166 | 32.5 | Maintenance of TISPAN release 2 common IMS | 114d? | 2007-07-02 A | 2007-12-06 A | 100% |  | 2007-07-02 | 2007-12-06 | 114d? |  | finish no earlier than 2007-12-06 | S2 | 912h | 912h | IMS_Comm_Mtce8 | Telecom Italia | antonio.ascolese@telecomitalia.it | Rel-8 | Maurice |
| 167 | 33 | **IMS Service Brokering enhancements** | 69d? | 2005-12-07 A | 2006-03-13 A | 100% |  | 2005-12-07 | 2006-03-13 | 69d? |  |  | S1 | 1104h | 1104h | ISB | Telcordia | jbakker@telcordia.com | Rel-8 | Alain |
| 168 | 33.1 | Stage 1 for ISB | 69d? | 2005-12-07 A | 2006-03-13 A | 100% |  | 2005-12-07 | 2006-03-13 | 69d? |  | finish no earlier than 2006-03-13 | S1 | 552h | 552h | ISB-s1 | Telcordia | jbakker@telcordia.com | Rel-8 | Alain |
| 169 | 34 | **Security Enhancements for IMS** | 466d? | 2007-03-01 A | 2008-12-11 | 54% | 215.24d? | 2007-03-01 | 2008-12-11 | 466d? | 271d |  | S3,C1,C4 | 12000h | 5011.2h | IMS-Sec | Ericsson | Bengt Sahlin | Rel-8 | Dionisio |
| 170 | 34.1 | Stage 2 aspects of IMSSec | 466d? | 2007-03-01 A | 2008-12-11 | 70% | 139.8d? | 2007-03-01 | 2008-12-11 | 466d? | 271d | finish no earlier than 2008-12-11 | S3 | 3728h | 2609.6h | IMS-Sec | Ericsson | Bengt Sahlin | Rel-8 | Dionisio |
| 171 | 34.2 | Stage 3 aspects of IMSSec | 207d? | 2007-06-07 | 2008-03-21 |  |  | 2007-06-07 | 2008-03-21 | 207d? | 460d | finish no earlier than 2008-03-21 | C1,C4 | 1656h |  | IMS-Sec | Ericsson |  | Rel-8 | Andrijana |
| 172 | 34.3 | CT1 part of NASS Bundled Authentication | 218d? | 2007-11-14 A | 2008-09-12 | 40% | 130.8d? | 2007-11-14 | 2008-09-12 | 218d? | 335d | start no earlier than 2007-11-14 | C1 | 1744h | 697.6h | NBA | ALU | drage@alcatel-lucent.com | Rel-8 | Andrijana |
| 173 | 34.4 | CT4 part of NASS Bundled Authentication | 143d? | 2007-11-14 A | 2008-05-30 A | 100% |  | 2007-11-14 | 2008-05-30 | 143d? |  | start no earlier than 2007-11-14 | C4 | 1144h | 1144h | NBA-CT4 | ALU |  | Rel-8 | Kimmo |

Notes:
- 147: SA#39: SA1 consider "Pilot Identity" concept need. SA#40 completed / Text3: 22.173
- 148: Text3: 24.239, 24.173
- 149: Text3: 29.163, 24.229, 24.173
- 150: Text3: 24.615, 24.229, 24.173
- 151: Text3: 29.163
- 152: SA#38 WID approved / Text3: 32.280, 32.240/260/296/298/299
- 153: SA#39 completed / Text3: 32.240/260/298/299
- 154: WID approved SA#38. per OPs & ETSI GA 39. This is a joint effort of SA2 and TISPAN2. SA#40 moved to Rel-9. / Text3: 23.8xx, 23203
- 155: Text3: 29.163, 24.279, 24.229
- 156: C3-46: WID in C1-073199/ C3-071126 / Text3: 24.279, 24.229
- 157: C3-46: WID in C1-073199/ C3-071126 / Text3: 29.163
- 158: CT#38 WID approved / Text3: 29.163, 24.229, 29.228, 29.229
- 159: CT#38 WID approved / Text3: 24.229
- 160: CT#38 WID approved / Text3: 29.163, 29.228, 29.229
- 161: SA#40 completed
- 162: CT#39 completed / Text3: 24.229, 24.127, 29.162, 29.163, 29.228, 29.229, 24.xxx
- 163: CT#39 completed / Text3: 24.229, 24.127, 29.162, 29.163, 29.228, 29.229, 24.xxx
- 164: WID approved SA#38. per OPs & ETSI GA 39. This is a joint effort of SA WG2 and TISPAN WG2. SA#40 completed / Text3: 23.228, 23.204, 23.167
- 165: WID and TSs approved at SA#38. SA#40 updated WID SP-070915=>SP-080315 / Text3: 22.273, 23.406, 23.417, 23.508, 23.509, 23.511, 22.401, 22.173
- 166: SA#38 approved WID and TSs / Text3: 23.517(ETSIES282.007), 23.506(ETSI182.006), 23.521(ETSI182.021), 23.507(ETSI182.007)
- 167: No Rel-8 changes / Text3: 22.228
- 168: No Rel-8 changes / Text3: 22.228
- 169: SA#36 WID approved
- 170: SA#39: SA3 to remove Stage 3 from 33.178-100 for CTx work. SA#40 withdrawn 33.178-100. / Text3: 33.203, 33.141, 33.978, 33.828, 33.803
- 171: SA#39: SA3 to remove Stage 3 from 33.178-100 for CT1 work
- 172: Text3: 24.229
- 173: CT#40 completed / Text3: 29.229, 29.228, 23.008

| ID | WBS | Task | Duration | Start | Finish | Complete | Remaining | Baseline start | Baseline finish | Baseline duration | Total slack | Constraint | Resources | Work | Actual work | Text1 | Text4 | Text5 | Text6 | Text8 | Text3 |
| --- | --- | --- | --- | --- | --- | --- | --- | --- | --- | --- | --- | --- | --- | --- | --- | --- | --- | --- | --- | --- | --- |
| 174 | 35 | **IMS System enhancements for corporate network access** | 395d? | 2007-06-22 A | 2008-12-25 | 27% | 288.67d? | 2007-06-22 | 2008-12-25 | 395d? | 261d |  | S1,S2,C1,C4 | 8764.8h | 2359.47h | IMS_Corp | Orange | Delphin Barankanira | Rel-8 | Maurice |  |
| 175 | 35.1 | SA1 aspects of IMS_Corp | 23.6d? | 2008-03-12 A | 2008-06-05 A | 100% |  | 2008-03-12 | 2008-06-05 | 23.6d? |  | finish no earlier than 2008-06-05 | S1 | 188.8h | 188.8h | IMS_Corp | Telecom Italia |  | Rel-8 | Alain |  |
| 176 | 35.2 | SA2 aspects of IMS_Corp | 395d? | 2007-06-22 A | 2008-12-25 | 15% | 335.75d? | 2007-06-22 | 2008-12-25 | 395d? | 261d | finish no earlier than 2008-12-25 | S2 | 3160h | 474h | IMS_Corp | Orange | Delphin Barankanira | Rel-8 | Maurice | 23.228 |
| 177 | 35.3 | CT1 aspects of IMS_Corp | 141d? | 2008-03-07 A | 2008-09-19 | 25% | 105.75d? | 2008-03-07 | 2008-09-19 | 141d? | 330d | finish no earlier than 2008-09-19 | C1 | 1128h | 282h | IMS_Corp | ALU | drage@alcatel-lucent.com | Rel-8 | Andrijana | 24.229, 24.503 |
| 178 | 35.4 | CT4 aspects of IMS_Corp | 141d? | 2008-02-26 A | 2008-09-19 | 50% | 70.5d? | 2008-02-26 | 2008-09-19 | 141d? | 330d | finish no earlier than 2008-09-19 | C4 | 1128h | 564h | IMS_Corp | ALU | drage@alcatel-lucent.com | Rel-8 | Kimmo | 29.228, 29.229, 23.003, 23.008, 29.433 |
| 179 | 36 | **IMS Enhancements for support of Packet Cable access** | 388d? | 2006-12-06 A | 2008-05-30 A | 100% |  | 2006-12-06 | 2008-05-30 | 388d? |  |  | S2,S3,C1,C3,C4 | 27448h | 27448h | PktCbl | NSN |  | Rel-8 | Maurice |  |
| 180 | 36.1 | **IMS Enhancements for Cable Client Types and Deployment Models** | 345d? | 2007-02-05 A | 2008-05-30 A | 100% |  | 2007-02-05 | 2008-05-30 | 345d? |  |  | S2,C1 | 6992h | 6992h | PktCbl-Deploy |  |  | Rel-8 | Maurice |  |
| 181 | 36.1.1 | Architecture aspects of PktCbl-Deploy | 219d? | 2007-02-05 A | 2007-12-06 A | 100% |  | 2007-02-05 | 2007-12-06 | 219d? |  | finish no earlier than 2007-12-03 | S2 | 1752h | 1752h | PktCbl-Deploy |  |  | Rel-8 | Maurice |  |
| 182 | 36.1.2 | CT1 aspects of PktCbl-Deploy | 310d? | 2007-03-26 A | 2008-05-30 A | 100% |  | 2007-03-26 | 2008-05-30 | 310d? |  | finish no earlier than 2008-06-15 | C1 | 2480h | 2480h | PktCbl-Deploy | Cablelabs | D.Hancock@ CableLabs.com | Rel-8 | Andrijana |  |
| 183 | 36.2 | **IMS Inter-working aspects in Support of Cable Regulatory requirements** | 290d? | 2007-02-05 A | 2008-03-15 A | 100% |  | 2007-02-05 | 2008-03-15 | 290d? |  |  | S2,C1,C3 | 5640h | 5640h | PktCbl-Intw | Cablelabs | B.McKibben@CableLabs.com | Rel-8 | Maurice | 23.228 |
| 184 | 36.2.1 | Architecture PktCbl-Interwork | 160d? | 2007-02-05 A | 2007-09-14 A | 100% |  | 2007-02-05 | 2007-09-14 | 160d? |  | start no earlier than 2007-02-05 | S2 | 1280h | 1280h | PktCbl-Intw | Cablelabs | B.McKibben@CableLabs.com | Rel-8 | Maurice | 23.228 |
| 185 | 36.2.2 | CT1,CT3 PktCbl-Interwork | 255d? | 2007-03-26 A | 2008-03-15 A | 100% |  | 2007-03-26 | 2008-03-15 | 255d? |  | finish no earlier than 2008-03-15 | C1,C3 | 2040h | 2040h | PktCbl-Intw | Cablelabs | D.Hancock@ CableLabs.com | Rel-8 | Andrijana | 24.229 |
| 186 | 36.3 | **IMS Enhancements for Security Requirements in Support of Cable Deployments** | 388d? | 2006-12-06 A | 2008-05-30 A | 100% |  | 2006-12-06 | 2008-05-30 | 388d? |  |  | S3,C1,C3,C4 | 11712h | 11712h | PktCbl-Sec | Cablelabs | s.dotson@cablelabs.com | Rel-8 | Dionisio |  |
| 187 | 36.3.1 | S3 Aspects of PktCbl-Sec | 331d? | 2006-12-06 A | 2008-03-12 A | 100% |  | 2006-12-06 | 2008-03-12 | 331d? |  | finish no earlier than 2007-12-20 | S3 | 2648h | 2648h | PktCbl-Sec | Cablelabs | s.dotson@cablelabs.com | Rel-8 | Dionisio | 33.203, 33.210, 33.220, 24.229 |
| 188 | 36.3.2 | CT1 Aspects of PktCbl-Sec | 310d? | 2007-03-26 A | 2008-05-30 A | 100% |  | 2007-03-26 | 2008-05-30 | 310d? |  | finish no earlier than 2008-06-06 | C1 | 2480h | 2480h | PktCbl-Sec | Cablelabs | D.Hancock@ CableLabs.com | Rel-8 | Andrijana | 24.229, 24.109 |
| 189 | 36.3.3 | CT3 Aspects of PktCbl-Sec | 180d? | 2007-03-26 A | 2007-11-30 A | 100% |  | 2007-03-26 | 2007-11-30 | 180d? |  | finish no earlier than 2008-03-15 | C3 | 1440h | 1440h | PktCbl-Intw | Cablelabs | D.Hancock@ CableLabs.com | Rel-8 | Gwiho | 24.229, 24.109 |
| 190 | 36.3.4 | CT4 Aspects of PktCbl-Sec | 255d? | 2007-03-26 A | 2008-03-14 A | 100% |  | 2007-03-26 | 2008-03-14 | 255d? |  | finish no earlier than 2008-03-14 | C4 | 2040h | 2040h | PktCbl-Sec | Cablelabs | D.Hancock@ CableLabs.com | Rel-8 | Kimmo | 29.228, 29.229, 23.008, |
| 191 | 37 | **Multimedia interworking between IMS and CS networks** | 846d? | 2005-09-23 A | 2008-12-19 | 87% | 105.86d? | 2005-09-23 | 2008-12-19 | 846d? | 265d |  | S2,C3,C4 | 15792h | 8286.8h | MIW-IMS | Vodafone | nico.gabriele@vodafone.com | Rel-8 | Gwiho | 29.163, 29.332 |
| 192 | 37.1 | Note: Stages 1 and 2 defined in earlier Release | 49d? | 2005-09-23 A | 2005-11-30 A | 100% |  | 2005-09-23 | 2005-11-30 | 49d? |  | start no earlier than 2005-09-23 | S2 | 392h | 392h | MIW-IMS | Vodafone | nico.gabriele@vodafone.com | Rel-8 | Maurice |  |
| 193 | 37.2 | Stage 3 of MW-IMS | 571d? | 2005-09-23 A | 2007-11-30 A | 100% |  | 2005-09-23 | 2007-11-30 | 571d? |  | finish no earlier than 2007-09-14 | C3 | 4568h | 4568h | MWIMS-St3 | Vodafone | nico.gabriele@vodafone.com | Rel-7 | Gwiho | 29.163 |
| 194 | 37.3 | Stage 3 for MW-IMS, MONA extension | 225d? | 2007-11-05 A | 2008-09-12 | 75% | 56.25d? | 2007-11-05 | 2008-09-12 | 225d? | 335d | finish no earlier than 2008-09-12 | C3 | 1800h | 1350h | MIW-IMS | Vodafone | Christer.Holmberg@ericsson.com | Rel-8 | Gwiho | 29.163 |
| 195 | 37.4 | Mn interface (MGCF – IM MGW) | 283d? | 2007-11-21 A | 2008-12-19 | 70% | 84.9d? | 2007-11-21 | 2008-12-19 | 283d? | 265d | finish no earlier than 2008-12-19 | C4 | 2264h | 1584.8h | MIW-IMS | Vodafone | Christer.Holmberg@ericsson.com | Rel-8 | Kimmo | 29.332 |
| 196 | 38 | IMS Stage-3 IETF Protocol Alignment | 387d? | 2007-06-22 A | 2008-12-15 | 50% | 193.5d? | 2007-06-22 | 2008-12-15 | 387d? | 269d | finish no earlier than 2008-12-15 | C1 | 3096h | 1548h | IMSProtoc2 | ALU | drage@alcatel-lucent.com | Rel-8 | Andrijana | 23.218, 24.229 |
| 197 | 39 | **3GPP2 Input to Common IMS** | 200d? | 2008-03-07 A | 2008-12-11 | 31% | 138.92d? | 2008-03-07 | 2008-12-11 | 200d? | 271d |  | S1,S2,S3,C1,C3,C4 | 8205.2h | 2505.83h | CIMS_3GPP2 | Nortel | Amar Deol | Rel-8 | Alain |  |
| 198 | 39.1 | Stage 1 CIMS_3GPP2 (SA1) | 30.65d? | 2008-03-12 A | 2008-06-05 A | 100% |  | 2008-03-12 | 2008-06-05 | 30.65d? |  | finish no earlier than 2008-06-12 | S1 | 245.2h | 245.2h | CIMS_3GPP2 | Nortel | Amar Deol | Rel-8 | Alain | 22.228, 22.173, 22.101, 22.153 |
| 199 | 39.2 | Stage 2 CIMS_3GPP2 (SA2) | 62d? | 2008-03-12 A | 2008-06-05 A | 100% |  | 2008-03-12 | 2008-06-05 | 62d? |  | finish no earlier than 2008-09-11 | S2 | 496h | 496h | IMS_Common | NSN |  | Rel-8 | Maurice | 23.002, 23.141, 23.203, 23.167, 23.228 |
| 200 | 39.3 | Security CIMS_3GPP2 (SA3) | 197d? | 2008-03-12 A | 2008-12-11 | 30% | 137.9d? | 2008-03-12 | 2008-12-11 | 197d? | 271d | finish no earlier than 2008-12-11 | S3 | 1576h | 472.8h | IMS_Common | NSN |  | Rel-8 | Dionisio | 33.141, 33.203, 33.210 |
| 201 | 39.4 | Stage 3 CIMS_3GPP2 (CT1) | 200d? | 2008-03-07 A | 2008-12-11 | 40% | 120d? | 2008-03-07 | 2008-12-11 | 200d? | 271d | finish no earlier than 2008-12-11 | C1 | 1600h | 640h | REDOC_3GPP2 | ALU | orsic@alcatel-lucent.com | Rel-8 | Andrijana |  |
| 202 | 39.5 | Stage 3 CIMS_3GPP2 (CT3) | 136d? | 2008-03-07 A | 2008-09-12 | 15% | 115.6d? | 2008-03-07 | 2008-09-12 | 136d? | 335d | finish no earlier than 2008-09-12 | C3 | 1088h | 163.2h | REDOC_3GPP2 | ALU | orsic@alcatel-lucent.com | Rel-8 | Gwiho |  |
| 203 | 39.6 | Stage 3 CIMS_3GPP2 (CT4) | 200d? | 2008-03-07 | 2008-12-11 |  |  | 2008-03-07 | 2008-12-11 | 200d? | 271d | finish no earlier than 2008-12-11 | C4 | 1600h |  | REDOC_3GPP2 | ALU | Milo Orsic, Alcatel-Lucent | Rel-8 | Kimmo |  |

Notes:
- 174: SA#40 SA2 proposed Rel-9 move. Rel-8 exception to Sep 2008 (await output of Workshop)
- 175: SA#40 completed
- 176: SA#40 SA2 proposed Rel-9 move. Rel-8 exception to Sep 2008 (await output of Workshop)
- 177: CP#39 WID approved
- 178: CP#39 WID approved
- 179: CT#40 completed
- 180: CT#40 completed
- 181: SA#38 completed
- 182: CT#40 completed
- 183: CT#39 completed
- 184: SA#37 completed
- 185: CT#39 completed
- 186: CT#40 completed
- 187: SA#39 completed
- 188: CT#40 completed
- 189: CT#38 completed
- 190: CT#39 completed
- 192: SA#31 Moved from FS section Feb 2006
- 193: Moved from R7 WP because it is part of Feature 713024. This feature was extended to R8 by the inclusion (at last November's CT3 meeting) of a stage 3 extension covering MONA (WI 380021)
- 197: SA#39 WID approved. SA#40 Stage 1/2 completed
- 198: SA#39 WID approved & Stage 1 exception Jun 2008. SA#40 completed
- 199: SA#39 WID approved. SA#40 completed
- 200: SA#39 WID approved. SA#40 exception to Sep 2008.
- 201: CT#39 WID approved. CT1 approved CRs with REDOC_3GPP2
- 202: CT#39 WID approved
- 203: CT#39 WID approved

| ID | WBS | Task | Type | Duration | Start | Finish | Complete | Remaining | Baseline start | Baseline finish | Baseline duration | Total slack | Constraint | Resources | Work | Actual work | Text1 | Text4 | Text5 | Text6 | Text8 | Text3 | Text12 |
| --- | --- | --- | --- | --- | --- | --- | --- | --- | --- | --- | --- | --- | --- | --- | --- | --- | --- | --- | --- | --- | --- | --- | --- |
| 204 | 40 | **IMS Service Continuity** |  | 197d? | 2008-03-12 A | 2008-12-11 | 47% | 104.47d? | 2008-03-12 | 2008-12-11 | 197d? | 271d |  | S1,S2,C1 | 3688h | 1448h | IMS-Cont | LG Electronics | JaeSeung SONG (anthonys@lge.com) | Rel-8 | Maurice |  |  |
| 205 | 40.1 | Stage 1 IMS Service Continuity |  | 62d? | 2008-03-12 A | 2008-06-05 A | 100% |  | 2008-03-12 | 2008-06-05 | 62d? |  | start no earlier than 2008-03-12 | S1 | 496h | 496h | IMS-Cont | LG Electronics | JaeSeung SONG (anthonys@lge.com) | Rel-8 | Alain |  |  |
| 206 | 40.2 | Stage 2 IMS Service Continuity |  | 62d? | 2008-03-12 A | 2008-06-05 A | 100% |  | 2008-03-12 | 2008-06-05 | 62d? |  | finish no earlier than 2008-06-05 | S2 | 496h | 496h | IMS-Cont | LG Electronics | JaeSeung SONG (anthonys@lge.com) | Rel-8 | Maurice | 23.237, 23.292 |  |
| 207 | 40.3 | Stage 3 IMS Service Continuity |  | 140d? | 2008-05-30 | 2008-12-11 |  |  | 2008-05-30 | 2008-12-11 | 140d? | 271d | finish no earlier than 2008-12-11 | C1 | 1120h |  | IMS-Cont | Huawei | kadyyang@huawei.com | Rel-8 | Maurice | 24.237, 24.229 |  |
| 208 | 41 | IMS initiated and controlled PSS and MBMS User Service |  | 197d? | 2008-03-12 A | 2008-12-11 | 10% | 177.3d? | 2008-03-12 | 2008-12-11 | 197d? | 271d |  | S4 | 1003.2h |  | IMS_PSS_MBMS_US | FT, Ericsson | olle.franceschi@ericsson.com | Rel-8 | Paolo | 26.xyz, 26.234, 26.346 |  |
| 209 | 42 | **IMS Restoration Procedures** |  | 142d? | 2008-05-30 | 2008-12-15 |  |  | 2008-05-30 | 2008-12-15 | 142d? | 269d |  | C4,C1 | 3408h |  | IMS_RP | Ericsson | german.blanco@ericsson.com | Rel-8 | Kimmo | 23.320, 29.228, 29.229, 29.230, 24.229 |  |
| 210 | 42.1 | IMS Restoration Procedures |  | 142d? | 2008-05-30 | 2008-12-15 |  |  | 2008-05-30 | 2008-12-15 | 142d? | 269d | finish no earlier than 2008-12-15 | C4 | 1136h |  | IMS_RP | Ericsson | german.blanco@ericsson.com | Rel-8 | Kimmo | 23.320, 29.228, 29.229, 29.230 |  |
| 211 | 42.2 | IMS Restoration Procedures |  | 142d? | 2008-05-30 | 2008-12-15 |  |  | 2008-05-30 | 2008-12-15 | 142d? | 269d | finish no earlier than 2008-12-15 | C1 | 1136h |  | IMS_RP | Ericsson | german.blanco@ericsson.com | Rel-8 | Andrijana | 24.229 |  |
| 212 | 43 | **I-WLAN Network Selection Principle (NSP)** |  | 326d? | 2007-06-14 A | 2008-09-12 | 60% | 130.4d? | 2007-06-14 | 2008-09-12 | 326d? | 335d |  | S1,C1 | 3696h | 2217.6h | IWLANNSP | Telefonica O2 | chris.friel@o2.com | Rel-8 | Alain | 22.234, 24.234 |  |
| 213 | 43.1 | Stage 1 for I-WLAN NSP | milestone | 0d? | 2007-06-14 A | 2007-06-14 A | 100% |  | 2007-06-14 | 2007-06-14 | 0d? |  |  | S1 |  |  | IWLANNSP | Telefonica O2 | chris.friel@o2.com | Rel-8 | Alain | 22.234 |  |
| 214 | 43.2 | Stage 3 for I-WLAN NSP |  | 136d? | 2008-03-07 A | 2008-09-12 | 60% | 54.4d? | 2008-03-07 | 2008-09-12 | 136d? | 335d | finish no earlier than 2008-09-12 | C1 | 1088h | 652.8h | IWLANNSP | RIM |  | Rel-8 | Andrijana | 24.234 |  |
| 215 | 44 | **Mobility between 3GPP-WLAN Interworking and 3GPP Systems** |  | 326d? | 2007-09-14 A | 2008-12-12 | 57% | 138.87d? | 2007-09-14 | 2008-12-12 | 326d? | 270d |  | S2 | 5256h | 3017.04h | IWLAN_Mob | Orange | xiaobao.chen@orange-ftgroup.com | Rel-8 | Maurice | 23.234 |  |
| 216 | 44.1 | Stage 2: I-WLAN Mobility |  | 190d? | 2007-09-14 A | 2008-06-05 A | 100% |  | 2007-09-14 | 2008-06-05 | 190d? |  | finish no earlier than 2008-09-08 | S2 | 1520h | 1520h | IWLAN_Mob | Orange | xiaobao.chen@orange-ftgroup.com | Rel-8 | Maurice | 23.234 |  |
| 217 | 44.2 | CT1 aspects of I-WLAN Mobility |  | 141d? | 2008-05-30 | 2008-12-12 |  |  | 2008-05-30 | 2008-12-12 | 141d? | 270d | finish no earlier than 2008-12-12 | C1 | 1128h |  | IWLAN_Mob | Orange | reina.nader@orange-ftgroup.com | Rel-8 | Andrijana | 24.327, 24.303 |  |
| 218 | 45 | **Enhancements for VGCS Applications (EVA)** |  | 653d? | 2006-03-15 A | 2008-09-12 | 98% | 11.09d? | 2006-03-15 | 2008-09-12 | 653d? | 335d |  | S1,C1,C4,G2 | 19256h | 15321.6h | EVA | Nortel | deola@nortel.com | Rel-8 | Alain |  |  |
| 219 | 45.1 | SA1 aspects of EVA |  | 191d? | 2006-03-15 A | 2006-12-06 A | 100% |  | 2006-03-15 | 2006-12-06 | 191d? |  | finish no earlier than 2006-12-06 | S1 | 1528h | 1528h | EVA-s1 | Nortel | deola@nortel.com | Rel-8 | Alain | 42.068 |  |
| 220 | 45.2 | VGCS/VBS and GPRS Interactions |  | 145d? | 2007-09-03 A | 2008-03-21 A | 100% |  | 2007-09-03 | 2008-03-21 | 145d? |  | finish no earlier than 2008-03-21 | S1 | 1160h | 1160h | EVA | Huawei |  | Rel-8 | Alain | 42.068, 42.069 |  |
| 221 | 45.3 | CT1 aspects of EVA |  | 596d? | 2006-06-02 A | 2008-09-12 | 95% | 29.8d? | 2006-06-02 | 2008-09-12 | 596d? | 335d | finish no earlier than 2008-09-12 | C1 | 4768h | 4529.6h | EVA | Nortel | milanpa@nortel.com | Rel-8 | Andrijana | 43.068, 44.068 |  |
| 222 | 45.4 | CT4 aspects of EVA |  | 391d? | 2006-06-02 A | 2007-11-30 A | 100% |  | 2006-06-02 | 2007-11-30 | 391d? |  | finish no earlier than 2007-06-01 | C4 | 3128h | 3128h | EVA | Nortel |  | Rel-8 | Kimmo | 29.002 |  |
| 223 | 45.5 | GERAN2 aspects of EVA |  | 431d? | 2006-06-30 A | 2008-02-22 A | 100% |  | 2006-06-30 | 2008-02-22 | 431d? |  | finish no earlier than 2008-02-22 | G2 | 3448h | 3448h | EVA-EVGCSA | Nortel | frank.billenkamp@nortel.com | Rel-8 | Gert | 44.018, 48.008 |  |
| 224 | 46 | **Personal Network Management** |  | 835d? | 2005-07-11 A | 2008-09-19 | 75% | 211.6d? | 2005-07-11 | 2008-09-19 | 835d? | 330d |  | S1,C1 | 21288h | 10908.8h | PNM | Vodafone | armin.toepfer@vodafone.com | Rel-8 | Alain |  |  |
| 225 | 46.1 | Stage 1 for PNM |  | 276d? | 2005-07-11 A | 2006-07-31 A | 100% |  | 2005-07-11 | 2006-07-31 | 276d? |  | start no earlier than 2005-07-11 | S1 | 2208h | 2208h | PNM | Vodafone | armin.toepfer@vodafone.com | Rel-8 | Alain | 22.259 |  |
| 226 | 46.2 | Stage 2 for PNM |  | 385d? | 2007-03-26 A | 2008-09-12 | 96% | 15.4d? | 2007-03-26 | 2008-09-12 | 385d? | 335d | finish no earlier than 2008-09-12 | C1 | 3080h | 2956.8h | PNM | Vodafone | yang.lu@vodafone.com | Rel-8 | Andrijana | 23.259 |  |
| 227 | 46.3 | **Stage 3 for PNM** |  | 390d? | 2007-03-26 A | 2008-09-19 | 55% | 175.37d? | 2007-03-26 | 2008-09-19 | 390d? | 330d |  | C1,C4 | 9320h | 3536h | PNM | Vodafone | yang.lu@vodafone.com | Rel-8 | Andrijana |  |  |
| 228 | 46.3.1 | CT1 aspects of Stage 3 PNM |  | 390d? | 2007-03-26 A | 2008-09-19 | 60% | 156d? | 2007-03-26 | 2008-09-19 | 390d? | 330d | finish no earlier than 2008-09-19 | C1 | 3120h | 1872h | PNM | Vodafone | yang.lu@vodafone.com | Rel-8 | Andrijana | 24.259, 24.229 |  |
| 229 | 46.3.2 | CT4 aspects of Stage 3 PNM |  | 385d? | 2007-03-26 A | 2008-09-12 | 50% | 192.5d? | 2007-03-26 | 2008-09-12 | 385d? | 335d | finish no earlier than 2008-09-12 | C4 | 3080h | 1540h | PNM | Vodafone |  | Rel-8 | Kimmo | 23.008, 23.018, 29.002, 29.328, 29.329 |  |
| 230 | 46.4 | Deleted - Actual Requirements of PNM | milestone | 0d? | 2007-03-26 A | 2007-03-26 A | 100% |  | 2007-03-26 | 2007-03-26 | 0d? |  | finish no earlier than 2007-03-26 | C1 |  |  | PNM | Ericsson |  | Rel-8 | Andrijana |  | SP-37 |

Notes:
- 204: SA#40 Stage 1/2 completed. CT#40 WID approved
- 205: SA#40 completed
- 206: SA#40 completed
- 207: CT#40 WID approved
- 208: SA#39 WID approved
- 209: CT#40 WID approved. Spin-off TR 23.820 FS UID_350018 (FS_IMS_RP)
- 210: CT#40 WID approved.
- 211: CT#40 WID approved.
- 212: SA#36 Stage 1 completed
- 213: SA#36 completed
- 215: SA#40 Stage 2 completed. CT#40 WID approved
- 216: SA#40 completed
- 217: CT#40 WID approved
- 218: Stage 1/2 completed
- 219: SA#38 completed
- 220: SA#39 completed
- 221: 06/08=>09/08
- 222: CT#38 completed
- 223: GP#37 completed
- 224: Feb 06 moved FS=>Feature. SA#31 Stage 1 completed. SA#40 WID updated with reduced scope SP-060574=>SP-080327
- 225: SA#31 completed. SA#40 WID updated SP-060574=>SP-080327
- 227: Moved from FS section Feb 06: SP-33: Create new section to capture the PNM stage 2 aspects and identify any impacts to existing stage 2 specifications.
- 230: SA#37 stopped

| ID | WBS | Task | Duration | Start | Finish | Complete | Remaining | Baseline start | Baseline finish | Baseline duration | Total slack | Constraint | Resources | Work | Actual work | Text1 | Text3 | Text4 | Text5 | Text6 | Text8 |
| --- | --- | --- | --- | --- | --- | --- | --- | --- | --- | --- | --- | --- | --- | --- | --- | --- | --- | --- | --- | --- | --- |
| 231 | 47 | **eCall Data Transfer** | 577d? | 2006-09-28 A | 2008-12-12 | 73% | 156.16d? | 2006-09-28 | 2008-12-12 | 577d? | 270d |  | S1 | 8784h | 6406.75h | Edata | 22.101, 22.105 | Airbiquity | rrobinson@airbiquity.com | Rel-8 | Alain |
| 232 | 47.1 | eData Requirements | 380d? | 2006-09-28 A | 2008-03-12 A | 100% |  | 2006-09-28 | 2008-03-12 | 380d? |  | finish no earlier than 2006-12-07 | S1 | 3040h | 3040h | EData | 22.101, 22.105 | Airbiquity | rrobinson@airbiquity.com | Rel-8 | Alain |
| 233 | 47.2 | Transfer of data during an emergency call | 141d? | 2008-05-30 | 2008-12-12 |  |  | 2008-05-30 | 2008-12-12 | 141d? | 270d | start no earlier than 2008-05-30 | C1 | 1128h |  | EData | 24.008 | T-Mobile | Dieter Jacobsohn | Rel-8 | Kimmo |
| 234 | 48 | eCall data transfer Phase 2: Comparison of alternative in-band modem solutions and standardization of one in-band modem solution | 391d? | 2007-12-06 A | 2009-06-04 | 50% | 195.5d? | 2007-12-06 | 2009-06-04 | 391d? | 146d | finish no earlier than 2009-06-04 | S4 | 3128h | 1564h | eCall_Phase2 | 26.xxx, 26.9xx | Airbiquity | lhong@airbiquity.com & rrobinson@airbiquity.com | Rel-8 | Paolo |
| 235 | 49 | **IP Interconnection of Services** | 70d? | 2007-12-06 A | 2008-03-12 A | 100% |  | 2007-12-06 | 2008-03-12 | 70d? |  |  | S1 | 1120h | 1120h | IPinterc | 22.101, 22.228 | Telefonica O2 | chris.friel@O2.com | Rel-8 | Alain |
| 236 | 49.1 | Stage 1 for Ipinterc | 70d? | 2007-12-06 A | 2008-03-12 A | 100% |  | 2007-12-06 | 2008-03-12 | 70d? |  | start no earlier than 2007-12-06 | S1 | 560h | 560h | IPinterc | 22.101, 22.228 | Telefonica O2 | chris.friel@O2.com | Rel-8 | Alain |
| 237 | 50 | **Support of (G)MSC-S – (G)MSC-S Nc Interface based on the SIP-I protocol** | 326d? | 2007-09-14 A | 2008-12-12 | 44% | 184.03d? | 2007-09-14 | 2008-12-12 | 326d? | 270d |  | C4,C3 | 12256h | 3951.4h | SIP_Nc |  | Vodafone | David.Hutton@vodafone.com | Rel-8 | Kimmo |
| 238 | 50.1 | SIP-I based circuit-switched core network; Stage 2 | 261d? | 2007-09-14 A | 2008-09-12 | 85% | 39.15d? | 2007-09-14 | 2008-09-12 | 261d? | 335d | finish no earlier than 2008-09-12 | C4 | 2088h | 1774.8h | SIP_Nc-St2 | 23.231, 23.153, 23.205 | Vodafone | David.Hutton@vodafone.com | Rel-8 | Kimmo |
| 239 | 50.2 | Application of SIP-I Protocols to Circuit Switched (CS) core network architecture; Stage 3 | 261d? | 2007-09-14 A | 2008-09-12 | 70% | 78.3d? | 2007-09-14 | 2008-09-12 | 261d? | 335d | finish no earlier than 2008-09-12 | C4 | 2088h | 1461.6h | SIP_Nc-St3 | 29.231, 29.232, 29.332 | Vodafone | David.Hutton@vodafone.com | Rel-8 | Kimmo |
| 240 | 50.3 | Interworking between the 3GPP CS domain with SIP-I as signalling protocol and other networks | 261d? | 2007-09-14 A | 2008-09-12 | 20% | 208.8d? | 2007-09-14 | 2008-09-12 | 261d? | 335d | finish no earlier than 2008-09-12 | C3 | 2088h | 417.6h | SIP_Nc | 29.235, 23.172, 23.202, 29.007, 29.163, 29.414, 29.415 | NSN | Thomas.Belling@nsn.com | Rel-8 | Gwiho |
| 241 | 50.4 | **CS-IBCF and CS-TrGW definition in 3GPP specifications** | 141d? | 2008-05-30 A | 2008-12-12 | 3% | 137.47d? | 2008-05-30 | 2008-12-12 | 141d? | 270d |  | C3,C4 | 3384h | 84.6h | CS-IBCF |  | Telecom Italia | mauro.ficaccio@telecomitalia.it | Rel-8 | Kimmo |
| 242 | 50.4.1 | CT3 aspects CS-IBCF | 141d? | 2008-05-30 A | 2008-12-12 | 5% | 133.95d? | 2008-05-30 | 2008-12-12 | 141d? | 270d | finish no earlier than 2008-12-12 | C3 | 1128h | 56.4h | CS-IBCF | 29.235 | Telecom Italia | mauro.ficaccio@telecomitalia.it | Rel-8 | Kimmo |
| 243 | 50.4.2 | CT4 aspects CS-IBCF | 141d? | 2008-05-30 | 2008-12-12 |  |  | 2008-05-30 | 2008-12-12 | 141d? | 270d | finish no earlier than 2008-12-12 | C4 | 1128h |  | CS-IBCF | 29.238, 23.231, 29.232 | Telecom Italia | mauro.ficaccio@telecomitalia.it | Rel-8 | Kimmo |
| 244 | 51 | **Earthquake and Tsunami Warning System** | 325d? | 2007-09-10 A | 2008-12-05 | 82% | 57.09d? | 2007-09-10 | 2008-12-05 | 325d? | 275d |  | S1,S2,C1 | 4900h | 2960h | ETWS |  | NTT DoCoMo | kitaharar@nttdocomo.co.jp | Rel-8 | Alain |
| 245 | 51.1 | Stage 1 for ETWS | 133d? | 2007-09-10 A | 2008-03-12 A | 100% |  | 2007-09-10 | 2008-03-12 | 133d? |  | finish no earlier than 2008-03-12 | S1 | 1064h | 1064h | ETWS | 22.168 | NTT DoCoMo | kitaharar@nttdocomo.co.jp | Rel-8 | Alain |
| 246 | 51.2 | SA2 aspects of ETWS | 104d? | 2008-01-14 A | 2008-06-05 A | 100% |  | 2008-01-14 | 2008-06-05 | 104d? |  | finish no earlier than 2008-09-08 | S2 | 832h | 832h | ETWS | 23.828 | NTT DoCoMo | tanakai@nttdocomo.co.jp | Rel-8 | Maurice |
| 247 | 51.3 | CT1 aspects of ETWS | 50.5d? | 2008-05-30 A | 2008-12-05 |  | 50.5d? | 2008-05-30 | 2008-12-05 | 50.5d? | 275d | finish no earlier than 2008-12-05 | C1 | 404h |  | ETWS | 23.041 | NTT DoCoMo | yamashitahi@s1.nttdocomo.co.jp | Rel-8 | Kimmo |
| 248 | 52 | Storage and easy access of In Case of Emergency numbers on USIM | 70d? | 2007-12-06 A | 2008-03-12 A | 100% |  | 2007-12-06 | 2008-03-12 | 70d? |  | finish no earlier than 2008-03-12 | S1 | 560h | 560h | ICE | 22.030, 22.101 | Telecom Italia |  | Rel-8 | Alain |
| 249 | 53 | Local Charging Zone Requirements | 380d? | 2006-09-28 A | 2008-03-12 A | 100% |  | 2006-09-28 | 2008-03-12 | 380d? |  | finish no earlier than 2006-12-07 | S1 | 3040h | 3040h | LCZR | 22.115 | China Mobile | liuhongyfw@chinamobile.com | Rel-8 | Alain |
| 250 | 54 | **Customized Alerting Tone (CAT)** | 523d? | 2006-12-06 A | 2008-12-05 | 44% | 291.04d? | 2006-12-06 | 2008-12-05 | 523d? | 275d |  | S1,C1,C3 | 9198.4h | 4079.7h | CAT |  | China Mobile | fenglingjuan@chinamobile.com | Rel-8 | Alain |
| 251 | 54.1 | Stage 1 for CAT | 207d? | 2006-12-06 A | 2007-09-20 A | 100% |  | 2006-12-06 | 2007-09-20 | 207d? |  | start no earlier than 2006-12-06 | S1 | 1656h | 1656h | CAT | 22.182 | China Mobile | fenglingjuan@chinamobile.com | Rel-8 | Alain |
| 252 | 54.2 | TISPAN requirements for customized multimedia information services | 71d? | 2007-09-03 A | 2007-12-10 A | 100% |  | 2007-09-03 | 2007-12-10 | 71d? |  | finish no earlier than 2007-12-10 | S1 | 568h | 568h | TISCMI | 22.182 | Ericsson |  | Rel-8 | Alain |
| 253 | 54.3 | IMS CAT Supplementary Service | 164d? | 2008-01-30 | 2008-09-15 |  |  | 2008-01-30 | 2008-09-15 | 164d? | 334d | finish no earlier than 2008-09-15 | C1 | 1312h |  | CAT_SS | 24.182 | Nortel | milanpa@nortel.com | Rel-8 | Andrijana |
| 254 | 54.4 | CAT solution for voice and video call in CS domain | 184.8d? | 2008-03-12 | 2008-12-05 |  |  | 2008-03-12 | 2008-12-05 | 184.8d? | 275d | finish no earlier than 2008-12-05 | C3 | 1478.4h |  | CAT |  | Ericsson |  | Rel-8 | Gwiho |

Notes:
- 231: SA#39 completed. Linked to SA4 Feature UID_34042 (eCall_Phase2). CT#40 approved Stage 3 WID.
- 232: SA4 to select a suitable in-band modem. SA#39 completed
- 233: CT#40 WID approved
- 234: Triggered by Study UID_360015 (eCALLIBMS). Linked to SA1 Feature UID_330005 (EData)
- 235: Inform GSMA of progress. SA#39 Stage 1 completed. Stage 2/3 in Feature UID_360025 (SIP_Nc)
- 236: SA#39 completed
- 237: Stage 1 in Feature UID_380060 (IPinterc). CT#40 updated WID CP-070517=>CP-080282
- 238: CT#40 updated WID CP-070517=>CP-080282
- 239: CT#40 updated WID CP-070517=>CP-080282
- 240: CT#40 updated WID CP-070517=>CP-080282
- 241: CT#40 WID approved
- 242: CT#40 WID approved
- 243: CT#40 WID approved
- 244: SA#38 WID approved. Larger scope Feature UID_380057 (PWS) moved to Rel-9. Stage 1 completed. No SA2 impact. CT#40 WID approved
- 245: SA#39 completed
- 246: SA#38 WID approved. SA#40 exception to Sep 2008 on impacts from adding the CBC to MME interface
- 247: CT#40 WID approved
- 248: SA#39 Stage 1 completed
- 249: SA#39 Stage 1 completed
- 250: Conflict 3GPP vs. 3GPP2 IMS CAT. SA#40 exception to Sep 2008 for SA2 (Forking, Early session model)
- 251: Conflict 3GPP vs. 3GPP2 IMS CAT
- 252: SA#38 completed
- 254: Wait for conclusion of Study UID_360031 (FS_CAT_VVC_CS)

| ID | WBS | Task | Type | Duration | Start | Finish | Complete | Remaining | Baseline start | Baseline finish | Baseline duration | Total slack | Constraint | Resources | Work | Actual work | Text1 | Text4 | Text5 | Text6 | Text8 | Text3 | Text7 | Text12 |
| --- | --- | --- | --- | --- | --- | --- | --- | --- | --- | --- | --- | --- | --- | --- | --- | --- | --- | --- | --- | --- | --- | --- | --- | --- |
| 255 | 55 | **Service-Level Interworking for Messaging Services** |  | 449d? | 2007-03-26 A | 2008-12-12 | 47% | 238.81d? | 2007-03-26 | 2008-12-12 | 449d? | 270d |  | S1,S2 | 7664h | 3587.78h | MESSIW | Huawei | ling.liu@huawei.com; duanxiaoqin@huawei.com | Rel-8 | Alain |  |  |  |
| 256 | 55.1 | Stage 1 for MESSIW | milestone | 0d? | 2007-03-26 A | 2007-03-26 A | 100% |  | 2007-03-26 | 2007-03-26 | 0d? |  | finish no earlier than 2007-12-01 | S1 |  |  | MESSIW | Huawei | ling.liu@huawei.com | Rel-8 | Alain | 22.105, 22.340 |  |  |
| 257 | 55.2 | Stage 2 for MESSIW |  | 227d? | 2007-04-26 A | 2008-03-07 A | 100% |  | 2007-04-26 | 2008-03-07 | 227d? |  | finish no earlier than 2008-03-07 | S2 | 1816h | 1816h | MESSIW | Huawei | patrice.hede@huawei.com | Rel-8 | Maurice | 23.811, 23.204 |  |  |
| 258 | 55.3 | Stage 3 for MESSIW |  | 141d? | 2008-05-30 A | 2008-12-12 | 8% | 129.72d? | 2008-05-30 | 2008-12-12 | 141d? | 270d | finish no earlier than 2008-12-12 | C3 | 1128h | 90.24h | MESSIW | Huawei | xupeili@huawei.com | Rel-8 | Gwiho | 29.331 |  |  |
| 259 | 55.4 | Stage 3 for MESSIW |  | 141d? | 2008-05-30 | 2008-12-12 |  |  | 2008-05-30 | 2008-12-12 | 141d? | 270d | finish no earlier than 2008-12-12 | C1 | 1128h |  | MESSIW | Huawei | xupeili@huawei.com | Rel-8 | Andrijana | 29.331, 24.341 |  |  |
| 260 | 56 | **Multimedia Priority Service** |  | 652d? | 2006-06-08 A | 2008-12-05 | 42% | 378.46d? | 2006-06-08 | 2008-12-05 | 652d? | 275d |  | S1,C1,C3,C4 | 16648h | 6984.48h | PRIOR | Telcordia | jgarraha@telcordia.com | Rel-8 | Alain |  |  |  |
| 261 | 56.1 | Service Requirements for PRIOR |  | 391d? | 2006-06-08 A | 2007-12-06 A | 100% |  | 2006-06-08 | 2007-12-06 | 391d? |  | finish no earlier than 2007-11-30 | S1 | 3128h | 3128h | PRIOR-EMR | Telcordia | jgarraha@telcordia.com | Rel-8 | Alain | 22.153 |  |  |
| 262 | 56.2 | Stage 3 for PRIOR |  | 466d? | 2006-12-01 A | 2008-09-14 | 42% | 270.28d? | 2006-12-01 | 2008-09-14 | 466d? | 335d | finish no earlier than 2008-09-14 | C1 | 3728h | 1565.77h | PRIOR-MM | ALU | drage@alcatel-lucent.com | Rel-8 | Andrijana | 24.229 |  |  |
| 263 | 56.3 | Stage 3 for PRIOR |  | 316d? | 2007-09-21 | 2008-12-05 |  |  | 2007-09-21 | 2008-12-05 | 316d? | 275d | finish no earlier than 2008-12-05 | C3 | 2528h |  | PRIOR-MM | ALU | drage@alcatel-lucent.com | Rel-8 | Gwiho | 29.212, 29.213, 29.214, 29.163 |  |  |
| 264 | 56.4 | Stage 3 for PRIOR |  | 256d? | 2007-09-21 A | 2008-09-12 | 5% | 243.2d? | 2007-09-21 | 2008-09-12 | 256d? | 335d | finish no earlier than 2008-09-12 | C4 | 2048h | 102.4h | PRIOR-MM | ALU | drage@alcatel-lucent.com | Rel-8 | Kimmo | 23.008, 29.228, 29.229 |  |  |
| 265 | 57 | **OSA Rel-8** |  | 202d? | 2007-08-23 A | 2008-05-30 A | 100% |  | 2007-08-23 | 2008-05-30 | 202d? |  |  | S1,C5 | 23552h | 23552h | OSA8 | Orange |  | Rel-8 | Alain | 22.127, 23.198, 29.198, 29.199 | TSG |  |
| 266 | 57.1 | OSA Stage 1 - Service Requirements |  | 145d? | 2007-08-23 A | 2008-03-12 A | 100% |  | 2007-08-23 | 2008-03-12 | 145d? |  | finish no earlier than 2007-12-04 | S1 | 1160h | 1160h | OSA8 | Orange, AePONA |  | Rel-8 | Alain | 22.127 | TSG |  |
| 267 | 57.2 | OSA Stage 1 - NGN Service Requirement |  | 140d? | 2007-09-03 A | 2008-03-14 A | 100% |  | 2007-09-03 | 2008-03-14 | 140d? |  | finish no earlier than 2008-03-14 | S1 | 1120h | 1120h | OSA8-IMS | Orange |  | Rel-8 | Alain | 22.127 |  |  |
| 268 | 57.3 | **OSA Stage 2/3 enhancements** |  | 157d? | 2007-10-25 A | 2008-05-30 A | 100% |  | 2007-10-25 | 2008-05-30 | 157d? |  |  | C5 | 20016h | 20016h | OSA8 | Orange | salim.mouniralaoui@orange-ftgroup.com | Rel-8 | Gwiho | 23.198, 29.198, 29.199 |  |  |
| 269 | 57.3.1 | Delete - Ensure Parlay-X composable with identity management frameworks, in particular Liberty Alliance |  | 157d? | 2007-10-25 A | 2008-05-30 A | 100% |  | 2007-10-25 | 2008-05-30 | 157d? |  | finish no earlier than 2008-12-25 | C5 | 1256h | 1256h | OSA8 | Ericsson, FT/Orange, Sprint, Telecom Italia | catherine.mulligan@ericsson.com | Rel-8 | Gwiho | existing 29.199-xy |  | CP-40 |
| 270 | 57.3.2 | Parlay-X Content Management web service (store/manage meta-data) |  | 157d? | 2007-10-25 A | 2008-05-30 A | 100% |  | 2007-10-25 | 2008-05-30 | 157d? |  | finish no earlier than 2008-12-04 | C5 | 1256h | 1256h | OSA8 | ETRI | Yoo, Hyunkyung (hkyoo@etri.re.kr) | Rel-8 | Gwiho | 29.199-21 |  |  |
| 271 | 57.3.3 | Parlay-X Policy web service |  | 157d? | 2007-10-25 A | 2008-05-30 A | 100% |  | 2007-10-25 | 2008-05-30 | 157d? |  | finish no earlier than 2008-12-04 | C5 | 1256h | 1256h | OSA8 | ETRI | Park, Yoo-mi ( parkym@etri.re.kr) | Rel-8 | Gwiho | 29.199-22 |  |  |
| 272 | 57.3.4 | Parlay-X Terminal status web service |  | 157d? | 2007-10-25 A | 2008-05-30 A | 100% |  | 2007-10-25 | 2008-05-30 | 157d? |  | finish no earlier than 2008-05-30 | C5 | 1256h | 1256h | OSA8 | Orange | salim.mouniralaoui@orange-ftgroup.com | Rel-8 | Gwiho | 29.199-08 |  |  |
| 273 | 57.3.5 | Delete - Identify communication format used by a particular application |  | 157d? | 2007-10-25 A | 2008-05-30 A | 100% |  | 2007-10-25 | 2008-05-30 | 157d? |  | finish no earlier than 2008-05-30 | C5 | 1256h | 1256h | OSA8 | Ericsson | catherine.mulligan@ericsson.com | Rel-8 | Gwiho | existing 29.199-xy |  | CP-40 |
| 274 | 57.3.6 | Delete - Security on User Profile Management - reuse GUP API (22.127 CR 0084 S1-071794) |  | 128d? | 2007-12-05 A | 2008-05-30 A | 100% |  | 2007-12-05 | 2008-05-30 | 128d? |  | finish no earlier than 2008-12-25 | C5 | 1024h | 1024h | OSA8 | Telecom Italia | vincenzo.amorino@telecomitalia.it | Rel-8 | Gwiho | PXWS Framework |  | CP-40 |
| 275 | 57.3.7 | Delete - Privacy on Subscriber Identity (Liberty Alliance, OASIS) (22.127 CR 0085 S1-071835) |  | 128d? | 2007-12-05 A | 2008-05-30 A | 100% |  | 2007-12-05 | 2008-05-30 | 128d? |  | finish no earlier than 2008-12-25 | C5 | 1024h | 1024h | OSA8 | Telecom Italia | vincenzo.amorino@telecomitalia.it | Rel-8 | Gwiho | PXWS Framework |  | CP-40 |
| 276 | 57.3.8 | Delete - Topology Hiding (22.127 CR 0086 S1-071838) |  | 128d? | 2007-12-05 A | 2008-05-30 A | 100% |  | 2007-12-05 | 2008-05-30 | 128d? |  | finish no earlier than 2008-12-25 | C5 | 1024h | 1024h | OSA8 | Telecom Italia | vincenzo.amorino@telecomitalia.it | Rel-8 | Gwiho | PXWS Framework |  | CP-40 |
| 277 | 57.3.9 | Delete - Subscriber event notification (22.127 CR 0087 S1-071836) |  | 128d? | 2007-12-05 A | 2008-05-30 A | 100% |  | 2007-12-05 | 2008-05-30 | 128d? |  | finish no earlier than 2008-12-25 | C5 | 1024h | 1024h | OSA8 | Telecom Italia | vincenzo.amorino@telecomitalia.it | Rel-8 | Gwiho | PXWS Framework |  | CP-40 |
| 278 | 57.3.10 | Delete - Event notification (22.127 CR 0088 S1-071762) |  | 128d? | 2007-12-05 A | 2008-05-30 A | 100% |  | 2007-12-05 | 2008-05-30 | 128d? |  | finish no earlier than 2008-12-25 | C5 | 1024h | 1024h | OSA8 | Telecom Italia | vincenzo.amorino@telecomitalia.it | Rel-8 | Gwiho | PXWS Framework |  | CP-40 |
| 279 | 57.3.11 | Delete - Access policy (22.127 CR 0089 S1-071763) |  | 128d? | 2007-12-05 A | 2008-05-30 A | 100% |  | 2007-12-05 | 2008-05-30 | 128d? |  | finish no earlier than 2008-12-25 | C5 | 1024h | 1024h | OSA8 | Telecom Italia | vincenzo.amorino@telecomitalia.it | Rel-8 | Gwiho | PXWS Framework |  | CP-40 |
| 280 | 57.3.12 | Delete - API usage accounting (22.127 CR 0090 S1-071792) |  | 128d? | 2007-12-05 A | 2008-05-30 A | 100% |  | 2007-12-05 | 2008-05-30 | 128d? |  | finish no earlier than 2008-12-25 | C5 | 1024h | 1024h | OSA8 | Telecom Italia | vincenzo.amorino@telecomitalia.it | Rel-8 | Gwiho | PXWS Framework |  | CP-40 |
| 281 | 57.3.13 | Presence alignment with OMA and IETF (22.127 CR 0092 S1-071764) |  | 128d? | 2007-12-05 A | 2008-05-30 A | 100% |  | 2007-12-05 | 2008-05-30 | 128d? |  | finish no earlier than 2008-05-30 | C5 | 1024h | 1024h | OSA8 | Ericsson | catherine.mulligan@ericsson.com | Rel-8 | Gwiho | 29.199-14/13 |  |  |
| 282 | 57.3.14 | Delete - Service identification (22.127 CR 0095 S1-071837) |  | 128d? | 2007-12-05 A | 2008-05-30 A | 100% |  | 2007-12-05 | 2008-05-30 | 128d? |  | finish no earlier than 2008-05-30 | C5 | 1024h | 1024h | OSA8 | Ericsson | catherine.mulligan@ericsson.com | Rel-8 | Gwiho | existing 29.199-xy |  | CP-40 |
| 283 | 57.3.15 | Framework Enterprise Operator (Service Subscription function) |  | 102d? | 2008-01-10 A | 2008-05-30 A | 100% |  | 2008-01-10 | 2008-05-30 | 102d? |  | finish no earlier than 2008-05-30 | C5 | 816h | 816h | OSA8 | AePONA | Alan.Taylor@aepona.com | Rel-8 | Gwiho | 29.198-03 |  |  |
| 284 | 57.3.16 | Mobility Emergency Location |  | 102d? | 2008-01-10 A | 2008-05-30 A | 100% |  | 2008-01-10 | 2008-05-30 | 102d? |  | finish no earlier than 2008-05-30 | C5 | 816h | 816h | OSA8 | AePONA | Alan.Taylor@aepona.com | Rel-8 | Gwiho | 29.198-06 |  |  |
| 285 | 57.3.17 | Connectivity Manager SCF |  | 102d? | 2008-01-10 A | 2008-05-30 A | 100% |  | 2008-01-10 | 2008-05-30 | 102d? |  |  | C5 | 816h | 816h | OSA8 | AePONA | Alan.Taylor@aepona.com | Rel-8 | Gwiho | 29.198-10 |  |  |
| 286 | 57.3.18 | PAM Presence Agent |  | 102d? | 2008-01-10 A | 2008-05-30 A | 100% |  | 2008-01-10 | 2008-05-30 | 102d? |  | finish no earlier than 2008-05-30 | C5 | 816h | 816h | OSA8 | AePONA | Alan.Taylor@aepona.com | Rel-8 | Gwiho | 29.198-14 |  |  |

Notes:
- 255: SA#39 Stage 2 completed. CT#40 added New Stage 3 WID.
- 256: SA#35 work completed
- 257: SA#39 work completed
- 258: CT#40 WID approved
- 259: CT#40 WID approved
- 260: SA#38 Stage 1 completed. No Stage 2 identified
- 261: SA#38 completed
- 265: TSG#40 completed. New OSA work in OMA. SA1 need to remove unfulfilled Requirements to align with CT5 Stage 2/3 reality.
- 266: TSG#40 New OSA work in OMA. SA1 to remove non-fulfilled Requirements.
- 267: TSG#40 New OSA work in OMA. SA1 to remove non-fulfilled Requirements.
- 268: CT#40 WID updated CP-070349=>CP-080252. Started work completed. Unfulfilled Rel-8 Stage 1 and New OSA work to be done in OMA. SA1 needs to remove non-fulfilled requirements in 22.127
- 269: CT#40: Work moved to OMA
- 270: CT#40 completed
- 271: CT#40 completed
- 272: CT#40 completed
- 273: CT#40: Work moved to OMA
- 274: SA#38 SP-070853 R8 CRs 22.127 OSA Stage 1. CT#40: Work moved to OMA
- 275: SA#38 SP-070853 R8 CRs 22.127 OSA Stage 1. CT#40: Work moved to OMA
- 276: SA#38 SP-070853 R8 CRs 22.127 OSA Stage 1. CT#40: Work moved to OMA
- 277: SA#38 SP-070853 R8 CRs 22.127 OSA Stage 1. CT#40: Work moved to OMA
- 278: SA#38 SP-070853 R8 CRs 22.127 OSA Stage 1. CT#40: Work moved to OMA
- 279: SA#38 SP-070853 R8 CRs 22.127 OSA Stage 1. CT#40: Work moved to OMA
- 280: SA#38 SP-070853 R8 CRs 22.127 OSA Stage 1. CT#40: Work moved to OMA
- 281: CT#40 completed
- 282: SA#38 SP-070853 R8 CRs 22.127 OSA Stage 1. CT#40: Work moved to OMA
- 283: CT#40 completed
- 284: CT#40 completed
- 285: CT#40 completed
- 286: CT#40 completed

| ID | WBS | Task | Duration | Start | Finish | Complete | Remaining | Baseline start | Baseline finish | Baseline duration | Total slack | Constraint | Resources | Work | Actual work | Text1 | Text4 | Text6 | Text8 | Text7 |
| --- | --- | --- | --- | --- | --- | --- | --- | --- | --- | --- | --- | --- | --- | --- | --- | --- | --- | --- | --- | --- |
| 287 | 58 | **Paging Permission with Access Control (PPACR)** | 329d? | 2007-06-12 A | 2008-09-12 | 92% | 24.99d? | 2007-06-12 | 2008-09-12 | 329d? | 335d |  | S1,C1 | 4928h | 2673.6h | PPACR | NTT DoCoMo | Rel-8 | Alain |  |
| 288 | 58.1 | Stage 1 for PPACR | 69d? | 2007-06-12 A | 2007-09-14 A | 100% |  | 2007-06-12 | 2007-09-14 | 69d? |  | finish no earlier than 2007-09-14 | S1 | 552h | 552h | PPACR-S1 | NTT DoCoMo | Rel-8 | Alain |  |
| 289 | 58.2 | Stage 3 for PPACR (CT1) | 218d? | 2007-11-14 A | 2008-09-12 | 90% | 21.8d? | 2007-11-14 | 2008-09-12 | 218d? | 335d | finish no earlier than 2008-09-12 | C1 | 1744h | 1569.6h | PPACR-CT1 | NTT DoCoMo | Rel-8 | Andrijana |  |
| 290 | 59 | Value Added Services for Short Message Service | 133d? | 2007-09-10 A | 2008-03-12 A | 100% |  | 2007-09-10 | 2008-03-12 | 133d? |  | finish no earlier than 2008-03-21 | S1 | 1064h | 1064h | VAS4SMS | China Mobile | Rel-8 | Alain |  |
| 291 | 60 | **Charging for multi-phases services** | 70d? | 2007-12-06 A | 2008-03-12 A | 100% |  | 2007-12-06 | 2008-03-12 | 70d? |  |  | S1 | 1120h | 1120h | CHRGMPH | Telecom Italia | Rel-8 | Alain |  |
| 292 | 60.1 | Stage 1 for CHRGMPH | 70d? | 2007-12-06 A | 2008-03-12 A | 100% |  | 2007-12-06 | 2008-03-12 | 70d? |  | start no earlier than 2007-12-06 | S1 | 560h | 560h | CHRGMPH-s1 | Telecom Italia | Rel-8 | Alain |  |
| 293 | 61 | **Home NodeB / eNodeB** | 70d? | 2007-12-06 A | 2008-03-12 A | 100% |  | 2007-12-06 | 2008-03-12 | 70d? |  |  | S1 | 1120h | 1120h | HomeNB | Telecom Italia | Rel-8 | Alain |  |
| 294 | 61.1 | Stage 1 for HNB_eHNB | 70d? | 2007-12-06 A | 2008-03-12 A | 100% |  | 2007-12-06 | 2008-03-12 | 70d? |  | start no earlier than 2007-12-06 | S1 | 560h | 560h | HomeNB-S1 | Telecom Italia | Rel-8 | Alain |  |
| 295 | 62 | Access Security Enhancements | 379d? | 2007-07-02 A | 2008-12-11 | 80% | 75.8d? | 2007-07-02 | 2008-12-11 | 379d? | 271d | finish no earlier than 2008-12-11 | S3 | 3032h | 2425.6h | ACCSEC2 | Ericsson | Rel-8 | Dionisio | TSG |
| 296 | 63 | Lawful Interception in the 3GPP Rel-8 | 459d? | 2007-03-12 A | 2008-12-11 | 40% | 275.4d? | 2007-03-12 | 2008-12-11 | 459d? | 271d | finish no earlier than 2008-12-11 | S3 | 3672h | 1468.8h | LI8 | BMWi | Rel-8 | Dionisio |  |
| 297 | 64 | Generic Bootstrapping Architecture Push Function | 132d? | 2008-03-12 A | 2008-09-11 | 60% | 52.8d? | 2008-03-12 | 2008-09-11 | 132d? | 336d | finish no earlier than 2008-03-21 | S3 | 1056h | 633.6h | GBAPush | Ericsson | Rel-8 | Dionisio |  |
| 298 | 65 | Requirements and Test methods for Wideband Terminals | 197d? | 2008-03-12 A | 2008-12-11 | 5% | 187.15d? | 2008-03-12 | 2008-12-11 | 197d? | 271d | start no earlier than 2008-03-12 | S4 | 1576h | 78.8h | RETEM_WB_T | FT, Ericsson | Rel-8 | Paolo |  |
| 299 | 66 | Extending PSS and MBMS User Services for optimized Mobile TV | 266d? | 2007-12-06 A | 2008-12-11 | 15% | 226.1d? | 2007-12-06 | 2008-12-11 | 266d? | 271d | finish no earlier than 2008-12-11 | S4 | 2128h | 319.2h | PSS_MBMS_OMTV | Ericsson | Rel-8 | Paolo |  |
| 300 | 67 | **Encoding formats, transport formats and media description signalling for interworking, QoE, and other enhancements to MTSI-MHI** | 267d? | 2007-12-06 A | 2008-12-12 | 7% | 249.51d? | 2007-12-06 | 2008-12-12 | 267d? | 270d |  | S4,C3,C1,C4 | 7168h | 469.51h | MTSI_eMHI | Ericsson, Qualcomm | Rel-8 | Paolo |  |
| 301 | 67.1 | MTSI Video - Dynamic Rate Adaptation/Signalling of Image Size | 206d? | 2007-12-06 A | 2008-09-18 | 20% | 164.8d? | 2007-12-06 | 2008-09-18 | 206d? | 331d | finish no earlier than 2008-09-18 | S4 | 1648h | 329.6h | MTSIV_DRASIS | Qualcomm, Samsung | Rel-8 | Paolo |  |
| 302 | 67.2 | Enhancement of interworking between MTSI and Circuit Switched networks | 141d? | 2008-05-30 | 2008-12-12 |  |  | 2008-05-30 | 2008-12-12 | 141d? | 270d | start no earlier than 2008-05-30 | C3 | 1128h |  | MTSI_eMHI | Huawei | Rel-8 | Gwiho |  |
| 303 | 67.3 | Enhancement of interworking between MTSI and Circuit Switched networks | 141d? | 2008-05-30 | 2008-12-12 |  |  | 2008-05-30 | 2008-12-12 | 141d? | 270d | start no earlier than 2008-05-30 | C1 | 1128h |  | MTSI_eMHI | Huawei | Rel-8 | Andrijana |  |
| 304 | 67.4 | Enhancement of interworking between MTSI and Circuit Switched networks | 141d? | 2008-05-30 | 2008-12-12 |  |  | 2008-05-30 | 2008-12-12 | 141d? | 270d | start no earlier than 2008-05-30 | C4 | 1128h |  | MTSI_eMHI | Huawei | Rel-8 | Kimmo |  |
| 305 | 68 | **OAM&P 8** | 461d? | 2007-06-07 A | 2009-03-12 | 61% | 179.06d? | 2007-06-07 | 2009-03-12 | 461d? | 206d |  | S5,C1 | 40627.2h | 21912.2h | OAM8 | Huawei | Rel-8 | Dionisio |  |
| 306 | 68.1 | **Network Infrastructure Management 8** | 461d? | 2007-06-07 A | 2009-03-12 | 62% | 176.97d? | 2007-06-07 | 2009-03-12 | 461d? | 206d |  | S5 | 16992h | 9472.33h | OAM8-NIM | Huawei | Rel-8 | Dionisio |  |
| 307 | 68.1.1 | Telecom Management Methodology | 396d? | 2007-06-07 A | 2008-12-11 | 70% | 118.8d? | 2007-06-07 | 2008-12-11 | 396d? | 271d | finish no earlier than 2008-12-11 | S5 | 3168h | 2217.6h | OAM8 | Ericsson | Rel-8 | Dionisio |  |
| 308 | 68.1.2 | Advanced Alarming on Itf-N | 266d? | 2007-06-07 A | 2008-06-12 A | 100% |  | 2007-06-07 | 2008-06-12 | 266d? |  | finish no earlier than 2008-12-11 | S5 | 2128h | 2128h | OAM8 | NSN | Rel-8 | Dionisio |  |
| 309 | 68.1.3 | CN CS Bearer Transport Network (BTN) relative NRM | 266d? | 2007-06-07 A | 2008-06-12 A | 100% |  | 2007-06-07 | 2008-06-12 | 266d? |  | finish no earlier than 2008-12-11 | S5 | 2128h | 2128h | OAM8 | China Mobile | Rel-8 | Dionisio |  |
| 310 | 68.1.4 | End point modelling for reference point | 324d? | 2007-09-17 A | 2008-12-11 | 60% | 129.6d? | 2007-09-17 | 2008-12-11 | 324d? | 271d | finish no earlier than 2008-12-11 | S5 | 2592h | 1555.2h | OAM8 | Motorola | Rel-8 | Dionisio |  |
| 311 | 68.1.5 | Alignment with eTOM and M.3060 architectural concepts | 210d? | 2008-02-22 A | 2008-12-11 | 10% | 189d? | 2008-02-22 | 2008-12-11 | 210d? | 271d | start no earlier than 2008-02-22 | S5 | 1680h | 168h | OAM8 | TeliaSonera | Rel-8 | Dionisio |  |
| 312 | 68.1.6 | SOAP Solution Sets | 201d? | 2008-06-05 | 2009-03-12 |  |  | 2008-06-05 | 2009-03-12 | 201d? | 206d | finish no earlier than 2009-03-12 | S5 | 1608h |  | OAM8 | Ericsson | Rel-8 | Dionisio |  |

Notes:
- 287: Triggered by Study UID_330016 (PPAC). SA#37 Stage 1 completed
- 288: Triggered by Study UID_330016 (PPAC). SA#37 completed / Text3: 22.011 / Text5: Morita Takashi
- 289: CT#38 WID approved. / Text3: 24.008, 23.122
- 290: SA#39 completed / Text3: 22.142, 22.942 / Text5: wubin@chinamobile.com
- 291: SA#39 completed / Text5: Marco.DeLuca1@telecomitalia.it
- 292: SA#39 completed / Text3: 22.115 / Text5: Marco.DeLuca1@telecomitalia.it
- 293: SA#39 completed / Text3: 22.011, 22.115
- 294: SA#39 completed / Text3: 22.011, 22.115
- 295: SA#38 moved to Rel-8 / Text3: 33.102, 43.020 / Text5: Bengt.Sahlin@ericsson.com
- 296: SA#40 exception to Sep 2008 for LI for SAE/LTE / Text3: 33.106, 33.107, 33.108 / Text5: berthold.wilhelm@bnetza.de, ron_ryan@verizon.net
- 297: SA#39 WID approved / Text3: 33.223, 33.224, 29.109, 24.109 / Text5: Rolf Blom
- 298: SA#39 WID approved / Text3: 26.131, 26.132 / Text5: stephane.ragot@orange-ftgroup.com, wanqing.shi@sonyericsson.com
- 299: SA#38 WID approved / Text3: 26.234, 26.346, 26.946 / Text5: thorsten.lohmar@ericsson.com
- 300: SA#40 WID approved / Text5: olle.franceschi@ericsson.com, nleung@qualcomm.com
- 301: SA#40 Feature=>BB under new Feature UID_400028 (MTSI). CT#40 updated WID SP-070755=>SP-080246 / Text3: 26.114 / Text5: nleung@qualcomm.com & kyunghun.jung@samsung.com
- 302: CT#40 WID approved / Text3: 29.163 / Text5: Tingfang Tang (tagna_online@huawei.com)
- 303: CT#40 WID approved / Text3: 24.229 / Text5: Tingfang Tang (tagna_online@huawei.com)
- 304: CT#40 WID approved / Text3: 29.332 / Text5: Tingfang Tang (tagna_online@huawei.com)
- 305: Collection of various SA5 WIs
- 307: Text3: 32.155, 32.153
- 308: Text3: 32.121, 32.122, 32.123
- 309: Text3: 32.632/3/5
- 310: Text3: 32.152, 32.62/3/4x, 32.73x
- 311: SA#39 WID approved / Text3: 32.101/2, 32.xyz
- 312: SA#40 WID approved / Text3: 32.111-7, 32.617, 32.417, 32.367, 32.627, 32.327, 32.337, 32.347, 32.357, 32.387, 32.397, 32.447, 32.637, 32.647, 32.657, 32.677, 32.697, 32.717, 32.727, 32.737, 32.747 / Text5: edwin.tse@ericsson.com

| ID | WBS | Task | Type | Duration | Start | Finish | Complete | Remaining | Baseline start | Baseline finish | Baseline duration | Total slack | Constraint | Resources | Work | Actual work | Text1 | Text4 | Text6 | Text8 | Text3 | Text12 | Text5 |
| --- | --- | --- | --- | --- | --- | --- | --- | --- | --- | --- | --- | --- | --- | --- | --- | --- | --- | --- | --- | --- | --- | --- | --- |
| 313 | 68.2 | **Performance Management 8** |  | 396d? | 2007-06-07 A | 2008-12-11 | 81% | 75.5d? | 2007-06-07 | 2008-12-11 | 396d? | 271d |  | S5 | 14800h | 11978.4h | OAM8-PM | Huawei | Rel-8 | Dionisio |  |  |  |
| 314 | 68.2.1 | Deleted IP bearer network Performance measurement definitions |  | 396d? | 2007-06-07 A | 2008-12-11 A | 100% |  | 2007-06-07 | 2008-12-11 | 396d? |  | finish no earlier than 2008-12-11 | S5 | 3168h | 3168h | OAM7-PM | China Mobile | Rel-8 | Dionisio | 32.321/2/3/5 | SP-36 |  |
| 315 | 68.2.2 | IP bearer network Performance measurement definitions |  | 266d? | 2007-06-07 A | 2008-06-12 A | 100% |  | 2007-06-07 | 2008-06-12 | 266d? |  | finish no earlier than 2008-12-11 | S5 | 2128h | 2128h | OAM8 | China Mobile | Rel-8 | Dionisio | 32.321/2/3/5 |  |  |
| 316 | 68.2.3 | HSUPA performance measurements |  | 396d? | 2007-06-07 A | 2008-12-11 | 70% | 118.8d? | 2007-06-07 | 2008-12-11 | 396d? | 271d | finish no earlier than 2008-12-11 | S5 | 3168h | 2217.6h | OAM8 | China Mobile | Rel-8 | Dionisio | 32.405 |  |  |
| 317 | 68.2.4 | Key Performance Indicators (KPIs) for UMTS/GERAN |  | 396d? | 2007-06-07 A | 2008-12-11 | 60% | 158.4d? | 2007-06-07 | 2008-12-11 | 396d? | 271d | finish no earlier than 2008-12-11 | S5 | 3168h | 1900.8h | OAM8 | China Mobile | Rel-8 | Dionisio | 32.xyz |  |  |
| 318 | 68.3 | **Trace Management 8** |  | 206d? | 2008-03-07 A | 2008-12-19 | 10% | 185.4d? | 2008-03-07 | 2008-12-19 | 206d? | 265d |  | S5,C1,C3,C4 | 6097.6h | 461.44h | OAM8-Trace | Huawei | Rel-8 | Dionisio |  |  |  |
| 319 | 68.3.1 | Service Level Tracing in IMS |  | 206d? | 2008-03-07 A | 2008-12-19 | 10% | 185.4d? | 2008-03-07 | 2008-12-19 | 206d? | 265d | start no earlier than 2008-03-07 | C1 | 1648h | 164.8h | OAM8-Trace | Vodafone | Rel-8 | Andrijana | 24.323, 24.229 |  | peter.dawes@vodafone.com |
| 320 | 68.3.2 | Service Level Tracing in IMS |  | 185.4d? | 2008-03-07 A | 2008-12-19 | 10% | 166.86d? | 2008-03-07 | 2008-12-19 | 185.4d? | 265d | finish no earlier than 2008-12-19 | C3 | 1483.2h | 148.32h | OAM8-Trace | Vodafone | Rel-8 | Andrijana | 29.163 |  | peter.dawes@vodafone.com |
| 321 | 68.3.3 | Service Level Tracing in IMS |  | 185.4d? | 2008-03-07 A | 2008-12-19 | 10% | 166.86d? | 2008-03-07 | 2008-12-19 | 185.4d? | 265d | finish no earlier than 2008-12-19 | C4 | 1483.2h | 148.32h | OAM8-Trace | Vodafone | Rel-8 | Andrijana | 29.228, 29.229, 29.332 |  | peter.dawes@vodafone.com |
| 322 | 69 | **Charging Management small Enhancements** |  | 716d? | 2006-03-16 A | 2008-12-11 | 71% | 208.48d? | 2006-03-16 | 2008-12-11 | 716d? | 271d |  | S5 | 12056h | 8545.66h | CH8 | Orange | Rel-8 | Dionisio | 32.2xy-series |  |  |
| 323 | 69.1 | Online charging correlation |  | 457d? | 2006-03-16 A | 2007-12-14 A | 100% |  | 2006-03-16 | 2007-12-14 | 457d? |  | start no earlier than 2006-03-16 | S5 | 3656h | 3656h | CH8 | Orange | Rel-8 | Dionisio | 32.240, 32.296 |  |  |
| 324 | 69.2 | SMS online charging |  | 137d? | 2007-06-07 A | 2007-12-14 A | 100% |  | 2007-06-07 | 2007-12-14 | 137d? |  | finish no earlier than 2007-12-14 | S5 | 1096h | 1096h | CH8 | Vodafone | Rel-8 | Dionisio | 32.274, 32.240/299/298 |  |  |
| 325 | 69.3 | WLAN Offline Charging |  | 244d? | 2008-01-07 | 2008-12-11 |  |  | 2008-01-07 | 2008-12-11 | 244d? | 271d | finish no earlier than 2008-12-11 | S5 | 1952h |  | CH8 | ALU | Rel-8 | Dionisio | 32.252/298/299 |  |  |
| 326 | 70 | **Conferencing enhancements for Mp interface** |  | 266d? | 2007-11-30 A | 2008-12-05 | 36% | 169.74d? | 2007-11-30 | 2008-12-05 | 266d? | 275d |  | C4 | 5904h | 2136.45h | eMp | Huawei | Rel-8 | Kimmo | 23.333, 29.333 |  | Chencheng@huawei.com |
| 327 | 70.1 | Stage 2 for eMp |  | 206d? | 2007-11-30 A | 2008-09-12 | 70% | 61.8d? | 2007-11-30 | 2008-09-12 | 206d? | 335d | finish no earlier than 2008-09-12 | C4 | 1648h | 1153.6h | eMp | Huawei | Rel-8 | Kimmo | 23.333 |  | Chencheng@huawei.com |
| 328 | 70.2 | Stage 3 for eMp |  | 266d? | 2007-11-30 A | 2008-12-05 | 10% | 239.4d? | 2007-11-30 | 2008-12-05 | 266d? | 275d | finish no earlier than 2008-12-05 | C4 | 2128h | 212.8h | eMp | Huawei | Rel-8 | Kimmo | 29.333 |  | Chencheng@huawei.com |
| 329 | 71 | **Contact Manager for 3GPP UICC applications** |  | 577d? | 2006-06-22 A | 2008-09-05 | 93% | 41.99d? | 2006-06-22 | 2008-09-05 | 577d? | 340d |  | C6 | 12312h | 11416.1h | eUPHBOOK | Gemalto | Rel-8 | Xavier | 21.111, 31.220, 31.221 |  | Jacques.seif@gemalto.com |
| 330 | 71.1 | Requirements for Contact Manager |  | 392d? | 2006-06-22 A | 2007-12-21 A | 100% |  | 2006-06-22 | 2007-12-21 | 392d? |  | finish no earlier than 2007-12-21 | C6 | 3136h | 3136h | eUPHBOOK-St1 | Gemalto | Rel-8 | Xavier | 21.111 |  | Jacques.seif@gemalto.com |
| 331 | 71.2 | External interface for eUPHBOOK |  | 220d? | 2007-05-07 A | 2008-03-07 A | 100% |  | 2007-05-07 | 2008-03-07 | 220d? |  | finish no earlier than 2008-03-07 | C6 | 1760h | 1760h | eUPHBOOK-Ext_Spec | Gemalto | Rel-8 | Xavier | 31.220 |  | Jacques.seif@gemalto.com |
| 332 | 71.3 | Internal interface for eUPHBOOK |  | 350d? | 2007-05-07 A | 2008-09-05 | 80% | 70d? | 2007-05-07 | 2008-09-05 | 350d? | 340d | finish no earlier than 2008-09-05 | C6 | 2800h | 2240h | eUPHBOOK-Int_Spec | Gemalto | Rel-8 | Xavier | 31.221 |  | Jacques.seif@gemalto.com |
| 333 | 71.4 | Deleted - Implementation of eUPHBOOK | milestone | 0d? | 2007-06-21 A | 2007-06-21 A | 100% |  | 2007-06-21 | 2007-06-21 | 0d? |  | start no earlier than 2007-06-21 | C6 |  |  | eUPHBOOK-St23 |  | Rel-8 | Xavier | 31.102 | SP-33 |  |
| 334 | 72 | Contact Manager Conformance Test specifications |  | 577d? | 2006-12-27 | 2009-03-12 |  |  | 2006-12-27 | 2009-03-12 | 577d? | 206d | finish no earlier than 2009-03-12 | C6 | 4616h |  | eUPHBOOK-Test | Comprion, Gemalto | Rel-8 | Xavier | 31.320, 31.321 |  | jacques.seif@gemalto.com, Udo Willenbrink |
| 335 | 73 | Definition of 3GPP UICC services over the new high-speed interface |  | 200d? | 2007-12-10 A | 2008-09-12 | 10% | 180d? | 2007-12-10 | 2008-09-12 | 200d? | 335d | finish no earlier than 2008-09-12 | C6 | 1600h | 160h | UICCHS | Gemalto | Rel-8 | Xavier | TS |  | jacques.seif@gemalto.com |
| 336 | 74 | **3G Long Term Evolution - Evolved Packet System RAN part** |  | 644d? | 2006-09-25 A | 2009-03-12 | 56% | 286.11d? | 2006-09-25 | 2009-03-12 | 644d? | 206d |  | RP,S5 | 41928h | 21476.6h | LTE | NTT DoCoMo | Rel-8 | Juergen |  |  | Takehiro Nakamura [nakamurata@nttdocomo.co.jp] |
| 337 | 74.1 | LTE – Physical Layer |  | 380d? | 2006-09-25 A | 2008-03-07 A | 100% |  | 2006-09-25 | 2008-03-07 | 380d? |  | finish no earlier than 2007-09-14 | R1 | 3040h | 3040h | LTE-Phys | NTT DoCoMo | Rel-8 | Patrick | 36.201, 36.211, 36.212, 36.213, 36.214 |  | Takehiro Nakamura [nakamurata@nttdocomo.co.jp] |
| 338 | 74.2 | LTE – Radio Interface Layer 2 and 3 Protocol Aspect |  | 515d? | 2006-09-25 A | 2008-09-12 | 95% | 25.75d? | 2006-09-25 | 2008-09-12 | 515d? | 335d | finish no earlier than 2008-09-12 | R2 | 4120h | 3914h | LTE-L23 | NTT DoCoMo | Rel-8 | Joern | 36.300, 36.304, 36.306, 36.321, 36.322, 36.323, 36.331 |  | Takehiro Nakamura [nakamurata@nttdocomo.co.jp] |
| 339 | 74.3 | LTE – eUTRAN Interfaces |  | 515d? | 2006-09-25 A | 2008-09-12 | 95% | 25.75d? | 2006-09-25 | 2008-09-12 | 515d? | 335d | finish no earlier than 2008-09-12 | R3 | 4120h | 3914h | LTE-interfaces | NTT DoCoMo | Rel-8 | Juergen | 36.4xy, 36.902 (SON use cases) |  | Takehiro Nakamura [nakamurata@nttdocomo.co.jp] |
| 340 | 74.4 | LTE – RF Radio Transmission/Reception, System Performance Requirements and Conformance Testing |  | 515d? | 2006-09-25 A | 2008-09-12 | 80% | 103d? | 2006-09-25 | 2008-09-12 | 515d? | 335d | finish no earlier than 2008-09-12 | R4 | 4120h | 3296h | LTE-RF | NTT DoCoMo | Rel-8 | Stefania | 36.101, 36.104, 36.133, 36.141 |  | Takehiro Nakamura [nakamurata@nttdocomo.co.jp] |
| 341 | 74.5 | LTE FDD repeaters |  | 325d? | 2007-09-14 A | 2008-12-11 | 25% | 243.75d? | 2007-09-14 | 2008-12-11 | 325d? | 271d | finish no earlier than 2008-12-11 | R4 | 2600h | 650h | LTE-Repeaters | Powerwave, Andrew Wireless | Rel-8 | Stefania | 36.x, 25.113 |  |  |

Notes:
- 314: SA#36 moved to Rel-8 under new UID
- 315: SA#36 moved to Rel-8 under new UID
- 319: Cannot proceed without substantial IETF contribution. CT#40 WID updated CP-060521=>CP-080315
- 320: Cannot proceed without substantial IETF contribution. CT#40 WID updated CP-060521=>CP-080315
- 321: Cannot proceed without substantial IETF contribution. CT#40 WID updated CP-060521=>CP-080315
- 322: Collection of various SA5 WIs
- 323: WID approved SA#35
- 325: SA#38 WID approved
- 329: aka Enhanced USIM phonebook. CT#40: WID updated CP-070622=>CP-080382
- 330: CT#38 completed
- 331: CT#39 completed
- 332: CT#37 created. CT#40 TS for Information
- 333: SA#33 stopped
- 334: CT#40 WID approved
- 335: CT#38 WID approved. CT#40: SCP/CT6 work split defined
- 336: Status report in RP-080256
- 337: Status report in RP-080256
- 338: Status report in RP-080256
- 339: Status report in RP-080256
- 340: Status report in RP-080256, updated RAN4 WID in RP-080314
- 341: Status report in RP-080257, WID in RP-0080034

| ID | WBS | Task | Duration | Start | Finish | Complete | Remaining | Baseline start | Baseline finish | Baseline duration | Total slack | Constraint | Resources | Work | Actual work | Text1 | Text4 | Text6 | Text8 | Text5 | Text7 |
| --- | --- | --- | --- | --- | --- | --- | --- | --- | --- | --- | --- | --- | --- | --- | --- | --- | --- | --- | --- | --- | --- |
| 342 | 74.6 | **E-UTRAN Data Definitions** | 389d? | 2007-09-17 A | 2009-03-12 | 26% | 289.47d? | 2007-09-17 | 2009-03-12 | 389d? | 206d |  | S5 | 12056h | 3084.63h | E-UTRAN-OAM | Huawei | Rel-8 | Dionisio |  |  |
| 343 | 74.6.1 | Subscriber and Equipment Trace for eUTRAN and EPC | 324d? | 2007-09-17 A | 2008-12-11 | 50% | 162d? | 2007-09-17 | 2008-12-11 | 324d? | 271d | finish no earlier than 2008-12-11 | S5 | 2592h | 1296h | E-UTRAN-OAM | Ericsson | Rel-8 | Dionisio |  |  |
| 344 | 74.6.2 | E-UTRAN Network Resource Model (NRM) Integration Reference Point (IRP) | 309d? | 2008-01-07 A | 2009-03-12 | 20% | 247.2d? | 2008-01-07 | 2009-03-12 | 309d? | 206d | finish no earlier than 2009-03-12 | S5 | 2472h | 494.4h | E-UTRAN-OAM | Ericsson | Rel-8 | Dionisio |  |  |
| 345 | 74.6.3 | Performance measurements for E-UTRAN | 210d? | 2008-02-22 A | 2008-12-11 | 10% | 189d? | 2008-02-22 | 2008-12-11 | 210d? | 271d | start no earlier than 2008-02-22 | S5 | 1680h | 168h | E-UTRAN-OAM | Motorola, Huawei | Rel-8 | Dionisio |  |  |
| 346 | 74.6.4 | Key Performance Indicators (KPIs) for E-UTRAN | 275d? | 2008-02-22 A | 2009-03-12 | 15% | 233.75d? | 2008-02-22 | 2009-03-12 | 275d? | 206d | finish no earlier than 2009-03-12 | S5 | 2200h | 330h | E-UTRAN-OAM | Ericsson | Rel-8 | Dionisio |  |  |
| 347 | 74.7 | **Self-Organizing Networks (SON)** | 210d? | 2008-02-22 A | 2008-12-11 | 13% | 182d? | 2008-02-22 | 2008-12-11 | 210d? | 271d |  | S5 | 6720h | 896h | LTE_SON-OAM | Vodafone | Rel-8 | Dionisio |  |  |
| 348 | 74.7.1 | Self-Establishment of eNBs | 210d? | 2008-02-22 A | 2008-12-11 | 20% | 168d? | 2008-02-22 | 2008-12-11 | 210d? | 271d | start no earlier than 2008-02-22 | S5 | 1680h | 336h | LTE_SON-OAM | NSN | Rel-8 | Dionisio |  |  |
| 349 | 74.7.2 | SON Automatic Neighbour Relations (ANR) List Management | 210d? | 2008-02-22 A | 2008-12-11 | 10% | 189d? | 2008-02-22 | 2008-12-11 | 210d? | 271d | finish no earlier than 2008-12-11 | S5 | 1680h | 168h | LTE_SON-OAM | Ericsson | Rel-8 | Dionisio |  |  |
| 350 | 74.7.3 | SON Self-Optimization & Self-Healing handling | 210d? | 2008-02-22 A | 2008-12-11 | 10% | 189d? | 2008-02-22 | 2008-12-11 | 210d? | 271d | finish no earlier than 2008-12-11 | S5 | 1680h | 168h | LTE_SON-OAM | Huawei | Rel-8 | Dionisio |  |  |
| 351 | 75 | **Improvements of the Radio Interface** | 532d? | 2007-03-05 A | 2009-03-17 | 68% | 168.89d? | 2007-03-05 | 2009-03-17 | 532d? | 203d |  | RP | 19816h | 11260.4h | RInImp8 | Alcatel-Lucent | Rel-8 | Juergen |  |  |
| 352 | 75.1 | UMTS 1500 MHz | 140d? | 2007-03-05 A | 2007-09-14 A | 100% |  | 2007-03-05 | 2007-09-14 | 140d? |  | finish no earlier than 2007-09-14 | R4 | 1120h | 1120h | RInImp8-UMTS1500 | NTT DoCoMo | Rel-8 | Stefania | NTT DoCoMo | TSG |
| 353 | 75.2 | UMTS 700 MHz | 325d? | 2007-03-05 A | 2008-05-30 A | 100% |  | 2007-03-05 | 2008-05-30 | 325d? |  | finish no earlier than 2008-06-12 | R4 | 2600h | 2600h | RInImp8-UMTS700 | Nokia | Rel-8 | Stefania |  | TSG |
| 354 | 75.3 | UMTS 2300 MHz | 400d? | 2007-03-05 A | 2008-09-12 | 20% | 320d? | 2007-03-05 | 2008-09-12 | 400d? | 335d | finish no earlier than 2008-09-12 | R4 | 3200h | 640h | RInImp8-UMTS2300 | AT&T | Rel-8 | Stefania | marc.grant@cingular.com | TSG |
| 355 | 75.4 | UMTS 2300 MHz TDD | 195d? | 2007-12-17 A | 2008-09-12 | 90% | 19.5d? | 2007-12-17 | 2008-09-12 | 195d? | 335d | finish no earlier than 2008-09-12 | R4 | 1560h | 1404h | RInImp8-UMTS2300TDD | Datang | Rel-8 | Stefania | songyuexia@datangmobile.cn |  |
| 356 | 75.5 | UMTS/LTE 3500 MHz | 327d? | 2007-12-17 A | 2009-03-17 | 15% | 277.95d? | 2007-12-17 | 2009-03-17 | 327d? | 203d | finish no earlier than 2009-03-17 | R4 | 2616h | 392.4h | RInImp8-UMTSLTE3500 | Ericsson | Rel-8 | Stefania | johan.skold@ericsson.com |  |
| 357 | 75.6 | Further Improved Minimum Performance Requirements for HSDPA UE (FDD) - Two-Branch Interference Cancellation | 265d? | 2007-03-05 A | 2008-03-07 A | 100% |  | 2007-03-05 | 2008-03-07 | 265d? |  | finish no earlier than 2008-03-12 | R4 | 2120h | 2120h | RInImp8-2BIC | AT&T | Rel-8 | Stefania | marc.grant@cingular.com |  |
| 358 | 75.7 | CS Voice Service over HSPA | 167d? | 2007-07-19 A | 2008-03-07 A | 100% |  | 2007-07-19 | 2008-03-07 | 167d? |  |  | R2 | 1336h | 1336h | RInImp8-CsHspa | NSN | Rel-8 | Joern | woonhee.hwang@nsn.com |  |
| 359 | 75.8 | Performance requirements for 15 code reception with 16QAM/QPSK | 126d? | 2007-06-11 A | 2008-03-07 A | 100% |  | 2007-06-11 | 2008-03-07 | 126d? |  | finish no earlier than 2008-06-12 | R4 | 1008h | 1008h | RInImp8-Hsdpa15codes | Vodafone | Rel-8 | Stefania | tim.frost@vodafone.com |  |
| 360 | 76 | MBSFN Downlink Optimized Broadcast 3.84 Mcps TDD | 335d? | 2007-06-04 | 2008-09-12 |  |  | 2007-06-04 | 2008-09-12 | 335d? | 335d | finish no earlier than 2008-09-12 | R1 | 2680h |  | MBSFN-DOB | Ericsson | Rel-8 | Patrick |  |  |
| 361 | 77 | **RAN improvements** | 529d? | 2007-06-04 A | 2009-06-11 | 44% | 294.66d? | 2007-06-04 | 2009-06-11 | 529d? | 141d |  | RP | 31392h | 13906.5h | RANimp | Alcatel-Lucent | Rel-8 | Juergen |  |  |
| 362 | 77.1 | Combination of 64QAM and MIMO for HSDPA (FDD) | 205d? | 2007-06-04 A | 2008-09-12 | 80% | 41d? | 2007-06-04 | 2008-09-12 | 205d? | 335d | finish no earlier than 2008-09-12 | R1 | 1640h | 1312h | RANimp-64QamMimoHsdpa | Ericsson | Rel-8 | Patrick | Johan.Bergman@ericsson.com |  |
| 363 | 77.2 | Improved L2 for uplink | 186d? | 2007-09-14 A | 2008-05-30 A | 100% |  | 2007-09-14 | 2008-05-30 | 186d? |  | finish no earlier than 2008-05-30 | R2 | 1488h | 1488h | RANimp-UplinkL2dataRates | Ericsson | Rel-8 | Joern | Janne.Peisa@ericsson.com |  |
| 364 | 77.3 | Enhanced Uplink for CELL_FACH State in FDD | 261d? | 2007-09-14 A | 2008-09-12 | 72% | 73.08d? | 2007-09-14 | 2008-09-12 | 261d? | 335d | finish no earlier than 2008-09-12 | R2 | 2088h | 1503.36h | RANimp-UplinkEnhState | NSN | Rel-8 | Joern | markus.wimmer@nsn.com |  |
| 365 | 77.4 | Enhanced UE DRX for FDD | 261d? | 2007-09-14 A | 2008-09-12 | 70% | 78.3d? | 2007-09-14 | 2008-09-12 | 261d? | 335d | finish no earlier than 2008-09-12 | R2 | 2088h | 1461.6h | RANimp-DRX | Nokia | Rel-8 | Joern | luis.barreto@nokia.com |  |
| 366 | 77.5 | Enhancements for SRNS Relocation Procedure | 261d? | 2007-09-14 A | 2008-09-12 | 75% | 65.25d? | 2007-09-14 | 2008-09-12 | 261d? | 335d | finish no earlier than 2008-09-12 | R3 | 2088h | 1566h | RANimp-SrnsReloc | NSN | Rel-8 | Juergen | masatoshi.nakamata@nsn.com |  |
| 367 | 77.6 | Enhancements for FDD HSPA Evolution | 261d? | 2007-09-14 A | 2008-09-12 | 40% | 156.6d? | 2007-09-14 | 2008-09-12 | 261d? | 335d | finish no earlier than 2008-09-12 | R3 | 2088h | 835.2h | RANimp-HSPAEvo | NSN | Rel-8 | Juergen | masatoshi.nakamata@nsn.com |  |
| 368 | 77.7 | 64QAM for 1.28 Mcps TDD HSDPA | 204d? | 2007-12-04 A | 2008-09-12 | 85% | 30.6d? | 2007-12-04 | 2008-09-12 | 204d? | 335d | finish no earlier than 2008-09-12 | R1 | 1632h | 1387.2h | RANimp-64Qam1.28TDD | ZTE | Rel-8 | Patrick | zfmail@zte.com.cn |  |
| 369 | 77.8 | Enhanced CELL_FACH state in 1.28 Mcps TDD | 204d? | 2007-12-04 A | 2008-09-12 | 50% | 102d? | 2007-12-04 | 2008-09-12 | 204d? | 335d | finish no earlier than 2008-09-12 | R2 | 1632h | 816h | RANimp-EnhState1.28TDD | ZTE | Rel-8 | Joern | zhang.yincheng@zte.com.cn |  |
| 370 | 77.9 | 1.28 Mcps TDD TDD Repeater Specification | 269d? | 2007-12-04 A | 2008-12-12 | 10% | 242.1d? | 2007-12-04 | 2008-12-12 | 269d? | 270d | finish no earlier than 2008-12-12 | R4 | 2152h | 215.2h | RANimp-Repeaters1.28TDD | RITT | Rel-8 | Stefania | qinyan@chinattl.com |  |
| 371 | 77.10 | Continuous Connectivity for packet data users for 1.28Mcps TDD | 201d? | 2008-03-07 A | 2008-12-12 | 10% | 180.9d? | 2008-03-07 | 2008-12-12 | 201d? | 270d | finish no earlier than 2008-12-12 | R1 | 1608h | 160.8h | RANimp-LCRCPC |  | Rel-8 | Patrick |  |  |
| 372 | 77.11 | HSPA VoIP to WCDMA/GSM CS continuity | 201d? | 2008-03-07 A | 2008-12-12 | 50% | 100.5d? | 2008-03-07 | 2008-12-12 | 201d? | 270d | finish no earlier than 2008-12-12 | R2 | 1608h | 804h | RANimp-HSPAVoIP |  | Rel-8 | Joern |  |  |
| 373 | 77.12 | HS-DSCH Serving Cell Change Enhancements | 201d? | 2008-03-07 A | 2008-12-12 | 30% | 140.7d? | 2008-03-07 | 2008-12-12 | 201d? | 270d | finish no earlier than 2008-12-12 | R2 | 1608h | 482.4h | RANimp-HSDSCH |  | Rel-8 | Joern |  |  |
| 374 | 77.13 | MIMO for 1.28 Mcps TDD | 205d? | 2008-05-30 | 2009-03-12 |  |  | 2008-05-30 | 2009-03-12 | 205d? | 206d | finish no earlier than 2009-03-12 | R1 | 1640h |  | RANimp-MIMOLCR |  | Rel-8 | Patrick |  |  |
| 375 | 77.14 | Support for Additional Navigation Satellite Systems (ANSS) for LCS | 205d? | 2008-05-30 | 2009-03-12 |  |  | 2008-05-30 | 2009-03-12 | 205d? | 206d | finish no earlier than 2009-03-12 | R2 | 1640h |  | RANimp-ANSS |  | Rel-8 | Joern |  |  |
| 376 | 77.15 | Dual-Cell HSDPA operation on adjacent carriers | 270d? | 2008-05-30 | 2009-06-11 |  |  | 2008-05-30 | 2009-06-11 | 270d? | 141d | finish no earlier than 2009-06-11 | R1 | 2160h |  | RANimp-DCHSDPA |  | Rel-8 | Patrick |  |  |

Notes:
- 343: Text3: 32.42x, 32.44x
- 344: SA#38 WID approved / Text3: 32.761/2/3/5
- 345: SA#39 WID approved / Text3: 32.425
- 346: SA#39 WID approved / Text3: 32.450, 32.451
- 347: SA#39 WID approved. SA#40 updated WID SP-080064=>SP-080275 / Text3: 32.500
- 348: SA#39 WID approved / Text3: 32.501, 32.502, 32.76x/32.75x
- 349: SA#39 WID approved / Text3: 32.511, 32.76x
- 350: SA#39 WID approved / Text3: 32.521
- 352: Text3: 25.101, 25.104, 25.133, 25.141, 25.331, 25.942, 25.306, 25.307, 34.121
- 353: Status Report in RP-080260 / Text3: 25.101, 25.104, 25.133, 25.141, 25.331, 25.942, 25.306, 25.307, 34.121
- 354: Status Report in RP-080261 / Text3: 25.101, 25.104, 25.133, 25.141, 25.331, 25.942, 25.306, 25.307, 34.121
- 355: WID in RP-071016. Status Report in RP-080263 / Text3: 25.102, 25.105, 25.113, 25.123, 25.142, 34.124, 25.306, 25.331, 34.122
- 356: WID in RP-071012. Status Report in RP-080262 / Text3: 25.101, 25.104, 25.113, 25.133, 25.141, 34.124, 25.307, 25.331, 25.461, 25.463, 34.108, 34.121, 36.101, 36.104, 36.141, 36.508, 25.307, 36.331, 36.521-1, 36.521-2
- 357: Status Report in RP-080041. RP#39 completed
- 358: WID in RP-070823. Status Report in RP-080042. RP#39 completed / Text3: 25.323, 25.331, 25.322
- 359: WID in RP-070824. Status Report in RP-080043. RP#39 completed / Text3: 25.101
- 360: Status Report in RP-080218 (RAN#39) / Text3: 25.346, 25.201, 25.221, 25.222, 25.223, 25.306, 25.331, 25.402, 25.433, 25.102, 25.105, 25.123
- 362: Status Report in RP-080264, 80% complete for RAN4 (100% for other WGs) / Text3: 25.308, 25.211, 25.212, 25.213, 25.306, 25.331, 25.433, 25.435, 25.423, 25.425, 25.101, 25.104, 25.141
- 363: Status Report in RP-080265 / Text3: 25.319, 25.301, 25.306, 25.321, 25.331, 25.433, 25.435, 25.423, 25.425, 25.427
- 364: Status Report in RP-080266 / Text3: 25.309, 25.211, 25.214, 25.321, 25.331, 25.423, 25.433
- 365: Status Report in RP-080267 / Text3: 25.306, 25.308, 25.321, 25.331, 25.423
- 366: Status Report in RP-080268 / Text3: 25.306, 25.308, 25.321, 25.331, 25.423, 25.433, 25.214, 25.133
- 367: Status Report in RP-080269 / Text3: 25.423, 25.427, 25.433
- 368: Status report in RP-080270, WID in RP-080050 / Text3: 25.201, 25.221, 25.222, 25.223, 25.224, 25.306, 25.308, 25.321, 25.331, 25.423, 25.433, 25.102, 25.105, 25.142
- 369: Status report in RP-080271, WID in RP-080051 / Text3: 25.308, 25.304, 25.306, 25.224, 25.321, 25.331, 25.433, 25.435, 25.423, 25.425, 25.123
- 370: Status report in RP-080272, WID in RP-071003 / Text3: 25.113
- 371: Status report in RP-080273, WID in RP-080085 / Text3: 25.929
- 372: Status report in RP-080274, WID in RP-080229
- 373: Status report in RP-080275, WID in RP-080227
- 374: WID in RP-080485
- 375: WID in RP-080346
- 376: WID in RP-080490

| ID | WBS | Task | Duration | Start | Finish | Complete | Remaining | Baseline start | Baseline finish | Baseline duration | Total slack | Constraint | Deadline | Resources | Work | Actual work | Text1 | Text4 | Text6 | Text8 | Text7 | Text5 | Text3 | Text10 |
| --- | --- | --- | --- | --- | --- | --- | --- | --- | --- | --- | --- | --- | --- | --- | --- | --- | --- | --- | --- | --- | --- | --- | --- | --- |
| 377 | 78 | **UTRA HNB** | 201d? | 2008-03-07 A | 2008-12-12 | 7% | 187.22d? | 2008-03-07 | 2008-12-12 | 201d? | 270d |  |  | RP | 4432h | 303.83h | HNB | ALU | Rel-8 | Juergen |  |  |  |  |
| 378 | 78.1 | Support of UTRA HNB | 76d? | 2008-05-30 A | 2008-09-12 | 5% | 72.2d? | 2008-05-30 | 2008-09-12 | 76d? | 335d | finish no earlier than 2008-09-12 |  | R2 | 608h | 30.4h | HNB-supp |  | Rel-8 | Joern |  |  |  |  |
| 379 | 78.2 | FDD Home NodeB RF requirements | 136d? | 2008-03-07 A | 2008-09-12 | 15% | 115.6d? | 2008-03-07 | 2008-09-12 | 136d? | 335d | start no earlier than 2008-03-07 |  | R4 | 1088h | 163.2h | HNB-RF |  | Rel-8 | Stefania | TSG |  |  |  |
| 380 | 78.3 | UTRAN Architecture for 3G HNB | 141d? | 2008-05-30 | 2008-12-12 |  |  | 2008-05-30 | 2008-12-12 | 141d? | 270d | finish no earlier than 2008-12-12 |  | R3 | 1128h |  | HNB-arch |  | Rel-8 | Juergen |  |  |  |  |
| 381 | 79 | **LTE – Terminal Conformance Test Specifications** | 401d? | 2007-06-01 A | 2008-12-12 | 16% | 338.85d? | 2007-06-01 | 2008-12-12 | 401d? | 270d |  |  | R5 | 8192.02h | 1269.77h | LTE-UEConTest | NEC | Rel-8 | Ingbert |  | catherine.salinoc@nectech.fr |  |  |
| 382 | 79.1 | 3G Long Term Evolution – Terminal Protocol Conformance Test Specifications | 401d? | 2007-06-01 A | 2008-12-12 | 11% | 356.89d? | 2007-06-01 | 2008-12-12 | 401d? | 270d | finish no earlier than 2008-12-12 |  | R5 | 3208h | 352.88h | LTE-UEConTest_SIG | NEC, Motorola | Rel-8 | Ingbert |  | catherine.salinoc@nectech.fr, Jacob.John@motorola.com | 36.508, 36.523-1/2/3 |  |
| 383 | 79.2 | 3G Long Term Evolution – Terminal Radio Transmission and Reception Conformance Test Specifications | 401d? | 2007-06-01 A | 2008-12-12 | 20% | 320.8d? | 2007-06-01 | 2008-12-12 | 401d? | 270d | finish no earlier than 2008-12-12 |  | R5 | 3208h | 641.6h | LTE-UEConTest_RF | Agilent | Rel-8 | Ingbert |  | andrea_leonardi@agilent.com | 36.508, 36.521-1/2 |  |
| 384 | 80 | **Improvements of the Radio Interface - UE Conformance Testing** | 801d? | 2005-11-11 A | 2008-12-05 | 75% | 203.56d? | 2005-11-11 | 2008-12-05 | 801d? | 275d |  |  | R5 | 21816h | 16271.9h | RInImp-UEConTest | RAN5 |  | Ingbert |  |  |  |  |
| 385 | 16.5.1 | UE conformance testing for UMTS 2600 MHz | 146d | 2005-11-11 A | 2006-06-02 A | 100% |  | 2005-11-11 | 2006-06-02 | 146d |  | finish no earlier than 2006-06-02 | 2006-06-02 | R5 | 1168h | 1168h | RInImp-UMTS2600_Test | Nokia | Rel-7 | Ingbert |  | Aleksi Heino | 34.108, 34.121 | Fri 7/11/05 |
| 386 | 16.5.1 | UE Conformance Test for UMTS in 900 MHz band (band VIII) | 146d | 2005-11-11 A | 2006-06-02 A | 100% |  | 2005-11-11 | 2006-06-02 | 146d |  | finish no earlier than 2006-06-02 | 2006-06-02 | R5 | 1168h | 1168h | RInImp-UMTS900_Test | Qualcomm | Rel-7 | Ingbert |  | hanye@qualcomm.com | 34.108, 34.121 | Fri 11/03/05 |
| 387 | 80.3 | Conformance Test Aspects – Improved Performance of HSDPA Receiver type 3 | 191d? | 2006-03-10 A | 2006-12-01 A | 100% |  | 2006-03-10 | 2006-12-01 | 191d? |  | finish no earlier than 2006-12-01 |  | R5 | 1528h | 1528h | RInImp-HSPerf-Type3_Test | Motorola | Rel-7 | Ingbert |  | carolyn.taylor@motorola.com | 34.121, 34.108 |  |
| 388 | 80.4 | UE antenna Over The Air (OTA) conformance testing | 517d? | 2006-09-20 A | 2008-09-11 | 70% | 155.1d? | 2006-09-20 | 2008-09-11 | 517d? | 336d | finish no earlier than 2008-09-11 |  | R5 | 4136h | 2895.2h | RInImp-UEAnt_Test | Nokia | Rel-7 | Ingbert |  | Aleksi.Heino@nokia.com | 34.114 |  |
| 389 | 80.5 | UE conformance testing for FDD Inter-Band Operation | 131d? | 2006-06-02 A | 2006-12-01 A | 100% |  | 2006-06-02 | 2006-12-01 | 131d? |  | finish no earlier than 2006-12-01 |  | R5 | 1048h | 1048h | RInImp-InterBand_Test | NEC, Motorola | Rel-7 | Ingbert |  | Jacob.John@motorola.com | 34.108, 34.123-1, 34.123-2, 34.123-3 |  |
| 390 | 80.6 | Conformance Test Aspects – Extended UMTS 1.7/2.1 GHz | 131d? | 2006-12-01 A | 2007-06-01 A | 100% |  | 2006-12-01 | 2007-06-01 | 131d? |  | finish no earlier than 2007-06-01 |  | R5 | 1048h | 1048h | RInImp-UEConTest_UMTS1721Ext | Motorola | Rel-7 | Ingbert |  | carolyn.taylor@motorola.com | 34.108, 34.121-1, 34.121-2 |  |
| 391 | 80.7 | Conformance Test Aspects – Minimum UE performance requirement for downlink physical channels in support of E-DCH operation based on type 1 enhanced receiver (Rx-Diversity) | 136d? | 2007-06-01 A | 2007-12-07 A | 100% |  | 2007-06-01 | 2007-12-07 | 136d? |  | finish no earlier than 2007-12-07 |  | R5 | 1088h | 1088h | RInImp-UEConTest_RxDivEDCH | Motorola | Rel-7 | Ingbert |  | carolyn.taylor@motorola.com |  |  |
| 392 | 80.8 | Conformance Test Aspects – Minimum UE performance requirement for downlink physical channels in support of MTCGH and MCCH operation based on type 1 enhanced receiver (Rx-Diversity) | 201d? | 2007-06-01 A | 2008-03-07 A | 100% |  | 2007-06-01 | 2008-03-07 | 201d? |  | finish no earlier than 2008-03-07 |  | R5 | 1608h | 1608h | RInImp-UEConTest_RxDivMBMS | Ericsson | Rel-7 | Ingbert |  | leif.mattisson@ericsson.com |  |  |
| 393 | 80.9 | Conformance Test Aspects – CS Voice Service over HSPA | 336d? | 2007-06-01 A | 2008-09-12 | 30% | 235.2d? | 2007-06-01 | 2008-09-12 | 336d? | 335d | finish no earlier than 2008-09-12 |  | R5 | 2688h | 806.4h | RInImp8-CsHspa_UEConTest | Bao Yi (Huawei) | Rel-8 | Ingbert |  | baoyi@huawei.com | 34.108, 34.123-1, 34.123-2, 34.123-3 |  |
| 394 | 80.10 | Conformance Test Aspects – Performance requirements for 15 code reception with 16QAM/QPSK (FDD) | 136d? | 2008-05-30 | 2008-12-05 |  |  | 2008-05-30 | 2008-12-05 | 136d? | 275d | finish no earlier than 2008-12-05 |  | R5 | 1088h |  | RInImp8-UEConTest_ Hsdpa15codes |  | Rel-8 | Ingbert |  |  |  |  |
| 395 | 81 | **RAN improvements - UE Conformance Testing** | 713d? | 2006-09-20 A | 2009-06-12 | 61% | 275.44d? | 2006-09-20 | 2009-06-12 | 713d? | 140d |  |  | R5 | 25520h | 15661.3h | RANimp-UEConTest | RAN5 |  | Ingbert |  |  |  |  |
| 396 | 81.1 | Conformance Test Aspects - 3.84 Mcps and 7.68 Mcps TDD Enhanced Uplink | 518d? | 2006-09-20 A | 2008-09-12 | 55% | 233.1d? | 2006-09-20 | 2008-09-12 | 518d? | 335d | finish no earlier than 2008-09-12 |  | R5 | 4144h | 2279.2h | RANimp-UEConTest_EDCHTDH | IPWireless | Rel-7 | Ingbert |  | tspeight@ipwireless.com | 34.108, 34.122, 34.123-1, 34.123-2, 34.123-3 |  |
| 397 | 81.2 | Conformance Test Aspects – 64QAM for HSDPA (FDD) | 257d? | 2007-03-09 A | 2008-03-03 A | 100% |  | 2007-03-09 | 2008-03-03 | 257d? |  | finish no earlier than 2008-03-03 |  | R5 | 2056h | 2056h | RANimp-UEConTest_64QamDownlink | Ericsson | Rel-7 | Ingbert |  | leif.mattisson@ericsson.com | 34.108, 34.121-1, 34.121-2, 34.123-1, 34.123-2, 34.123-3 |  |
| 398 | 81.3 | Conformance Test Aspects – 16QAM for HSUPA (FDD) | 321d? | 2007-03-09 A | 2008-05-30 A | 100% |  | 2007-03-09 | 2008-05-30 | 321d? |  | finish no earlier than 2008-06-03 |  | R5 | 2568h | 2568h | RANimp-UEConTest_16QamUplink | Motorola | Rel-7 | Ingbert |  | carolyn.taylor@motorola.com | 34.108, 34.121-1, 34.121-2, 34.123-1, 34.123-2, 34.123-3 |  |
| 399 | 81.4 | Conformance Test Aspects – Improved L2 support for high data rates | 257d? | 2007-03-09 A | 2008-03-03 A | 100% |  | 2007-03-09 | 2008-03-03 | 257d? |  | finish no earlier than 2008-03-03 |  | R5 | 2056h | 2056h | RANimp-UEConTest_L2DataRates | Ericsson | Rel-7 | Ingbert |  | leif.mattisson@ericsson.com | 34.108, 34.123-1, 34.123-2, 34.123-3 |  |
| 400 | 81.5 | Conformance Test Aspects – Continuous connectivity for packet data users | 321d? | 2007-03-09 A | 2008-05-30 A | 100% |  | 2007-03-09 | 2008-05-30 | 321d? |  | finish no earlier than 2008-05-30 |  | R5 | 2568h | 2568h | RANimp-UEConTest_CPC | Nokia | Rel-7 | Ingbert |  | jarkko.hellsten@nokia.com | 34.108, 34.121-1, 34.121-2, 34.123-1, 34.123-2, 34.123-3 |  |
| 401 | 81.6 | Conformance Test Aspects – Enhanced CELL_FACH state in FDD | 396d? | 2007-03-09 A | 2008-09-12 | 20% | 316.8d? | 2007-03-09 | 2008-09-12 | 396d? | 335d | finish no earlier than 2008-09-12 |  | R5 | 3168h | 633.6h | RANimp–UEConTest_EnhancedCellFACHState | Nokia | Rel-7 | Ingbert |  | jarkko.hellsten@nokia.com | 34.108, 34.123-1, 34.123-2, 34.123-3 |  |
| 402 | 81.7 | Conformance Test Aspects – Improved L2 for uplink | 136d? | 2008-05-30 | 2008-12-05 |  |  | 2008-05-30 | 2008-12-05 | 136d? | 275d | finish no earlier than 2008-12-05 |  | R5 | 1088h |  | RANimp-UEConTest_UplinkL2dataRates |  | Rel-8 | Ingbert |  |  |  |  |
| 403 | 81.8 | Conformance Test Aspects – 64QAM for 1.28Mcps TDD HSDPA | 271d? | 2008-05-30 | 2009-06-12 |  |  | 2008-05-30 | 2009-06-12 | 271d? | 140d | finish no earlier than 2009-06-12 |  | R5 | 2168h |  | RANimp-UEConTest_64Qam1.28TDD |  | Rel-8 | Ingbert |  |  |  |  |
| 404 | 82 | 1.28Mcps TDD Enhanced Uplink - UE Conformance Testing | 257d? | 2007-09-19 | 2008-09-11 |  |  | 2007-09-19 | 2008-09-11 | 257d? | 336d | finish no earlier than 2008-09-11 |  | R5 | 624h |  | LCRTDD-EDCH-UEConTest | CATT | Rel-7 | Ingbert |  | chenxiaozhong@datangmobile.cn | 34.108, 34.122, 34.123-1/2/3 |  |
| 405 | 83 | Multimedia Telephony Service for IMS (MTSI) - UE Conformance Testing | 257d | 2007-09-19 | 2008-09-11 |  |  | 2007-09-19 | 2008-09-11 | 257d | 336d | finish no earlier than 2008-09-11 |  | R5 | 624h |  | MTSI-UEConfTest | CATT | Rel-7 | Ingbert |  | chenxiaozhong@datangmobile.cn | 34.108, 34.122, 34.123-1/2/3 |  |
| 406 | 84 | Network Selection Enhancements (NSP) - UE Conformance Testing | 396d? | 2007-06-01 A | 2008-12-05 | 30% | 277.2d? | 2007-06-01 | 2008-12-05 | 396d? | 275d | finish no earlier than 2008-12-05 |  | R5 | 3168h | 950.4h | NSP-CR_UEConTest | Nokia | Rel-7 | Ingbert |  | jarkko.hellsten@nokia.com | 34.108, 34.123-1, 34.123-2, 34.123-3 |  |
| 407 | 85 | Test - (Small) Technical Enhancements and Improvements for Rel-8 | 140d? | 2008-05-30 | 2008-12-11 |  |  | 2008-05-30 | 2008-12-11 | 140d? | 271d | start no earlier than 2008-05-30 |  | R5 | 1120h |  | TEI8_Test | ALL | Rel-8 | Ingbert |  |  |  |  |

Notes:
- 377: RAN#40 WID approved RP-080483
- 378: Status report in RP-080276, WID in RP-080483
- 379: Status report in RP-080277, WID RP-080234
- 380: WID in RP-080487
- 381: Testing for Feature UID_20068 (LTE).
- 382: Status Report in RP-080425
- 383: Status Report in RP-080259, updated WID in RP-080382
- 384: 05/08: Linked to Feature UID_20028 (RInImp)
- 388: Status report in RP-080279
- 393: Status Report in RP-080288, WID in RP-080160
- 394: WID in RP-080311, linked UID_370033
- 395: 05/08: Linked to Feature UID_20029 (RANimp)
- 396: Status report in RP-080280
- 398: RAN#40 completed. Status Report in RP-080281
- 400: RAN#40 completed. Status Report in RP-080282
- 401: Status Report in RP-080283
- 402: WID in RP-080310, linked UID_370036
- 403: WID in RP-080334, linked UID_380075
- 404: UID_350046->350146. 05/08: Linked to Feature UID_20055 (LCRTDD-EDCH). Status Report in RP-080285
- 405: UID_350047->350147. 05/08: Linked to Feature UID_7038 (MTSI). Status Report in RP-080284
- 406: 05/08: Linked to Feature UID_7041 (NSP-CR). Status Report in RP-080286, WID in RP-080135
- 407: Created on RAN5/JMM request

| ID | WBS | Task | Type | Duration | Start | Finish | Complete | Remaining | Baseline start | Baseline finish | Baseline duration | Total slack | Constraint | Resources | Work | Actual work | Text1 | Text8 | Text4 | Text6 | Text12 | Text7 |
| --- | --- | --- | --- | --- | --- | --- | --- | --- | --- | --- | --- | --- | --- | --- | --- | --- | --- | --- | --- | --- | --- | --- |
| 408 | 86 | **MBMS - UE Conformance Testing** |  | 596d? | 2007-06-01 A | 2009-09-11 | 9% | 540.94d? | 2007-06-01 | 2009-09-11 | 596d? | 75d |  | R5 | 12752h | 1178.08h | MBMSE_UEConTest | Ingbert |  |  |  |  |
| 409 | 86.1 | MBMS TDD Physical layer Enhancements – MBSFN for HCR and VHCR TDD – UE Conformance Test Aspects |  | 461d? | 2007-06-01 A | 2009-03-06 | 20% | 368.8d? | 2007-06-01 | 2009-03-06 | 461d? | 210d | start no earlier than 2007-06-01 | R5 | 3688h | 737.6h | MBMSE-RANPhysTDD_UEConTest | Ingbert | IPWireless | Rel-7 |  |  |
| 410 | 86.2 | UE conformance test aspects – MBMS LCR TDD Physical Layer Enhancement |  | 336d? | 2008-05-30 | 2009-09-11 |  |  | 2008-05-30 | 2009-09-11 | 336d? | 75d | finish no earlier than 2009-09-11 | R5 | 2688h |  | MBMSE-RANPhysLCRTDD_UEConTest | Ingbert |  | Rel-8 |  |  |
| 411 | 86.3 | Conformance Test Aspects – MBSFN for FDD |  | 201d? | 2008-05-30 | 2009-03-06 |  |  | 2008-05-30 | 2009-03-06 | 201d? | 210d | finish no earlier than 2009-03-06 | R5 | 1608h |  | MBMSE-UEConTest_RANPhysFDD | Ingbert |  | Rel-8 |  |  |
| 412 | 87 | MS Antenna Performance Evaluation Method and Requirements |  | 731d? | 2005-01-28 A | 2007-11-16 A | 100% |  | 2005-01-28 | 2007-11-16 | 731d? |  | finish no earlier than 2007-11-16 | GP | 5848h | 5848h | APEMR | Paolo | TeliaSonera | Rel-7 |  |  |
| 413 | 88 | GERAN support for GERAN - 3G Long Term Evolution interworking |  | 576d? | 2006-09-08 A | 2008-11-21 | 45% | 316.8d? | 2006-09-08 | 2008-11-21 | 576d? | 285d | finish no earlier than 2008-11-21 | GP | 4608h | 2073.6h | GELTE | Paolo | Nokia, NSN | Rel-8 |  |  |
| 414 | 89 | **GAN Enhancements** |  | 321d? | 2007-08-31 A | 2008-11-21 | 32% | 218.99d? | 2007-08-31 | 2008-11-21 | 321d? | 285d |  | GP | 6144h | 1952.47h | GANENH | Paolo | T-Mobile | Rel-8 |  |  |
| 415 | 89.1 | Update to GAN specifications |  | 126d? | 2007-08-31 A | 2008-02-22 A | 100% |  | 2007-08-31 | 2008-02-22 | 126d? |  | finish no earlier than 2008-02-22 | GP | 1008h | 1008h | GANENH-SPEC | Paolo | T-Mobile | Rel-8 |  |  |
| 416 | 89.2 | Update TS 51.010 Mobile Station (MS) Conformance Specification for GAN Enhancements |  | 321d? | 2007-08-31 A | 2008-11-21 | 5% | 304.95d? | 2007-08-31 | 2008-11-21 | 321d? | 285d | finish no earlier than 2008-11-21 | GP | 2568h | 128.4h | GANENH-MStest | Ingbert | T-Mobile | Rel-8 |  |  |
| 417 | 90 | **AoIP (A-interface over IP)** |  | 2334d? | 2000-01-03 A | 2008-12-11 | 43% | 1339.08d? | 2000-01-03 | 2008-12-11 | 2334d? | 271d |  | GP,C4,S4 | 40396.1h | 17279.3h | AoIP | Paolo | China Mobile, Ericsson | Rel-8 |  |  |
| 418 | 90.1 | GERAN aspects of AoIP |  | 2330d? | 2000-01-03 A | 2008-12-05 | 50% | 1165d? | 2000-01-03 | 2008-12-05 | 2330d? | 275d | finish no earlier than 2008-12-05 | GP | 18640h | 9320h | AoIP | Paolo | China Mobile, Ericsson | Rel-8 |  |  |
| 419 | 90.2 | Media Requirements for CS over IP based User Plane |  | 267d? | 2007-12-05 | 2008-12-11 |  |  | 2007-12-05 | 2008-12-11 | 267d? | 271d | finish no earlier than 2008-12-11 | S4 | 1996.1h |  | AoIP-CSoIP | Paolo | China Mobile, Ericsson | Rel-8 |  |  |
| 420 | 90.3 | Core Network Impacts for A-Interface User Plane over IP |  | 136d? | 2008-05-30 | 2008-12-05 |  |  | 2008-05-30 | 2008-12-05 | 136d? | 275d | start no earlier than 2008-05-30 | C4 | 1088h |  | AoIP-CN | Kimmo | Ericsson | Rel-8 |  |  |
| 421 | 91 | New multicarrier BTS class |  | 261d? | 2007-08-31 A | 2008-08-29 | 82% | 47.65d? | 2007-08-31 | 2008-08-29 | 261d? | 345d | finish no earlier than 2008-08-29 | G1 | 2088h | 1706.8h | MCBTS | Paolo | Alcatel-Lucent | Rel-8 |  |  |
| 422 | 92 | Support for Additional Navigation Satellite Systems (ANSS) for LCS |  | 136d? | 2008-05-16 | 2008-11-21 |  |  | 2008-05-16 | 2008-11-21 | 136d? | 285d | start no earlier than 2008-05-16 | G2 | 1088h |  | ANSS | Paolo | Qualcomm | Rel-8 |  |  |
| 423 | 93 | **A-GNSS Performances and Testing Procedures** |  | 341d? | 2008-05-16 | 2009-09-04 |  |  | 2008-05-16 | 2009-09-04 | 341d? | 80d |  | GP | 7544h |  | AGNSSPTP | Paolo | Thales | Rel-8 |  |  |
| 424 | 93.1 | A-GNSS Minimum Performances |  | 261d? | 2008-05-16 | 2009-05-15 |  |  | 2008-05-16 | 2009-05-15 | 261d? | 160d | start no earlier than 2008-05-16 | G1 | 2088h |  | AGNSSPTP- Perfreq | Paolo | Thales | Rel-8 |  |  |
| 425 | 93.2 | A-GNSS Testing Procedures |  | 341d? | 2008-05-16 | 2009-09-04 |  |  | 2008-05-16 | 2009-09-04 | 341d? | 80d | start no earlier than 2008-05-16 | G3new | 2728h |  | AGNSSPTP-MStest | Paolo | Thales | Rel-8 |  |  |
| 426 | 94 | **Conformance testing for the Latency Reductions feature** |  | 196d? | 2008-02-22 A | 2008-11-21 | 42% | 114.41d? | 2008-02-22 | 2008-11-21 | 196d? | 285d |  | G1, G3new | 4224h | 1758.3h | CTLATRED | Paolo | Ericsson | Rel-8 |  |  |
| 427 | 94.1 | MS conformance testing for the Latency Reductions feature |  | 196d? | 2008-02-22 A | 2008-11-21 | 15% | 166.6d? | 2008-02-22 | 2008-11-21 | 196d? | 285d | finish no earlier than 2008-11-21 | G3new | 1568h | 235.2h | CTLATRED-MStest | Ingbert | Ericsson | Rel-8 |  |  |
| 428 | 94.2 | BTS conformance testing for the Latency Reductions feature |  | 136d? | 2008-02-22 A | 2008-08-29 | 80% | 27.2d? | 2008-02-22 | 2008-08-29 | 136d? | 345d | finish no earlier than 2008-08-29 | G1 | 1088h | 870.4h | CTLATRED-BTStest | Paolo | Ericsson | Rel-8 |  |  |
| 429 | 95 | MS Conformance Tests of changes introduced by WI “Support of Packet-switched Handover for GERAN A/Gb mode” |  | 196d? | 2008-02-22 A | 2008-11-21 | 45% | 107.8d? | 2008-02-22 | 2008-11-21 | 196d? | 285d | finish no earlier than 2008-11-21 | G3new | 1568h | 705.6h | PSHCT-MStest | Ingbert | Rohde & Schwarz | Rel-8 |  |  |
| 430 | 96 | Mobile Station conformance testing of Support of Conversational Services in A/Gb mode via the PS domain |  | 321d? | 2008-02-22 | 2009-05-15 |  |  | 2008-02-22 | 2009-05-15 | 321d? | 160d | finish no earlier than 2009-05-15 | G3new | 2568h |  | SCSAGBCT-MStest | Ingbert | Nokia | Rel-8 |  |  |
| 431 | 97 | (Small) Technical Enhancements and Improvements for Rel-8 |  | 509d? | 2007-01-01 A | 2008-12-11 | 70% | 152.7d? | 2007-01-01 | 2008-12-11 | 509d? | 271d | finish no earlier than 2008-12-11 | All | 4072h | 2850.4h | TEI8 |  | ALL | Rel-8 |  |  |
| 432 | 98 | Deleted - was Rel7 - LCS for 3GPP Interworking WLAN | milestone | 0d? | 2007-09-28 A | 2007-09-28 A | 100% |  | 2007-09-28 | 2007-09-28 | 0d? |  | start no earlier than 2007-09-28 | S2 |  |  | LCS4_IWLAN | Maurice | LG Electronics | Rel-8 | SP-35 |  |
| 433 | 99 | Deleted - never approved- FBI Phase 2 | milestone | 0d | 2007-09-28 A | 2007-09-28 A | 100% |  | 2007-09-28 | 2007-09-28 | 0d |  | start no earlier than 2007-09-28 | S2 |  |  | FBI2 | Maurice | NSN | Rel-8 | SP-38 | TSG |
| 434 | 100 | Deleted -Enhancements to BS30 Bearer service for Videotelephony | milestone | 0d? | 2007-03-15 A | 2007-03-15 A | 100% |  | 2007-03-15 | 2007-03-15 | 0d? |  | finish no earlier than 2007-03-15 | S1 |  |  | BS30 | Alain |  | Rel-8 | SP-38 |  |
| 435 | 101 | Deleted - IMS Enhancements Rel-8 |  | 75d? | 2007-09-03 A | 2007-12-14 A | 100% |  | 2007-09-03 | 2007-12-14 | 75d? |  |  | S1 | 600h | 600h | IMS8 | Alain | Telecom Italia | Rel-8 | SP-38 |  |
| 436 | 102 | Deleted - U-TDOA Enhancement |  | 131d? | 2007-05-18 A | 2007-11-16 A | 100% |  | 2007-05-18 | 2007-11-16 | 131d? |  | finish no earlier than 2007-11-16 | GP | 1048h | 1048h | GUTEN | Paolo | TruePosition | Rel-7 | SP-39 |  |
| 437 | 103 | Feasibility Studies | milestone | 0d? | 2008-03-20 | 2008-03-20 |  |  | 2008-03-20 | 2008-03-20 | 0d? | 461d | finish no earlier than 2008-03-20 | CP,GP,RP,SP |  |  |  |  |  |  |  |  |
| 438 | 104 | Study on Facilitating Machine to Machine Communication in GSM and UMTS (M2M) |  | 350d? | 2005-11-04 A | 2007-03-08 A | 100% |  | 2005-11-04 | 2007-03-08 | 350d? |  | finish no earlier than 2006-06-16 | S1 | 2800h | 2800h | M2M | Alain | NSN | Rel-8 |  |  |
| 439 | 105 | Study on Network Composition |  | 526d? | 2005-12-07 A | 2007-12-12 A | 100% |  | 2005-12-07 | 2007-12-12 | 526d? |  | finish no earlier than 2006-09-27 | S1 | 4208h | 4208h | NetComp | Alain | NSN | Rel-8 |  |  |
| 440 | 106 | Study on Requirements of IMS Multimedia Conferencing |  | 330d? | 2006-06-08 A | 2007-09-12 A | 100% |  | 2006-06-08 | 2007-09-12 | 330d? |  | finish no earlier than 2007-03-21 | S1 | 2640h | 2640h | SI-IMSconf | Alain | China Mobile | Rel-8 |  |  |
| 441 | 107 | Study on Value Added Services for Short Message Service |  | 263d? | 2006-12-06 A | 2007-12-07 A | 100% |  | 2006-12-06 | 2007-12-07 | 263d? |  | finish no earlier than 2007-12-07 | S1 | 2104h | 2104h | FSVAS4SMS | Alain | China Mobile | Rel-8 |  |  |

Notes:
- 409: 05/08: Linked to Feature UID_31084 (MBMSE), BB UID_340043 (MBMSE-RANPhysTDD). Status Report in RP-080287, WID in RP-080155 / Text3: 34.108, 34.122, 34.123-1/2/3 / Text5: tspeight@ipwireless.com
- 410: WID in RP-080318, linked UID_xyz
- 411: WID in RP-080336, linked UID 4582
- 412: GP#36 completed for R7 / Text3: 25.914, 25.144, 45.005 / Text5: Ulf.Tegth@teliasonera.com
- 413: GP#31 WID approved / Text3: 24.008, 43.055, 43.129, 43.246, 44.018, 44.060, 45.002, 45.008, 45.010, 48.008, 48.018, 51.010 / Text5: sergio.parolari@nsn.com, vlora.rexhepi@nokia.com
- 414: GP#37 completed. Decouple Testing / Text3: 43.318, 44.318, 51.010 / Text5: mohammed.versi@t-mobile.com
- 415: GP#37 completed / Text3: 43.318, 44.318 / Text5: mohammed.versi@t-mobile.com
- 416: 08/08=>11/08. Decouple Testing / Text3: 51.010 / Text5: mohammed.versi@t-mobile.com
- 417: GP#38 updated WID GP-080404=>GP-080901. CT#40 WID approved / Text3: 48.001, 48.002, 48.008, 48.020, 49.008 / Text5: wangshuaiyu@chinamobile.com and paul.schliwa-bertling@ericsson.com
- 418: GP#38 updated WID GP-080404=>GP-080901 / Text3: 48.001, 48.002, 48.008, 48.020, 49.008 / Text5: wangshuaiyu@chinamobile.com and paul.schliwa-bertling@ericsson.com
- 419: SA#40 WID approved / Text3: 26.102, 26.202, 26.103 / Text5: Karl.Hellwig@Ericsson.com
- 420: CT#40 WID approved / Text3: 23.205, 23.153, 23.231, 23.009, 29.232, 29.002, 29.007 / Text5: Phil Hodges
- 421: 05/08=>08/08. / Text3: 45.005, 45.050, 51.021 / Text5: thomas.bitzer@alcatel-lucent.de
- 422: Testing de-coupled (completion 09/2009) / Text3: 43.059, 44.031, 49.031, 44.071, 48.031, 51.010 / Text5: Mungal Dhanda
- 423: GP#38 WID approved / Text3: 45.005, 51.010-1 / Text5: Michel.monnerat@thalesaleniaspace.com
- 424: GP#38 WID approved / Text3: 45.005 / Text5: Michel.monnerat@thalesaleniaspace.com
- 425: GP#38 WID approved / Text3: 51.010-1 / Text5: Michel.monnerat@thalesaleniaspace.com
- 426: Text3: 51.010, 51.021 / Text5: mats.y.samuelsson@ericsson.com and hakan.e.grunditz@ericsson.com
- 427: Text3: 51.010 / Text5: hakan.e.grunditz@ericsson.com
- 428: Text3: 51.021 / Text5: mats.y.samuelsson@ericsson.com
- 429: Text3: 51.010 / Text5: Franz.Segerer@ROHDE-SCHWARZ.COM
- 430: Text3: 51.010 / Text5: arsi.heino@nokia.com
- 432: SA#35 stopped / Text3: 23.234, 23.271, 23.167 / Text5: dhshim@lge.com
- 433: SA#38 stopped
- 434: SA#38 stopped (no support) / Text3: 22.002, 22.004, 22.101, 22.105, 24.008 / Text5: andre.jarvis@three.co.uk
- 435: SA#38 stopped
- 436: SA#39: Included in Rel7 / Text3: 43.059, 45.008, 48.071 / Text5: terri.brooks@trueposition.com
- 438: SA#35 completed. Spin-off SA3 SID UID_370053. SA#40 Spin-off new Feature UID_400033 (NIMTC) / Text3: 22.868
- 439: SA#38 completed / Text3: 22.980 / Text5: joerg.swetina@siemens.com
- 440: SA#37 completed. Spin-off New Feature UID_370026 (VAS4SM) / Text3: 22.948 / Text5: zhengjianping@chinamobile.com
- 441: SA#38 completed. Spin-off New Feature UID_370026 (VAS4SM) / Text3: 22.942 / Text5: wubin@chinamobile.com

| ID | WBS | Task | Duration | Start | Finish | Complete | Remaining | Baseline start | Baseline finish | Baseline duration | Total slack | Constraint | Resources | Work | Actual work | Text1 | Text3 | Text4 | Text5 | Text6 | Text8 | Text7 | Text12 |
| --- | --- | --- | --- | --- | --- | --- | --- | --- | --- | --- | --- | --- | --- | --- | --- | --- | --- | --- | --- | --- | --- | --- | --- |
| 442 | 108 | **Study on centralized IMS services** | 363d? | 2006-10-23 A | 2008-03-12 A | 100% |  | 2006-10-23 | 2008-03-12 | 363d? |  |  | S1,S2 | 5048h | 5048h | FSICS | 22.892, 23.892 | Ericsson | peter.bleckert@ericsson.com | Rel-8 | Alain |  |  |
| 443 | 108.1 | Study on centralized IMS services requirements | 268d? | 2007-03-05 A | 2008-03-12 A | 100% |  | 2007-03-05 | 2008-03-12 | 268d? |  | start no earlier than 2007-03-05 | S1 | 2144h | 2144h | FSICS-S1 | 22.892 | Ericsson | peter.bleckert@ericsson.com | Rel-8 | Alain |  |  |
| 444 | 108.2 | Study on centralized IMS services control | 363d? | 2006-10-23 A | 2008-03-12 A | 100% |  | 2006-10-23 | 2008-03-12 | 363d? |  | finish no earlier than 2008-02-21 | S2 | 2904h | 2904h | IMS_CSC | 23.892 | Alcatel-Lucent | andybennett@Alcatel-Lucent.com | Rel-8 | Maurice |  |  |
| 445 | 109 | Study on Paging Permission with Access Control | 256d? | 2006-09-28 A | 2007-09-20 A | 100% |  | 2006-09-28 | 2007-09-20 | 256d? |  | finish no earlier than 2007-09-20 | S1 | 2048h | 2048h | PPAC | 22.908 | NTT DoCoMo | noguchi@nttdocomo.co.jp | Rel-8 | Alain |  |  |
| 446 | 110 | Study on Non 3GPP access NSP | 392d? | 2006-12-06 A | 2008-06-05 A | 100% |  | 2006-12-06 | 2008-06-05 | 392d? |  | finish no earlier than 2007-11-19 | S1 | 3136h | 3136h | N3GtoNSP | 22.912 | Telefonica O2 | chris.friel@o2.com | Rel-8 | Alain |  |  |
| 447 | 111 | Study on Services Alignment and Migration | 331d? | 2006-12-06 A | 2008-03-12 A | 100% |  | 2006-12-06 | 2008-03-12 | 331d? |  | finish no earlier than 2007-09-20 | S1 | 2648h | 2648h | FSServAl | 22.983 | China Mobile | fenglingjuan@chinamobile.com | Rel-8 | Alain |  |  |
| 448 | 112 | Study on support of a Public Warning System | 140d? | 2007-09-03 A | 2008-03-14 A | 100% |  | 2007-09-03 | 2008-03-14 | 140d? |  |  | S1 | 1120h | 1120h | PWS-SI | 22.968 | T-Mobile | mark.younge@t-mobile.com | Rel-8 | Alain |  |  |
| 449 | 113 | **Study on enhanced voice service requirements for the EPS** | 464d? | 2007-09-03 A | 2009-06-11 | 18% | 381.2d? | 2007-09-03 | 2009-06-11 | 464d? | 141d |  | S1,S4 | 9576h | 1708.79h | FS_EV_EPS | 22.813 | Orange | tim.haysom@orange-ftgroup.com | Rel-9 | Alain |  |  |
| 450 | 113.1 | Use cases definition and service and system requirements | 269d? | 2007-09-03 A | 2008-09-11 | 40% | 161.4d? | 2007-09-03 | 2008-09-11 | 269d? | 336d | finish no earlier than 2008-09-11 | S1 | 2152h | 860.8h | FS_EV_EPS-S1 | 22.813 | Orange | tim.haysom@orange-ftgroup.com | Rel-9 | Alain |  |  |
| 451 | 113.2 | Codec specific part of FSEV_EPS | 464d? | 2007-09-03 A | 2009-06-11 | 5% | 440.8d? | 2007-09-03 | 2009-06-11 | 464d? | 141d | finish no earlier than 2009-06-11 | S4 | 3712h | 185.6h | FS_EV_EPS-S4 |  | Orange | tim.haysom@orange-ftgroup.com | Rel-9 | Paolo |  |  |
| 452 | 114 | Study on advanced requirements for IP interconnect | 78d? | 2007-12-04 | 2008-03-20 |  |  | 2007-12-04 | 2008-03-20 | 78d? | 461d | finish no earlier than 2008-03-20 | S1 | 624h |  | FS_IPXS | 22.893 | Telefonica O2 | chris.friel@O2.com | Rel-9 | Alain |  |  |
| 453 | 115 | Study on Service continuity between mobile and WLAN networks | 537d? | 2006-12-06 A | 2008-12-25 | 90% | 53.7d? | 2006-12-06 | 2008-12-25 | 537d? | 261d | finish no earlier than 2008-12-25 | S1 | 4296h | 3866.4h | FS_SMLSWLAN | 22.937 | BT | mike.meyerstein@bt.com | Rel-9 | Alain |  |  |
| 454 | 116 | Study on Service Specific Access Control in EPS | 201d? | 2008-06-05 | 2009-03-12 |  |  | 2008-06-05 | 2009-03-12 | 201d? | 206d | start no earlier than 2008-06-05 | S1 | 1608h |  | FS_SSAC_EPS | 22.8xy | NTT DoCoMo | Frederic Thepot (thepot@docomolab-euro.com) | Rel-9 | Alain |  |  |
| 455 | 117 | Study on Unauthenticated PS Emergency Calls | 201d? | 2008-06-05 | 2009-03-12 |  |  | 2008-06-05 | 2009-03-12 | 201d? | 206d | start no earlier than 2008-06-05 | S1 | 1608h |  | FS_UA_PS_eCall | 22.9XX | NSN | Juergen Merkel | Rel-9 | Alain |  |  |
| 456 | 118 | **Study on 3GPP System Architecture Evolution** | 1050d? | 2004-12-03 A | 2008-12-11 | 90% | 105d? | 2004-12-03 | 2008-12-11 | 1050d? | 271d |  | S2,S3 | 21736h | 19562.4h | FS_SAE | 23.882 | Vodafone |  | Rel-8 | Maurice | TSG |  |
| 457 | 118.1 | Stage 2 Interim conclusion for RAN Work to start | 915d? | 2004-12-03 A | 2008-06-05 | 90% | 91.5d? | 2004-12-03 | 2008-06-05 | 915d? | 406d | finish no earlier than 2005-09-23 | S2 | 7320h | 6588h | FS_SAE | 23.882 | Vodafone |  | Rel-8 | Maurice |  |  |
| 458 | 118.2 | Stage 2 study on 3GPP architectural development | 629d? | 2006-01-09 A | 2008-06-05 | 90% | 62.9d? | 2006-01-09 | 2008-06-05 | 629d? | 406d | finish no earlier than 2007-09-28 | S2 | 5032h | 4528.8h | FS_SAE | 23.882 | Vodafone | Chris Pudney | Rel-8 | Maurice |  |  |
| 459 | 118.3 | Security study for Inter-access mobility between non 3GPP and 3GPP system | 334d? | 2007-09-03 A | 2008-12-11 | 90% | 33.4d? | 2007-09-03 | 2008-12-11 | 334d? | 271d | finish no earlier than 2008-12-11 | S3 | 2672h | 2404.8h | FS_SAE | 33.821, 33.922 | Nokia | dajiang.zhang@nokia.com | Rel-8 | Dionisio |  |  |
| 460 | 119 | Study on Stage 2 aspects of IMS Service Brokering | 581d? | 2006-06-19 A | 2008-09-08 | 55% | 261.45d? | 2006-06-19 | 2008-09-08 | 581d? | 339d | finish no earlier than 2008-09-08 | S2 | 4648h | 2556.4h | ISB_ST2_SDY | 23.810 | Telcordia | raquel@research.telcordia.com | Rel-8 | Maurice |  |  |
| 461 | 120 | Study on VCC support for Emergency Calls | 657d? | 2006-06-08 A | 2008-12-12 | 35% | 427.05d? | 2006-06-08 | 2008-12-12 | 657d? | 270d | finish no earlier than 2008-12-12 | S2 | 5256h | 1839.6h | FSVCCEm | 23.826 | Nortel |  | Rel-8 | Maurice |  |  |
| 462 | 121 | Study on IMS utilizing multicast bearer services | 447d? | 2006-03-22 A | 2007-12-06 A | 100% |  | 2006-03-22 | 2007-12-06 | 447d? |  | finish no earlier than 2007-12-03 | S2 | 3576h | 3576h | FS-MLTICAST-IMS | 23.847 | NSN |  | Rel-8 | Maurice |  |  |
| 463 | 122 | Study of Mobility between 3GPP-WLAN Interworking and 3GPP Systems | 129d? | 2007-03-20 A | 2007-09-14 A | 100% |  | 2007-03-20 | 2007-09-14 | 129d? |  | start no earlier than 2007-03-20 | S2 | 1032h | 1032h | SM3GWLAN | 23.837 | Orange | orange | Rel-8 | Maurice |  |  |
| 464 | 123 | Study on Multimedia Session Continuity | 291d? | 2007-04-26 A | 2008-06-05 | 90% | 29.1d? | 2007-04-26 | 2008-06-05 | 291d? | 406d | finish no earlier than 2008-06-05 | S2 | 2328h | 2095.2h | MMSC_FS | 23.893 | LG Electronics |  | Rel-8 | Maurice |  |  |
| 465 | 124 | Study on CS Domain Services over EPS access | 359d? | 2007-04-25 A | 2008-09-08 | 70% | 107.7d? | 2007-04-25 | 2008-09-08 | 359d? | 339d | finish no earlier than 2008-09-08 | S2 | 2872h | 2010.4h | FS_CSoPS | 23.879 | T-Mobile | Sabine.Demel@T-Mobile.at | Rel-9 | Maurice |  |  |
| 466 | 125 | Study on Extended Support of IMS Emergency Calls | 320d? | 2007-09-24 A | 2008-12-12 | 15% | 272d? | 2007-09-24 | 2008-12-12 | 320d? | 270d | finish no earlier than 2008-12-12 | S2 | 2560h | 384h | FS_IMS-eCall | 23.868 | Qualcomm |  | Rel-9 | Maurice |  |  |
| 467 | 126 | Study on System enhancements for the use of IMS services in local breakout and optimal routing of media | 315d? | 2007-10-01 A | 2008-12-12 | 20% | 252d? | 2007-10-01 | 2008-12-12 | 315d? | 270d | finish no earlier than 2008-12-12 | S2 | 2520h | 504h | FS_IMS_LBO_ORM | 23.894 | Telecom Italia | mario.madella@telecomitalia.it, victor.kueh@bt.com | Rel-9 | Maurice |  |  |
| 468 | 127 | Study on Evaluation of LCS Control Plane Solution for EPS | 100d? | 2008-01-14 A | 2008-05-30 A | 100% |  | 2008-01-14 | 2008-05-30 | 100d? |  | finish no earlier than 2009-03-20 | S2 | 800h | 800h | FS_LCS_EPS | none | SiRF Technology |  | Rel-8 | Maurice |  |  |
| 469 | 128 | Study on Architecture of IMS based Customized Alerting Tone (CAT) | 200d? | 2007-12-04 A | 2008-09-08 | 70% | 60d? | 2007-12-04 | 2008-09-08 | 200d? | 339d | finish no earlier than 2008-09-08 | S2 | 1600h | 1120h | FS_CAT-St2 | 23.872 | China Mobile | wangjing@chinamobilecom | Rel-9 | Maurice |  |  |
| 470 | 129 | Study on Intra Domain Connection of RAN Nodes to Multiple CN Nodes | 262d? | 2008-03-12 | 2009-03-12 |  |  | 2008-03-12 | 2009-03-12 | 262d? | 206d | finish no earlier than 2009-03-12 | S2 | 2096h |  | FS_IDC | 23.8xy | China Mobile | LIU HONG (liuhongyfw@chinamobile.com) | Rel-9 | Maurice |  |  |
| 471 | 130 | Study on Protection against SMS and MMS spam | 657d? | 2006-06-08 A | 2008-12-12 | 30% | 459.9d? | 2006-06-08 | 2008-12-12 | 657d? | 270d | finish no earlier than 2008-12-12 | S3 | 5256h | 1576.8h | CPSMal | 33.9xx | Orange | eric.gauthier@orange.ch | Rel-8 | Dionisio |  |  |
| 472 | 131 | Study on Remote management of USIM application on M2M Equipment | 263d? | 2007-09-19 A | 2008-09-19 | 50% | 131.5d? | 2007-09-19 | 2008-09-19 | 263d? | 330d | finish no earlier than 2008-09-19 | S3 | 2104h | 1052h | FS_UM2M | 33.812 | Ericsson | vesa.lehtovirta@ericsson.com | Rel-9 | Dionisio |  |  |
| 473 | 132 | Study on UTRAN key management enhancements | 192d? | 2007-12-20 A | 2008-09-12 | 20% | 153.6d? | 2007-12-20 | 2008-09-12 | 192d? | 335d | finish no earlier than 2008-09-12 | S3 | 1536h | 307.2h | FS_UKM | TR | Ericsson |  | Rel-9 | Dionisio |  |  |
| 474 | 133 | Study on Home (e)NodeB Security | 192d? | 2007-12-20 A | 2008-09-12 | 30% | 134.4d? | 2007-12-20 | 2008-09-12 | 192d? | 335d | start no earlier than 2007-12-20 | S3 | 1536h | 460.8h | FS_HNB_Sec | TR | Huawei | yangyanmei@huawei.com | Rel-9 | Dionisio |  |  |
| 475 | 134 | Study on Transferring of emergency call data – in-band modem solution | 265d? | 2006-12-07 A | 2007-12-12 A | 100% |  | 2006-12-07 | 2007-12-12 | 265d? |  | finish no earlier than 2008-09-18 | S4 | 2120h | 2120h | eCALLIBMS | 26.967 | Airbiquity | lhong@airbiquity.com | Rel-8 | Paolo |  |  |
| 476 | 135 | Deleted OAM&P Rel-8 Studies | 742d? | 2006-05-10 A | 2009-03-12 A | 100% |  | 2006-05-10 | 2009-03-12 | 742d? |  |  | S5 | 3425.6h | 3425.6h | OAM8-Studies |  |  |  | Rel-8 | Dionisio |  | SP-39 |
| 477 | 136 | Study of Element Operations Systems Function (EOSF) definition | 266d? | 2007-06-07 A | 2008-06-12 A | 100% |  | 2007-06-07 | 2008-06-12 | 266d? |  | finish no earlier than 2008-12-11 | S5 | 2128h | 2128h | OAM8-Studies | 32.819 | China Mobile |  | Rel-8 | Dionisio |  |  |
| 478 | 137 | Deleted Study of Element Operations Systems Function (EOSF) definition | 396d? | 2007-06-07 A | 2008-12-11 A | 100% |  | 2007-06-07 | 2008-12-11 | 396d? |  | finish no earlier than 2008-12-11 | S5 | 3168h | 3168h | OAM7-NIM- EOSF | 32.819 | China Mobile |  | Rel-7 | Dionisio |  | SP-36 |
| 479 | 138 | Delete Study on SA5 MTOSI XML Harmonization | 351d? | 2006-05-10 A | 2007-09-12 A | 100% |  | 2006-05-10 | 2007-09-12 | 351d? |  | finish no earlier than 2007-12-14 | S5 | 2808h | 2808h | OAM7-NIM-XML | 32.818 | Nortel |  | Rel-7 | Dionisio |  | SP-36 |
| 480 | 139 | Study on SA5 MTOSI XML Harmonization | 351d? | 2006-05-10 A | 2007-09-12 A | 100% |  | 2006-05-10 | 2007-09-12 | 351d? |  | finish no earlier than 2007-12-14 | S5 | 2808h | 2808h | OAM8-Studies | 32.818 | Nortel |  | Rel-8 | Dionisio |  |  |
| 481 | 140 | Delete Study of Common Profile Storage (CPS) Framework of User Data for network services and management | 244d? | 2006-07-03 A | 2007-06-07 A | 100% |  | 2006-07-03 | 2007-06-07 | 244d? |  | finish no earlier than 2007-06-07 | S5 | 1952h | 1952h | OAM7-CPS | 32.808 | T-Mobile |  | Rel-8 | Dionisio |  | SP-36 |
| 482 | 141 | Study of Common Profile Storage (CPS) Framework of User Data for network services and management | 244d? | 2006-07-03 A | 2007-06-07 A | 100% |  | 2006-07-03 | 2007-06-07 | 244d? |  | finish no earlier than 2007-06-07 | S5 | 1952h | 1952h | OAM8-Studies | 32.808 | T-Mobile |  | Rel-8 | Dionisio |  |  |
| 483 | 142 | Study of Management for LTE and SAE | 526d? | 2006-12-07 A | 2008-12-11 | 90% | 52.6d? | 2006-12-07 | 2008-12-11 | 526d? | 271d | finish no earlier than 2008-12-11 | S5 | 4208h | 3787.2h | OAM8-Studies | 32.816 | Ericsson |  | Rel-8 | Dionisio |  |  |
| 484 | 143 | Study on Charging Aspects of 3GPP System Evolution | 179d? | 2007-04-02 A | 2007-12-06 A | 100% |  | 2007-04-02 | 2007-12-06 | 179d? |  | finish no earlier than 2007-12-06 | S5 | 1432h | 1432h | FSSAEcharg | 32.820 | NSN |  | Rel-8 | Dionisio |  |  |
| 485 | 144 | Study of System Maintenance over Itf-N | 396d? | 2007-06-07 A | 2008-12-11 | 60% | 158.4d? | 2007-06-07 | 2008-12-11 | 396d? | 271d | finish no earlier than 2008-12-11 | S5 | 3168h | 1900.8h | OAM8-Studies | 32.822 | ZTE |  | Rel-8 | Dionisio |  |  |
| 486 | 145 | Study of Self-Organizing Networks (SON) related OAM interfaces for Home NodeB | 396d? | 2007-06-07 A | 2008-12-11 | 40% | 237.6d? | 2007-06-07 | 2008-12-11 | 396d? | 271d | finish no earlier than 2008-12-11 | S5 | 3168h | 1267.2h | OAM8-Studies | 32.821 | Huawei |  | Rel-8 | Dionisio |  |  |
| 487 | 146 | Study on Self-healing of Self-Organizing Networks (SON) | 275d? | 2008-02-22 A | 2009-03-12 | 10% | 247.5d? | 2008-02-22 | 2009-03-12 | 275d? | 206d | finish no earlier than 2009-03-12 | S5 | 2200h | 220h | OAM8-Studies | 32.823 | ZTE |  | Rel-8 | Dionisio |  |  |
| 488 | 147 | Study on Service Oriented Architecture (SOA) for IRP | 201d? | 2008-06-05 | 2009-03-12 |  |  | 2008-06-05 | 2009-03-12 | 201d? | 206d | finish no earlier than 2009-03-12 | S5 | 1608h |  | FS_OAM_SOA_IRP | 32.824 | Ericsson | edwin.tse@ericsson.com | Rel-9 | Dionisio |  |  |
| 489 | 148 | Study on AS-MRFC media server control protocol | 583d? | 2006-03-22 A | 2008-06-13 A | 100% |  | 2006-03-22 | 2008-06-13 | 583d? |  | finish no earlier than 2008-06-13 | C1 | 4664h | 4664h | MRFC | 24.880 | HP | mark.syrett@hp.com | Rel-8 | Andrijana |  |  |
| 490 | 149 | Study on Restoration Procedures | 310d? | 2007-03-26 A | 2008-05-30 A | 100% |  | 2007-03-26 | 2008-05-30 | 310d? |  | finish no earlier than 2008-05-30 | C4 | 2480h | 2480h | FS_IMS_RP | 23.820 | Ericsson | german.blanco@ericsson.com | Rel-8 | Kimmo |  |  |
| 491 | 150 | Study on IMS Application Server Service Data Descriptions for AS interoperability | 261d? | 2007-09-14 A | 2008-09-12 | 70% | 78.3d? | 2007-09-14 | 2008-09-12 | 261d? | 335d | finish no earlier than 2008-09-12 | C4 | 2088h | 1461.6h | FS_IMS_ASIO | 29.864 | ALU | nhberry@ALCATEL-LUCENT.COM | Rel-8 | Kimmo |  |  |
| 492 | 151 | Study on Customized Alerting Tone (CAT) solution for voice and video call in CS domain | 261d? | 2007-09-14 A | 2008-09-12 | 60% | 104.4d? | 2007-09-14 | 2008-09-12 | 261d? | 335d |  | C4 | 626.4h |  | FS_CAT_VVC_CS | 29.882 | China Mobile | zhanghao@chinamobile.com | Rel-8 | Kimmo |  |  |
| 493 | 152 | Study on InterWorking Function between MAP based and Diameter based interfaces | 206d? | 2007-11-30 A | 2008-09-12 | 60% | 82.4d? | 2007-11-30 | 2008-09-12 | 206d? | 335d | finish no earlier than 2008-09-12 | C4 | 1648h | 988.8h | FS_MAP2Diam | 29.805 | Huawei | liming49985@HUAWEI.COM | Rel-8 | Kimmo |  |  |
| 494 | 153 | Study on Scope of future HSPA Evolution for 1.28Mcps TDD | 186d? | 2007-09-14 A | 2008-05-30 A | 100% |  | 2007-09-14 | 2008-05-30 | 186d? |  | finish no earlier than 2008-05-30 | R1 | 1488h | 1488h | FS_RAN-LCRTDDHSPAEvo | 25.824 | RITT |  | Rel-8 | Patrick |  |  |
| 495 | 154 | Study on Synchronized E-DCH for UTRA FDD | 126d? | 2007-09-14 A | 2008-03-07 A | 100% |  | 2007-09-14 | 2008-03-07 | 126d? |  | finish no earlier than 2008-03-14 | R1 | 1008h | 1008h | FS_RAN-UplinkSync | 25.823 | NSN | Karri.Ranta-aho@nsn.com | Rel-8 | Patrick |  |  |
| 496 | 155 | Study on LTE-Advanced | 326d? | 2008-03-07 A | 2009-09-11 | 80% | 65.2d? | 2008-03-07 | 2009-09-11 | 326d? | 75d | finish no earlier than 2009-09-11 | R1 | 2608h | 2086.4h | FS_RAN_LTEA | 36.913 | ALU |  | Rel-9 | Patrick |  |  |
| 497 | 156 | Study on Dual-Cell HSDPA operation | 196d? | 2008-03-07 A | 2008-12-05 | 75% | 49d? | 2008-03-07 | 2008-12-05 | 196d? | 275d | finish no earlier than 2008-12-05 | R1,R4 | 1568h | 1176h | FS_RAN-DCHS | 25.9xx | ALU |  | Rel-8 | Patrick |  |  |
| 498 | 157 | Study on Improved network controlled mobility between LTE and 3GPP2/mobile WiMAX radio technologies | 131d? | 2007-06-04 A | 2007-12-03 A | 100% |  | 2007-06-04 | 2007-12-03 | 131d? |  | finish no earlier than 2007-12-03 | R2 | 1048h | 1048h | FS_RAN-LTEmob | 36.938 | Motorola | hao.bi@Motorola.com | Rel-8 | Joern |  |  |
| 499 | 158 | Study on 3G Home NodeB/eNodeB | 325d? | 2007-03-05 A | 2008-05-30 A | 100% |  | 2007-03-05 | 2008-05-30 | 325d? |  | finish no earlier than 2008-05-30 | R4 | 2600h | 2600h | FS_RAN-HNBeNB | 25.820 | Motorola |  | Rel-8 | Stefania |  |  |
| 500 | 159 | Study on Evaluation of the inclusion of Path Loss Based Technology in the UTRAN | 195d? | 2007-12-17 A | 2008-09-12 | 10% | 175.5d? | 2007-12-17 | 2008-09-12 | 195d? | 335d | start no earlier than 2007-12-17 | R4 | 1560h | 156h | FS_RAN-Pathloss | 25.9xx | Polaris Wireless |  | Rel-8 | Stefania |  |  |
| 501 | 160 | Study on HS-PDSCH serving cell change enhancements | 60d? | 2007-12-17 A | 2008-03-07 A | 100% |  | 2007-12-17 | 2008-03-07 | 60d? |  | finish no earlier than 2008-06-12 | R4 | 480h | 480h | FS_RAN-HSPDSCH | none | Qualcomm |  | Rel-8 | Stefania |  |  |
| 502 | 161 | Study on A-interface over IP | 126d? | 2007-08-31 A | 2008-02-22 A | 100% |  | 2007-08-31 | 2008-02-22 | 126d? |  | finish no earlier than 2008-02-22 | GP | 1008h | 1008h | AINTIP | 43.903 | China Mobile, Ericsson | paul.schliwa-bertling@ericsson.com | Rel-8 | Paolo |  |  |
| 503 | 162 | Study on Multi-User Reusing-One-Slot | 206d? | 2007-11-16 A | 2008-08-29 | 38% | 127.6d? | 2007-11-16 | 2008-08-29 | 206d? | 345d | finish no earlier than 2008-08-29 | GP | 1648h | 627.2h | MUROS | TR | NSN | juergen.hofmann@nsn.com | Rel-8 | Paolo |  |  |
| 504 | 163 | Study on Optimized Transmit Pulse Shape for Downlink EGPRS2-B | 266d? | 2007-11-16 A | 2008-11-21 | 20% | 212.8d? | 2007-11-16 | 2008-11-21 | 266d? | 285d | finish no earlier than 2008-11-21 | G1 | 2128h | 425.6h | WIDER | 45.9xx | RIM, NSN | jdwyer@RIM.COM and eddie.riddington@nsn.com | Rel-8 | Paolo |  |  |
| 505 | 164 | Deleted - equals 340035 -FS on Service continuity between mobile and WLAN networks | 75d? | 2007-09-03 A | 2007-12-14 A | 100% |  | 2007-09-03 | 2007-12-14 | 75d? |  | finish no earlier than 2007-12-14 | S1 | 600h | 600h | FSSCMobToW | 22.937 | BT | mike.meyerstein@bt.com | Rel-8 | Alain |  | SP-39 |
| 506 | 165 | Deleted - Study on GAN Enhancements | 206d? | 2006-11-17 A | 2007-08-31 A | 100% |  | 2006-11-17 | 2007-08-31 | 206d? |  | start no earlier than 2006-11-17 | GP | 1648h | 1648h | EGAN | 43.902 | T-Mobile | janne.linkola@t-mobile.com | Rel-7 | Paolo |  | SP-37 |

Notes:
- 442: SA#39 completed
- 443: SA#39 completed
- 444: SA#39 completed
- 445: SA#37 completed. Spin-off new Feature UID_370084 (PPACR)
- 446: SA#38 completed. Spin-off New Feature UID_380062 (N3GTONSP). SA#40 WID updated SP-060930=>SP-080318. TR re-approved with new # 22.812=>22.912
- 447: SA#39 completed. Spin-off Feature UID_330017 (ServAl)
- 448: SA#39 completed. Spin-off Rel-9 Feature UID_380057 (PWS)
- 449: Moved to Rel9
- 450: Moved to Re-9. SA#40 03/08=>09/08
- 451: Moved to Rel9
- 452: SA#38 SID approved.
- 453: Moved to Rel-9
- 454: SA#40 SID approved.
- 455: SA#40 SID approved.
- 456: Moved from Rel-7
- 457: TR 23.882 is 100% complete, but technically out-of-date. SA2 to submit for SA#40 Approval with disclaimer text.
- 458: TR 23.882 is 100% complete, but technically out-of-date. SA2 to submit for SA#40 Approval with disclaimer text.
- 459: Moved from Rel-7
- 460: SA#32 SID approved
- 462: SA#38 completed
- 463: SA#37 completed
- 464: SA#38 TR for information
- 465: Moved to Rel-9
- 466: Moved to Rel-9
- 467: SA#39 Revised SID approved. Moved to Rel-9
- 468: SA#38 SID approved. SA#40 spin-off Feature UID_400038 (LCS_CPS_EPS)
- 470: SA#39: SID approved. Linked to 23.236
- 471: Mechanisms to define spam messages still being evaluated. No progress
- 472: Triggered by SA1 Study UID_7029 (M2M) TR 22.868. SA#37: WID SP-070635=>SP-070702
- 475: SA#38 completed. Spin-off WID UID_34042 (eCall_Phase2)
- 476: Created to encompass the Rel7 FSs shifted to Re-8. Set SA5 FSs in-line (1) with the others
- 477: SA#40 completed
- 478: Moved from Rel-7
- 479: Moved from Rel-7
- 480: SA#37 completed
- 481: Moved from Rel-7
- 482: SA#36 completed. Spin-off New Feature UID_400034 (UDC)
- 483: Slow progress
- 484: SA#38 completed
- 485: Slow progress
- 486: No progress
- 487: SA#39 SID approved
- 488: SA#40 SID approved
- 489: CT#40 completed. Spin-off New Feature UID_380035 (MRFC_TS)
- 490: CT#40 completed. Spin-off WID UID_400000 (IMS_RP)
- 491: Target May 08 => Sep 08
- 492: CT#37 WID approved
- 494: RAN#40 completed. Status Report in 080290
- 495: RAN#39 completed. Status Report in RP-080068
- 496: Status Report in RP-080293, SID in RP-080137. RAN#40 TR approved ?! Target completion Sep 2009
- 497: Status Report in RP-080292, SID in RP-080228, SI is on hold, new WI approved in RP-080490
- 498: Status Report in RP-070827. RAN#38 completed
- 499: RAN#40 completed. Status Report in RP-080289
- 500: Status Report in RP-080291, SID in RP-080069
- 501: RAN#39 completed. SID in RP-080070. New WID in RP-080227.
- 502: GP#37 completed
- 504: 08/08=>11/08.
- 505: SA#39 stopped
- 506: SA#37 Included in Rel7

| ID | WBS | Task | Duration | Start | Finish | Complete | Remaining | Baseline start | Baseline finish | Baseline duration | Total slack | Constraint | Resources | Work | Actual work | Text1 | Text4 | Text5 | Text6 | Text7 | Text8 | Text12 |
| --- | --- | --- | --- | --- | --- | --- | --- | --- | --- | --- | --- | --- | --- | --- | --- | --- | --- | --- | --- | --- | --- | --- |
| 507 | 166 | **Deleted - Study on All-IP Network** | 448d? | 2004-06-28 A | 2006-03-15 A | 100% |  | 2004-06-28 | 2006-03-15 | 448d? |  |  | S1 | 8672h | 8672h | AIPN | NTT DoCoMo | c.masyu@nttdocomo.co.jp | Rel-8 | TSG | Alain | SP-38 |
| 508 | 166.1 | Deleted - All-IP Network Feasibility Study | 188d? | 2004-06-28 A | 2005-03-16 A | 100% |  | 2004-06-28 | 2005-03-16 | 188d? |  | start no earlier than 2004-06-28 | S1 | 1504h | 1504h | AIPFS | NTT DoCoMo | c.masyu@nttdocomo.co.jp | Rel-8 | TSG | Alain | SP-27 |
| 509 | 166.2 | Deleted - draft Stage 1 | 448d? | 2004-06-28 A | 2006-03-15 A | 100% |  | 2004-06-28 | 2006-03-15 | 448d? |  | finish no earlier than 2006-03-15 | S1 | 3584h | 3584h | AIPN | NTT DoCoMo | c.masyu@nttdocomo.co.jp | Rel-8 | TSG | Alain | SP-38 |
| 510 | 167 | GERAN3new Rel-7 Testing | 1d? | 2000-01-03 | 2000-01-03 |  |  | 2000-01-03 | 2000-01-03 | 1d? | 2604d |  | G3new | 8h |  |  |  |  | Rel-7 |  |  |  |
| 511 | 168 | **Downlink Dual Carrier** | 741d? | 2006-01-20 A | 2008-11-21 | 54% | 340.78d? | 2006-01-20 | 2008-11-21 | 741d? | 285d |  | GP | 16140.8h | 9120.93h | GDCDL | Leonardo Provvedi, Nokia Siemens Networks | leonardo.provvedi@roke.co.uk | Rel-7 |  | Paolo |  |
| 512 | 168.1 | Downlink Dual Carrier Stage 2 | 116d? | 2006-01-20 A | 2006-06-30 A | 100% |  | 2006-01-20 | 2006-06-30 | 116d? |  | finish no earlier than 2006-06-30 | G1 | 928h | 928h | GDCDL-Stage2 | Leonardo Provvedi, Nokia Siemens Networks | leonardo.provvedi@roke.co.uk | Rel-7 |  | Paolo |  |
| 513 | 168.2 | Downlink Dual Carrier Stage 3 | 421d? | 2006-01-20 A | 2007-08-31 A | 100% |  | 2006-01-20 | 2007-08-31 | 421d? |  | finish no earlier than 2007-08-31 | G2; G1 | 4244.8h | 4244.8h | GDCDL-Stage3 | Leonardo Provvedi, Nokia Siemens Networks | leonardo.provvedi@roke.co.uk | Rel-7 |  | Paolo |  |
| 514 | 168.3 | Downlink Dual Carrier – MS Conformance Test | 630d? | 2006-01-20 A | 2008-11-21 | 15% | 536.7d? | 2006-01-20 | 2008-11-21 | 630d? | 285d | finish no earlier than 2008-11-21 | G3new | 5040h | 746.4h | GDCDL-MStest | Leonardo Provvedi, Nokia Siemens Networks | leonardo.provvedi@roke.co.uk | Rel-7 |  | Ingbert |  |
| 515 | 169 | **Higher Uplink performance for GERAN Evolution** | 646d? | 2006-09-08 A | 2009-02-27 | 64% | 234.58d? | 2006-09-08 | 2009-02-27 | 646d? | 215d |  | GP | 26128h | 13499.4h | HUGE | NSN, Ericsson) | eddie.riddington@nokia.com, stefan.g.eriksson@ericsson.com | Rel-7 |  | Paolo |  |
| 516 | 169.1 | Stage 2 of HUGE | 261d? | 2006-09-08 A | 2007-09-07 A | 100% |  | 2006-09-08 | 2007-09-07 | 261d? |  | finish no earlier than 2007-09-07 | G1 | 2088h | 2088h | HUGE-Stage2 | NSN, Ericsson) | eddie.riddington@nokia.com, stefan.g.eriksson@ericsson.com | Rel-7 |  | Paolo |  |
| 517 | 169.2 | Layer 1 Support of HUGE | 381d? | 2006-09-08 A | 2008-02-22 A | 100% |  | 2006-09-08 | 2008-02-22 | 381d? |  | finish no earlier than 2008-02-22 | G1 | 3048h | 3048h | HUGE-Layer1 | NSN, Ericsson) | eddie.riddington@nokia.com, stefan.g.eriksson@ericsson.com | Rel-7 |  | Paolo |  |
| 518 | 169.3 | Layer 2/3 Support of HUGE | 256d? | 2006-09-08 A | 2007-08-31 A | 100% |  | 2006-09-08 | 2007-08-31 | 256d? |  | finish no earlier than 2007-08-31 | G2 | 2048h | 2048h | HUGE-Layer23 | NSN, Ericsson) | eddie.riddington@nokia.com, stefan.g.eriksson@ericsson.com | Rel-7 |  | Gert |  |
| 519 | 169.4 | Performance requirements | 500d? | 2006-09-08 A | 2008-08-08 | 85% | 75d? | 2006-09-08 | 2008-08-08 | 500d? | 361d | finish no earlier than 2008-08-08 | G1 | 4000h | 3400h | HUGE-Perfreq | NSN, Ericsson) | eddie.riddington@nokia.com, stefan.g.eriksson@ericsson.com | Rel-7 |  | Paolo |  |
| 520 | 169.5 | MS Conformance Test | 646d? | 2006-09-08 | 2009-02-27 |  |  | 2006-09-08 | 2009-02-27 | 646d? | 215d | finish no earlier than 2009-02-27 | G3new | 5168h |  | HUGE-Mstest | NSN, Ericsson) | eddie.riddington@nokia.com, stefan.g.eriksson@ericsson.com | Rel-7 |  | Ingbert |  |
| 521 | 169.6 | BTS Conformance Test | 576d? | 2006-09-08 A | 2008-11-21 | 60% | 230.4d? | 2006-09-08 | 2008-11-21 | 576d? | 285d | finish no earlier than 2008-11-21 | G1 | 4608h | 2764.8h | HUGE-BTStest | NSN, Ericsson) | eddie.riddington@nokia.com, stefan.g.eriksson@ericsson.com | Rel-7 |  | Paolo |  |
| 522 | 170 | **REduced symbol Duration, Higher Order modulation and Turbo coding (RED HOT) for downlink** | 596d? | 2006-11-17 A | 2009-02-27 | 53% | 279.59d? | 2006-11-17 | 2009-02-27 | 596d? | 215d |  | GP | 18520h | 7356.27h | REDHOT | Ericsson, NSN, Marvell | stefan.g.eriksson@ericsson.com | Rel-7 |  | Paolo |  |
| 523 | 170.1 | Stage 2 for REDHOT | 206d? | 2006-11-17 A | 2007-08-31 A | 100% |  | 2006-11-17 | 2007-08-31 | 206d? |  | finish no earlier than 2007-08-31 | G1 | 1648h | 1648h | REDHOT-Stage2 | Ericsson, NSN, Marvell | stefan.g.eriksson@ericsson.com | Rel-7 |  | Paolo |  |
| 524 | 170.2 | Stage 3 for REDHOT | 391d? | 2006-11-17 A | 2008-05-16 A | 100% |  | 2006-11-17 | 2008-05-16 | 391d? |  | finish no earlier than 2008-05-16 | G1 | 3128h | 3128h | REDHOT-Stage3 | Ericsson, NSN, Marvell | stefan.g.eriksson@ericsson.com | Rel-7 |  | Paolo |  |
| 525 | 170.3 | MS Conformance Tests | 596d? | 2006-11-17 | 2009-02-27 |  |  | 2006-11-17 | 2009-02-27 | 596d? | 215d | finish no earlier than 2009-02-27 | G3new | 4768h |  | REDHOT-Mstest | Ericsson | stefan.g.eriksson@ericsson.com | Rel-7 |  | Ingbert |  |
| 526 | 170.4 | BTS Conformance Tests | 526d? | 2006-11-17 A | 2008-11-21 | 60% | 210.4d? | 2006-11-17 | 2008-11-21 | 526d? | 285d | finish no earlier than 2008-11-21 | G1 | 4208h | 2524.8h | REDHOT-BTStest | Ericsson, NSN, Marvell | stefan.g.eriksson@ericsson.com | Rel-7 |  | Paolo |  |

Notes:
- 507: SA#38 stopped / Text3: 22.978
- 508: SA#27 stopped / Text3: 22.978
- 509: 22.258 withdrawn, superseded by 22.278 (UID 320022). SA#38 stopped / Text3: 22.258
- 511: GP#37 completed. Decouple Testing / Text3: 24.008, 43.055, 43.064, 44.018, 44.060, 45.001, 45.002, 45.005, 45.008, 51.010
- 512: GP#30 completed / Text3: 43.055, 43.064
- 513: GP#35 completed / Text3: 24.008, 44.018, 44.060, 45.001, 45.002, 45.005, 45.008
- 514: Decouple Testing / Text3: 51.010
- 515: GP#37 98% complete. Decouple Testing / Text3: 24.008, 43.055, 43.064, 44.018, 44.060, 45.001, 45.002, 45.003, 45.004, 45.005, 45.008, 45.010, 51.010, 51.021
- 516: GP#35 completed / Text3: 43.055, 43.064
- 517: GP#37 completed / Text3: 45.001, 45.002, 45.003, 45.004, 45.008
- 518: GP#35 completed / Text3: 24.008, 44.018, 44.060
- 519: 05/08=>08/08. Decouple Testing / Text3: 45.005
- 520: 05/08=>02/09. Decouple Testing / Text3: 51.010
- 521: 05/08=>11/08. Decouple Testing / Text3: 51.021
- 522: GP#38 completed. Decouple Testing / Text3: 24.008, 43.064, 43.055, 44.018, 44.060, 45.001, 45.002, 45.003, 45.004, 45.005, 45.008, 51.010, 51.021
- 523: GP#35 completed / Text3: 43.055, 43.064
- 524: GP#38 completed / Text3: 24.008, 44.018, 44.060, 45.001, 45.002, 45.003, 45.004, 45.005, 45.008
- 525: 08/08=>02/09. Decouple Testing / Text3: 51.010
- 526: 05/08=>11/08. Decouple Testing / Text3: 51.021
